# Imager_and_IFS_PD_Phase_v1_2_tracked_Jan10

Schedule from MS Project, 2009-05-01 to 2011-01-17, costs in $, A marks actual dates.
CARA

## Calendars

- Standard: Mon-Fri 08:00-12:00, 13:00-17:00; Sat-Sun off.

## Resources

| Resource | Group | Rate |
| --- | --- | --- |
| Sean Adkins | WMKO | 87 |
| Instrument Scientist | UCLA |  |
| Science Team |  |  |
| ME - Jim Bell | WMKO | 60 |
| ME - TBD | UCLA | 60 |
| Electronics Engineer | UCLA | 60 |
| Software Engineer | TBD | 60 |
| OE - Optical Engineer 2 |  | 70 |
| WMKO Support Astronomer | WMKO | 57 |
| WMKO Software Staff | WMKO | 57 |
| WMKO Instrument Staff | WMKO | 57 |
| WMKO Electronics Staff | WMKO | 57 |
| ME - Bob Weber | CIT | 60 |
| OE - Sergey Panteleev |  | 70 |

## Schedule

| ID | WBS | Task | Type | Duration | Start | Finish | Predecessors | Complete | Remaining | Total slack | Constraint | Resources | Work | Actual work | Cost | Actual cost | Text1 |
| --- | --- | --- | --- | --- | --- | --- | --- | --- | --- | --- | --- | --- | --- | --- | --- | --- | --- |
| 1 | 0 | **Milestones** |  | 291.26d? | 2009-05-01 A | 2010-06-14 |  |  | 291.26d? | 155.67d |  |  |  |  |  |  |  |
| 2 | 0.1 | Project Start | milestone | 0d? | 2009-05-01 A | 2009-05-01 A |  | 100% |  |  |  |  |  |  |  |  | PD |
| 3 | 0.2 | Imager Preliminary Design Review | milestone | 0d? | 2010-06-14 | 2010-06-14 | 58FS-1d |  |  | 155.67d |  |  |  |  |  |  | PD |
| 4 | 0.3 | IFS System Design Review | milestone | 0d | 2010-03-17 | 2010-03-17 | 113FS-1d |  |  | 218.87d |  |  |  |  |  |  |  |
| 5 | 1 | **Near-IR Imager and IFS** |  | 422.92d? | 2009-06-04 A | 2011-01-17 |  | 20% | 339.46d? | 0d |  |  | 7441.2h | 606.4h | 421,915.26 | 36,220.34 |  |
| 6 | 1.1 | **Management** |  | 377.5d? | 2009-06-04 A | 2010-11-15 |  | 11% | 334.57d? | 45.42d |  |  | 1027.2h | 118.4h | 69,509.6 | 9,453.6 |  |
| 7 | 1.1.1 | **Monthly Reports** |  | 371d | 2009-06-05 A | 2010-11-05 |  | 50% | 185.5d | 50.92d |  |  | 115.2h | 57.6h | 10,022.4 | 5,011.2 |  |
| 8 | 1.1.1.1 | Monthly Reports 1 |  | 1d | 2009-06-05 A | 2009-06-05 A |  | 100% |  |  | start no earlier than 2009-06-05 | Sean Adkins [80%] | 6.4h | 6.4h | 556.8 | 556.8 |  |
| 9 | 1.1.1.2 | Monthly Reports 2 |  | 1d | 2009-07-06 A | 2009-07-06 A |  | 100% |  |  | start no earlier than 2009-07-05 | Sean Adkins [80%] | 6.4h | 6.4h | 556.8 | 556.8 |  |
| 10 | 1.1.1.3 | Monthly Reports 3 |  | 1d | 2009-08-05 A | 2009-08-05 A |  | 100% |  |  | start no earlier than 2009-08-05 | Sean Adkins [80%] | 6.4h | 6.4h | 556.8 | 556.8 |  |
| 11 | 1.1.1.4 | Monthly Reports 4 |  | 1d | 2009-09-07 A | 2009-09-07 A |  | 100% |  |  | start no earlier than 2009-09-05 | Sean Adkins [80%] | 6.4h | 6.4h | 556.8 | 556.8 |  |
| 12 | 1.1.1.5 | Monthly Reports 5 |  | 1d | 2009-10-05 A | 2009-10-05 A |  | 100% |  |  | start no earlier than 2009-10-05 | Sean Adkins [80%] | 6.4h | 6.4h | 556.8 | 556.8 |  |
| 13 | 1.1.1.6 | Monthly Reports 6 |  | 1d | 2009-11-05 A | 2009-11-05 A |  | 100% |  |  | start no earlier than 2009-11-05 | Sean Adkins [80%] | 6.4h | 6.4h | 556.8 | 556.8 |  |
| 14 | 1.1.1.7 | Monthly Reports 7 |  | 1d | 2009-12-07 A | 2009-12-07 A |  | 100% |  |  | start no earlier than 2009-12-05 | Sean Adkins [80%] | 6.4h | 6.4h | 556.8 | 556.8 |  |
| 15 | 1.1.1.8 | Monthly Reports 8 |  | 1d | 2010-01-05 A | 2010-01-05 A |  | 100% |  |  | start no earlier than 2010-01-05 | Sean Adkins [80%] | 6.4h | 6.4h | 556.8 | 556.8 |  |
| 16 | 1.1.1.9 | Monthly Reports 9 |  | 1d | 2010-02-05 A | 2010-02-05 A |  | 100% |  |  | start no earlier than 2010-02-05 | Sean Adkins [80%] | 6.4h | 6.4h | 556.8 | 556.8 |  |
| 17 | 1.1.1.10 | Monthly Reports 10 |  | 1d | 2010-03-05 | 2010-03-05 |  |  |  | 225.92d | start no earlier than 2010-03-05 | Sean Adkins [80%] | 6.4h |  | 556.8 |  |  |
| 18 | 1.1.1.11 | Monthly Reports 11 |  | 1d | 2010-04-05 | 2010-04-05 |  |  |  | 204.92d | start no earlier than 2010-04-05 | Sean Adkins [80%] | 6.4h |  | 556.8 |  |  |
| 19 | 1.1.1.12 | Monthly Reports 12 |  | 1d | 2010-05-05 | 2010-05-05 |  |  |  | 182.92d | start no earlier than 2010-05-05 | Sean Adkins [80%] | 6.4h |  | 556.8 |  |  |
| 20 | 1.1.1.13 | Monthly Reports 13 |  | 1d | 2010-06-07 | 2010-06-07 |  |  |  | 159.92d | start no earlier than 2010-06-05 | Sean Adkins [80%] | 6.4h |  | 556.8 |  |  |
| 21 | 1.1.1.14 | Monthly Reports 14 |  | 1d | 2010-07-05 | 2010-07-05 |  |  |  | 139.92d | start no earlier than 2010-07-05 | Sean Adkins [80%] | 6.4h |  | 556.8 |  |  |
| 22 | 1.1.1.15 | Monthly Reports 15 |  | 1d | 2010-08-05 | 2010-08-05 |  |  |  | 116.92d | start no earlier than 2010-08-05 | Sean Adkins [80%] | 6.4h |  | 556.8 |  |  |
| 23 | 1.1.1.16 | Monthly Reports 16 |  | 1d | 2010-09-06 | 2010-09-06 |  |  |  | 94.92d | start no earlier than 2010-09-05 | Sean Adkins [80%] | 6.4h |  | 556.8 |  |  |
| 24 | 1.1.1.17 | Monthly Reports 17 |  | 1d | 2010-10-05 | 2010-10-05 |  |  |  | 73.92d | start no earlier than 2010-10-05 | Sean Adkins [80%] | 6.4h |  | 556.8 |  |  |
| 25 | 1.1.1.18 | Monthly Reports 18 |  | 1d | 2010-11-05 | 2010-11-05 |  |  |  | 50.92d | start no earlier than 2010-11-05 | Sean Adkins [80%] | 6.4h |  | 556.8 |  |  |

| ID | WBS | Task | Duration | Start | Finish | Predecessors | Complete | Remaining | Total slack | Free slack | Constraint | Resources | Work | Actual work | Cost | Actual cost | Text1 | Text2 |
| --- | --- | --- | --- | --- | --- | --- | --- | --- | --- | --- | --- | --- | --- | --- | --- | --- | --- | --- |
| 26 | 1.1.2 | **Project Meetings** | 216.5d | 2010-01-15 A | 2010-11-15 |  | 9% | 196.82d | 45.42d |  |  |  | 310.4h | 28.8h | 17,772 | 1,658.4 |  |  |
| 27 | 1.1.2.1 | Project Meeting 1 | 4h | 2010-01-15 A | 2010-01-15 A |  | 100% |  |  |  | start no earlier than 2010-01-15 | Sean Adkins [80%]; Instrument Scientist [70%]; ME - TBD [90%]; OE - Optical Engineer 2 [90%]; Software Engineer [90%]; WMKO Support Astronomer; WMKO Electronics Staff; ME - Jim Bell | 28.8h | 28.8h | 1,658.4 | 1,658.4 |  |  |
| 28 | 1.1.2.2 | Project Meeting 2 | 4h | 2010-02-15 | 2010-02-15 |  |  |  | 240.42d |  | start no earlier than 2010-02-15 | Sean Adkins [80%]; Instrument Scientist [70%]; ME - TBD [90%]; OE - Optical Engineer 2 [90%]; Software Engineer [90%]; WMKO Support Astronomer; WMKO Electronics Staff; ME - Jim Bell | 28.8h |  | 1,658.4 |  |  |  |
| 29 | 1.1.2.3 | Project Meeting 3 | 4h | 2010-03-15 | 2010-03-15 |  |  |  | 220.42d |  | start no earlier than 2010-03-15 | Sean Adkins [80%]; Instrument Scientist [70%]; ME - TBD [90%]; OE - Optical Engineer 2 [90%]; Software Engineer [90%]; WMKO Support Astronomer; WMKO Electronics Staff; ME - Jim Bell | 25.6h |  | 1,380 |  |  |  |
| 30 | 1.1.2.4 | Project Meeting 4 | 4h | 2010-04-15 | 2010-04-15 |  |  |  | 197.42d |  | start no earlier than 2010-04-15 | Sean Adkins [80%]; Instrument Scientist [70%]; ME - Jim Bell [90%]; ME - TBD [90%]; OE - Optical Engineer 2 [90%]; Software Engineer [90%]; WMKO Support Astronomer; WMKO Electronics Staff | 28.4h |  | 1,634.4 |  |  |  |
| 31 | 1.1.2.5 | Project Meeting 5 | 4h | 2010-05-17 | 2010-05-17 |  |  |  | 175.42d |  | start no earlier than 2010-05-15 | Sean Adkins [80%]; Instrument Scientist [70%]; ME - Jim Bell [90%]; ME - TBD [90%]; OE - Optical Engineer 2 [90%]; Software Engineer [90%]; WMKO Support Astronomer; WMKO Electronics Staff | 28.4h |  | 1,634.4 |  |  |  |
| 32 | 1.1.2.6 | Project Meeting 6 | 4h | 2010-06-15 | 2010-06-15 |  |  |  | 154.42d |  | start no earlier than 2010-06-15 | Sean Adkins [80%]; Instrument Scientist [70%]; ME - Jim Bell [90%]; ME - TBD [90%]; OE - Optical Engineer 2 [90%]; Software Engineer [90%]; WMKO Support Astronomer; WMKO Electronics Staff | 28.4h |  | 1,634.4 |  |  |  |
| 33 | 1.1.2.7 | Project Meeting 7 | 4h | 2010-07-15 | 2010-07-15 |  |  |  | 132.42d |  | start no earlier than 2010-07-15 | Sean Adkins [80%]; Instrument Scientist [70%]; ME - Jim Bell [90%]; ME - TBD [90%]; OE - Optical Engineer 2 [90%]; Software Engineer [90%]; WMKO Support Astronomer; WMKO Electronics Staff | 28.4h |  | 1,634.4 |  |  |  |
| 34 | 1.1.2.8 | Project Meeting 8 | 4h | 2010-08-16 | 2010-08-16 |  |  |  | 110.42d |  | start no earlier than 2010-08-15 | Sean Adkins [80%]; Instrument Scientist [70%]; ME - Jim Bell [90%]; ME - TBD [90%]; OE - Optical Engineer 2 [90%]; Software Engineer [90%]; WMKO Support Astronomer; WMKO Electronics Staff | 28.4h |  | 1,634.4 |  |  |  |
| 35 | 1.1.2.9 | Project Meeting 9 | 4h | 2010-09-15 | 2010-09-15 |  |  |  | 88.42d |  | start no earlier than 2010-09-15 | Sean Adkins [80%]; Instrument Scientist [70%]; ME - Jim Bell [90%]; ME - TBD [90%]; OE - Optical Engineer 2 [90%]; Software Engineer [90%]; WMKO Support Astronomer; WMKO Electronics Staff | 28.4h |  | 1,634.4 |  |  |  |
| 36 | 1.1.2.10 | Project Meeting 10 | 4h | 2010-10-15 | 2010-10-15 |  |  |  | 66.42d |  | start no earlier than 2010-10-15 | Sean Adkins [80%]; Instrument Scientist [70%]; ME - Jim Bell [90%]; ME - TBD [90%]; OE - Optical Engineer 2 [90%]; Software Engineer [90%]; WMKO Support Astronomer; WMKO Electronics Staff | 28.4h |  | 1,634.4 |  |  |  |
| 37 | 1.1.2.11 | Project Meeting 11 | 4h | 2010-11-15 | 2010-11-15 |  |  |  | 45.42d |  | start no earlier than 2010-11-15 | Sean Adkins [80%]; Instrument Scientist [70%]; ME - Jim Bell [90%]; ME - TBD [90%]; OE - Optical Engineer 2 [90%]; Software Engineer [90%]; WMKO Support Astronomer; WMKO Electronics Staff | 28.4h |  | 1,634.4 |  |  |  |
| 38 | 1.1.3 | System Engineering Management Plan | 12.5d | 2010-02-15 | 2010-03-03 |  |  |  | 235.66d |  | start no earlier than 2010-02-14 | Sean Adkins [20%] | 20h |  | 1,740 |  | PD | IFS |
| 39 | 1.1.4 | Proposals to Fund Future Phases (ATI, MRI would be early 2010) | 43d? | 2010-05-03 | 2010-06-30 |  |  |  | 150.22d |  | start no earlier than 2010-05-02 | Sean Adkins [11.6%] | 40h |  | 3,480 |  | PD |  |
| 40 | 1.1.5 | Cost Review | 25d? | 2010-03-31 | 2010-05-14 | 148 |  |  | 176.15d |  |  | Sean Adkins [20%] | 40h |  | 3,480 |  | PD |  |
| 41 | 1.1.6 | **Project Plan Maintenance** | 328d | 2009-06-04 A | 2010-09-06 |  | 50% | 164d | 94.92d |  |  |  | 38.4h | 19.2h | 3,340.8 | 1,670.4 |  |  |
| 42 | 1.1.6.1 | Project Plan Maintenance 1 | 1d | 2009-06-04 A | 2009-06-04 A |  | 100% |  |  |  | start no earlier than 2009-06-04 | Sean Adkins [80%] | 6.4h | 6.4h | 556.8 | 556.8 |  |  |
| 43 | 1.1.6.2 | Project Plan Maintenance 2 | 1d | 2009-09-04 A | 2009-09-04 A |  | 100% |  |  |  | start no earlier than 2009-09-04 | Sean Adkins [80%] | 6.4h | 6.4h | 556.8 | 556.8 |  |  |
| 44 | 1.1.6.3 | Project Plan Maintenance 3 | 1d | 2009-12-04 A | 2009-12-04 A |  | 100% |  |  |  | start no earlier than 2009-12-04 | Sean Adkins [80%] | 6.4h | 6.4h | 556.8 | 556.8 |  |  |
| 45 | 1.1.6.4 | Project Plan Maintenance 4 | 1d | 2010-03-04 | 2010-03-04 |  |  |  | 260.89d |  | start no earlier than 2010-03-04 | Sean Adkins [80%] | 6.4h |  | 556.8 |  |  |  |
| 46 | 1.1.6.5 | Project Plan Maintenance 5 | 1d | 2010-06-04 | 2010-06-04 |  |  |  | 194.89d |  | start no earlier than 2010-06-04 | Sean Adkins [80%] | 6.4h |  | 556.8 |  |  |  |
| 47 | 1.1.6.6 | Project Plan Maintenance 6 | 1d | 2010-09-06 | 2010-09-06 |  |  |  | 128.89d |  | start no earlier than 2010-09-04 | Sean Adkins [80%] | 6.4h |  | 556.8 |  |  |  |
| 48 | 1.1.7 | **Budget Maintenance** | 348d | 2009-06-04 A | 2010-10-04 |  | 25% | 261d | 74.92d |  |  |  | 51.2h | 12.8h | 4,454.4 | 1,113.6 |  |  |
| 49 | 1.1.7.1 | Budget Maintenance 1 | 1d | 2009-06-04 A | 2009-06-04 A |  | 100% |  |  |  | start no earlier than 2009-06-04 | Sean Adkins [80%] | 6.4h | 6.4h | 556.8 | 556.8 |  |  |
| 50 | 1.1.7.2 | Budget Maintenance 2 | 1d | 2009-08-04 A | 2009-08-04 A |  | 100% |  |  |  | start no earlier than 2009-08-04 | Sean Adkins [80%] | 6.4h | 6.4h | 556.8 | 556.8 |  |  |
| 51 | 1.1.7.4 | Budget Maintenance 3 | 1d | 2009-12-04 | 2009-12-04 |  |  |  | 359.05d |  | start no earlier than 2009-12-04 | Sean Adkins [80%] | 6.4h |  | 556.8 |  |  |  |
| 52 | 1.1.7.5 | Budget Maintenance 4 | 1d | 2010-02-04 | 2010-02-04 |  |  |  | 315.05d |  | start no earlier than 2010-02-04 | Sean Adkins [80%] | 6.4h |  | 556.8 |  |  |  |
| 53 | 1.1.7.6 | Budget Maintenance 6 | 1d | 2010-04-05 | 2010-04-05 |  |  |  | 273.05d |  | start no earlier than 2010-04-04 | Sean Adkins [80%] | 6.4h |  | 556.8 |  |  |  |
| 54 | 1.1.7.7 | Budget Maintenance 7 | 1d | 2010-06-04 | 2010-06-04 |  |  |  | 229.05d |  | start no earlier than 2010-06-04 | Sean Adkins [80%] | 6.4h |  | 556.8 |  |  |  |
| 55 | 1.1.7.8 | Budget Maintenance 8 | 1d | 2010-08-04 | 2010-08-04 |  |  |  | 186.05d |  | start no earlier than 2010-08-04 | Sean Adkins [80%] | 6.4h |  | 556.8 |  |  |  |
| 56 | 1.1.7.9 | Budget Maintenance 9 | 1d | 2010-10-04 | 2010-10-04 |  |  |  | 143.05d |  | start no earlier than 2010-10-04 | Sean Adkins [80%] | 6.4h |  | 556.8 |  |  |  |
| 57 | 1.1.8 | Preliminary Design Report | 8d | 2010-05-18 | 2010-05-28 | 65, 192, 214, 148 |  |  | 154.67d | 0d |  | Sean Adkins [125%]; Instrument Scientist; ME - Jim Bell; ME - TBD; Software Engineer; Electronics Engineer; WMKO Support Astronomer; WMKO Software Staff; WMKO Instrument Staff; WMKO Electronics Staff; OE - Optical Engineer 2 | 280h |  | 17,720 |  | PD |  |
| 58 | 1.1.9 | Preliminary Design Review | 1.5d | 2010-06-11 | 2010-06-15 | 57FS+2w |  |  | 154.67d | 0d |  | Sean Adkins; Instrument Scientist; ME - Jim Bell; ME - TBD; Software Engineer; Electronics Engineer; WMKO Support Astronomer; WMKO Software Staff; WMKO Instrument Staff; WMKO Electronics Staff; OE - Optical Engineer 2 | 132h |  | 7,500 |  |  |  |

Notes:
- 57: Effort for team members includes writing PD report.

| ID | WBS | Task | Duration | Start | Finish | Predecessors | Complete | Remaining | Total slack | Free slack | Constraint | Resources | Work | Actual work | Cost | Actual cost | Text1 |
| --- | --- | --- | --- | --- | --- | --- | --- | --- | --- | --- | --- | --- | --- | --- | --- | --- | --- |
| 59 | 1.2 | **Science** | 82.76d? | 2010-01-22 | 2010-05-18 |  |  |  | 174.17d |  |  |  | 194h |  | 8,178 |  |  |
| 60 | 1.2.1 | **Science Team Meetings** | 51.5d? | 2010-01-22 | 2010-04-05 |  |  |  | 205.42d |  |  |  | 64h |  | 2,088 |  |  |
| 61 | 1.2.1.1 | Meeting 1 | 1.5d? | 2010-01-22 | 2010-01-25 | 2FS+9.5mo |  |  | 323.55d |  |  | Sean Adkins; Instrument Scientist; Science Team | 32h |  | 1,044 |  | PD |
| 62 | 1.2.1.2 | Meeting 2 | 1.5d? | 2010-04-02 | 2010-04-05 | 2FS+12mo |  |  | 273.55d |  |  | Sean Adkins; Instrument Scientist; Science Team | 32h |  | 1,044 |  | PD |
| 63 | 1.2.2 | **Common Observing Operations Concept Document** | 41.76d? | 2010-03-22 | 2010-05-18 |  |  |  | 174.17d |  |  |  | 130h |  | 6,090 |  |  |
| 64 | 1.2.2.1 | Initial Draft | 19.75d? | 2010-03-22 | 2010-04-16 | 2FS+9mo |  |  | 196.17d |  | start no earlier than 2010-03-21 | Sean Adkins [20%]; Instrument Scientist [20%]; Science Team [20%] | 70h |  | 2,610 |  | PD |
| 65 | 1.2.2.2 | Final Version | 5.51d? | 2010-05-03 | 2010-05-18 | 182, 201FS-2w |  |  | 154.67d | 0d |  | Sean Adkins; Instrument Scientist; Science Team | 60h |  | 3,480 |  | PD |
| 66 | 1.3 | **Instrument Design and Fabrication** | 412.92d? | 2009-06-18 A | 2011-01-17 |  | 21% | 324.42d? | 0d |  |  |  | 6220h | 488h | 344,227.66 | 26,766.74 |  |
| 67 | 1.3.1 | **AO System to Instrument Interface Definitions** | 84d? | 2009-09-14 A | 2010-01-08 |  | 64% | 30.37d? | 266.92d |  |  |  | 136h | 56h | 9,708 | 3,992 | PD |
| 68 | 1.3.1.1 | Optical | 2.6d? | 2009-09-14 A | 2009-09-16 A | 76 | 100% |  |  |  |  | Sean Adkins; OE - Optical Engineer 2 | 28h | 28h | 2,096 | 2,096 | PD |
| 69 | 1.3.1.2 | Mechanical | 3.5d? | 2009-09-16 A | 2009-09-24 A | 68 | 100% |  |  |  |  | Sean Adkins; ME - Jim Bell | 28h | 28h | 1,896 | 1,896 | PD |
| 70 | 1.3.1.3 | Electronic/Electrical | 1.5d? | 2009-09-24 A | 2009-09-25 | 69 | 75% | 0.38d? | 0d |  |  | Sean Adkins | 12h |  | 1,044 |  | PD |
| 71 | 1.3.1.4 | Software | 2.5d? | 2009-09-25 | 2009-09-30 | 70 |  |  | 0d |  |  | Sean Adkins; Software Engineer | 28h |  | 1,896 |  | PD |
| 72 | 1.3.1.5 | Alignment and Calibration Concept for Instrument on AO System | 2d? | 2010-01-06 A | 2010-01-08 | 71FS+14w | 25% | 1.5d? | 274.22d |  |  | Sean Adkins; OE - Optical Engineer 2; ME - Jim Bell | 40h |  | 2,776 |  | PD |
| 73 | 1.3.2 | **Shared Facilities** | 246.45d? | 2009-06-18 A | 2010-05-28 |  | 36% | 157.34d? | 166.47d |  |  |  | 216h | 48h | 15,706 | 4,176 |  |
| 74 | 1.3.2.1 | **AO System** | 246.45d? | 2009-06-18 A | 2010-05-28 |  | 33% | 164.7d? | 166.47d |  |  |  | 176h | 48h | 13,036 | 4,176 |  |
| 75 | 1.3.2.1.1 | **High Order AO Relay** | 246.45d? | 2009-06-18 A | 2010-05-28 |  | 75% | 60.44d? | 166.47d |  |  |  | 68h | 48h | 5,916 | 4,176 |  |
| 76 | 1.3.2.1.1.1 | Design Liason | 38.47d? | 2009-06-18 A | 2009-09-14 A |  | 100% |  |  |  | start no earlier than 2009-06-18 | Sean Adkins [16.1%] | 48h | 48h | 4,176 | 4,176 | PD |
| 77 | 1.3.2.1.1.2 | RTC and Control Liason | 12.5d? | 2010-05-11 | 2010-05-28 | 201SS |  |  | 166.47d |  |  | Sean Adkins [20%] | 20h |  | 1,740 |  | PD |
| 78 | 1.3.2.1.2 | **ADC** | 35d? | 2010-01-25 | 2010-03-12 |  |  |  | 220.92d |  |  |  | 56h |  | 4,464 |  |  |
| 79 | 1.3.2.1.2.1 | Requirements Liason | 20d? | 2010-01-25 | 2010-02-19 | 76FS+10w |  |  | 228.22d | 0d | start no earlier than 2010-01-24 | Sean Adkins [20%] | 32h |  | 2,784 |  | PD |
| 80 | 1.3.2.1.2.2 | Design Liason | 15d? | 2010-02-22 | 2010-03-12 | 79 |  |  | 228.22d |  |  | OE - Optical Engineer 2 [20%] | 24h |  | 1,680 |  | PD |
| 81 | 1.3.2.1.3 | **Calibration Faciltiy** | 30d? | 2010-03-02 | 2010-04-13 |  |  |  | 199.67d |  |  |  | 52h |  | 2,656 |  |  |
| 82 | 1.3.2.1.3.1 | Requirements Liason | 10d? | 2010-03-02 | 2010-03-16 | 142 |  |  | 199.67d | 0d |  | Sean Adkins [20%]; Instrument Scientist [20%]; OE - Optical Engineer 2 [20%] | 28h |  | 1,536 |  | PD |
| 83 | 1.3.2.1.3.2 | Design Liason | 20d? | 2010-03-16 | 2010-04-13 | 82 |  |  | 199.67d |  |  | Instrument Scientist [10%]; OE - Optical Engineer 2 [10%] | 24h |  | 1,120 |  | PD |

| ID | WBS | Task | Duration | Start | Finish | Predecessors | Complete | Remaining | Total slack | Free slack | Constraint | Resources | Work | Actual work | Cost | Actual cost | Text1 | Text2 |
| --- | --- | --- | --- | --- | --- | --- | --- | --- | --- | --- | --- | --- | --- | --- | --- | --- | --- | --- |
| 84 | 1.3.2.2 | **Nasmyth Enclosure** | 29.48d? | 2010-03-31 A | 2010-05-11 |  | 50% | 14.74d? | 178.99d |  |  |  | 40h |  | 2,670 |  |  |  |
| 85 | 1.3.2.2.1 | Requirements Liason | 12.5d? | 2010-03-31 A | 2010-04-23 | 146 | 50% | 6.25d? | 0d |  |  | Sean Adkins [20%]; ME - Jim Bell [20%] | 20h |  | 1,470 |  | PD |  |
| 86 | 1.3.2.2.2 | Design Liason | 12.5d? | 2010-04-23 A | 2010-05-11 | 85 | 50% | 6.25d? | 186.29d |  |  | ME - Jim Bell [20%] | 20h |  | 1,200 |  | PD |  |
| 87 | 1.3.3 | **Instrument** | 404.92d? | 2009-06-30 A | 2011-01-17 |  | 18% | 331.19d? | 0d |  |  |  | 5868h | 384h | 318,813.66 | 18,598.74 |  |  |
| 88 | 1.3.3.1 | **IFS System Design Phase** | 118.34d? | 2009-11-02 A | 2010-04-15 |  | 42% | 68.72d? | 197.58d |  |  |  | 1552h | 320h | 77,914.31 | 13,942.74 | PD | IFS |
| 89 | 1.3.3.1.1 | **IFS Performance Budgets** | 118.34d | 2009-11-02 A | 2010-04-15 |  | 31% | 82.03d | 197.58d |  |  |  | 260h |  | 11,576.17 |  | PD | IFS |
| 90 | 1.3.3.1.1.1 | Throughput | 8.33d | 2009-11-02 A | 2010-02-04 | 135FS+4mo | 70% | 2.5d | 222.39d | 0d |  | Sean Adkins [50%]; Instrument Scientist [50%]; OE - Sergey Panteleev [50%] | 60h |  | 2,446.67 |  | PD | IFS |
| 91 | 1.3.3.1.1.2 | Background | 5d | 2009-11-10 A | 2010-02-22 | 90 | 40% | 3d | 213.99d | 0d |  | Sean Adkins [50%]; Instrument Scientist [50%]; OE - Sergey Panteleev [50%] | 40h |  | 1,980 |  | PD | IFS |
| 92 | 1.3.3.1.1.3 | Wavefront error | 6.67d | 2010-02-22 | 2010-03-02 | 91 |  |  | 268.53d | 0d |  | Sean Adkins [50%]; Instrument Scientist [50%]; OE - Sergey Panteleev [50%] | 60h |  | 2,446.67 |  | PD | IFS |
| 93 | 1.3.3.1.1.4 | Spectroscopic performance | 14.27d | 2009-12-04 A | 2010-04-08 | 92 | 30% | 9.99d | 197.58d | 0d |  | Sean Adkins [50%]; Instrument Scientist [50%]; OE - Sergey Panteleev [38%] | 80h |  | 3,390.34 |  | PD | IFS |
| 94 | 1.3.3.1.1.5 | Size and mass | 5.21d | 2010-04-08 | 2010-04-15 | 93 |  |  | 253.55d |  |  | Sean Adkins [50%]; ME - Jim Bell [38%] | 20h |  | 1,312.5 |  | PD | IFS |
| 95 | 1.3.3.1.2 | **Trade Studies** | 93.41d | 2009-11-10 A | 2010-03-22 |  | 36% | 59.58d | 215.85d |  |  |  | 350h |  | 16,446.78 |  | PD | IFS |
| 96 | 1.3.3.1.2.1 | FOV and spatial sampling | 14.31d | 2009-11-10 A | 2010-03-09 | 90 | 20% | 11.45d | 224.84d | 0d |  | Sean Adkins [33.3%]; Instrument Scientist [50%]; OE - Sergey Panteleev [33%] | 90h |  | 4,461.53 |  | PD | IFS |
| 97 | 1.3.3.1.2.2 | Wavelength coverage and spatial sampling | 13.19d | 2009-11-10 A | 2010-01-01 | 96SS | 50% | 6.6d | 267.5d | 0d |  | Sean Adkins [50%]; Instrument Scientist [50%]; OE - Sergey Panteleev [33%] | 70h |  | 3,202.78 |  | PD | IFS |
| 98 | 1.3.3.1.2.3 | Optimization of image slicing formats and spectrograph formats | 13.49d | 2009-12-11 A | 2010-02-04 | 97 | 40% | 3.98d | 247.3d |  |  | Sean Adkins [33.3%]; Instrument Scientist [50%]; OE - Sergey Panteleev [33%]; ME - TBD [50%] | 110h |  | 5,784.33 |  | PD | IFS |
| 99 | 1.3.3.1.2.4 | Wavefront error allocations | 7.17d | 2010-03-04 | 2010-03-15 | 108 |  |  | 215.85d | 0d |  | Sean Adkins [50%]; Instrument Scientist [50%]; OE - Sergey Panteleev [33%] | 50h |  | 1,532.99 |  | PD | IFS |
| 100 | 1.3.3.1.2.5 | Trade study report | 4.21d | 2010-03-15 | 2010-03-22 | 99 |  |  | 215.85d |  |  | Sean Adkins [16.7%]; Instrument Scientist [50%]; OE - Sergey Panteleev [50%] | 30h |  | 1,465.15 |  | PD | IFS |
| 101 | 1.3.3.1.3 | **Conceptual Designs** | 72.92d? | 2009-12-07 A | 2010-03-17 |  | 55% | 33.17d? | 218d |  |  |  | 850h | 320h | 44,793.39 | 13,942.74 | PD | IFS |
| 102 | 1.3.3.1.3.1 | Development of design options | 33.77d | 2009-12-07 A | 2010-01-21 A | 90SS+1mo | 100% |  |  |  | start no earlier than 2009-12-06 | Sean Adkins [50%]; Instrument Scientist [50%]; OE - Sergey Panteleev [19.4%]; ME - TBD [57.4%] | 320h | 320h | 13,942.74 | 13,942.74 | PD | IFS |
| 103 | 1.3.3.1.3.2 | Evaluation of design options | 10d? | 2010-01-21 A | 2010-02-04 | 102 | 50% | 5d? | 0d |  |  | Sean Adkins [50%]; Instrument Scientist [50%]; OE - Sergey Panteleev [50%]; ME - TBD [50%] | 110h |  | 7,380 |  | PD | IFS |
| 104 | 1.3.3.1.3.3 | Calibration and alignment issues | 5.58d? | 2010-02-04 | 2010-02-12 | 103 |  |  | 0d |  |  | Sean Adkins [50%]; Instrument Scientist [50%]; OE - Sergey Panteleev [50%]; ME - TBD [50%] | 60h |  | 3,122.46 |  | PD | IFS |
| 105 | 1.3.3.1.3.4 | Downselect of conceptual design | 5d? | 2010-02-12 A | 2010-02-19 | 104 | 50% | 2.5d? | 0d |  |  | Sean Adkins [50%]; Instrument Scientist [50%]; OE - Sergey Panteleev [50%]; ME - TBD [50%] | 80h |  | 4,340 |  | PD | IFS |
| 106 | 1.3.3.1.3.5 | Revised performance budgets | 4d? | 2010-02-19 | 2010-02-25 | 105 |  |  | 228.83d | 0d |  | Sean Adkins [50%]; Instrument Scientist [50%]; OE - Sergey Panteleev [50%] | 40h |  | 1,816 |  | PD | IFS |
| 107 | 1.3.3.1.3.6 | Performance budget report | 3.75d? | 2010-02-25 | 2010-03-03 | 106 |  |  | 228.83d |  |  | Sean Adkins [50%]; OE - Sergey Panteleev [50%] | 30h |  | 2,355 |  | PD | IFS |
| 108 | 1.3.3.1.3.7 | Performance estimates | 4.38d? | 2010-02-19 | 2010-03-04 | 105 |  |  | 0d |  |  | Sean Adkins [50%]; Instrument Scientist [50%]; OE - Sergey Panteleev [50%]; ME - TBD [50%] | 60h |  | 3,308.13 |  | PD | IFS |
| 109 | 1.3.3.1.3.8 | System requirements document | 4.38d? | 2010-03-04 | 2010-03-11 | 108 |  |  | 0d |  |  | Sean Adkins [50%]; Instrument Scientist [50%]; OE - Sergey Panteleev [50%]; ME - TBD [50%] | 70h |  | 3,797.5 |  | PD | IFS |
| 110 | 1.3.3.1.3.9 | System design manual | 4.85d? | 2010-03-11 | 2010-03-17 | 109 |  |  | 218d |  |  | Sean Adkins [75%]; Instrument Scientist [75%]; OE - Sergey Panteleev [75%]; ME - TBD [75%] | 80h |  | 4,731.57 |  | PD | IFS |

| ID | WBS | Task | Duration | Start | Finish | Predecessors | Complete | Remaining | Total slack | Free slack | Constraint | Resources | Work | Actual work | Cost | Actual cost | Text1 | Text2 |
| --- | --- | --- | --- | --- | --- | --- | --- | --- | --- | --- | --- | --- | --- | --- | --- | --- | --- | --- |
| 111 | 1.3.3.1.4 | **System Design Review** | 4.98d? | 2010-03-11 | 2010-03-18 | 108 |  |  | 0d |  |  |  | 92h |  | 5,097.97 |  | PD | IFS |
| 112 | 1.3.3.1.4.1 | System design report | 3.75d? | 2010-03-11 | 2010-03-16 | 109 |  |  | 0d |  |  | Sean Adkins [50%]; Instrument Scientist [50%]; OE - Sergey Panteleev [50%]; ME - TBD [50%] | 60h |  | 3,255 |  | PD | IFS |
| 113 | 1.3.3.1.4.2 | System design review meeting | 1.23d? | 2010-03-16 | 2010-03-18 | 112 |  |  | 0d |  |  | Sean Adkins [80%]; Instrument Scientist [80%]; OE - Sergey Panteleev [90%]; ME - TBD [90%] | 32h |  | 1,842.97 |  | PD | IFS |
| 114 | 1.3.3.2 | **IFS Preliminary Design Phase** | 217.87d? | 2010-03-18 | 2011-01-17 |  |  |  | 0d |  |  |  | 2148h |  | 107,197.9 |  | DD | IFS |
| 115 | 1.3.3.2.1 | Initial AO system to instrument interface definitions | 5.39d? | 2010-03-18 | 2010-03-29 | 113 |  |  | 0d |  |  | Sean Adkins [50%]; OE - Sergey Panteleev [50%]; ME - Jim Bell [50%] | 60h |  | 4,340 |  | DD | IFS |
| 116 | 1.3.3.2.2 | Alignment and calibration concept | 8.19d? | 2010-03-29 | 2010-04-08 | 115 |  |  | 0d |  |  | Sean Adkins [50%]; Instrument Scientist [50%]; OE - Sergey Panteleev [50%]; ME - Jim Bell [50%] | 100h |  | 4,669.23 |  | DD | IFS |
| 117 | 1.3.3.2.3 | Optical design | 91.7d? | 2010-04-08 | 2010-08-13 | 116 |  |  | 0d |  |  | Sean Adkins [50%]; Instrument Scientist [50%]; OE - Sergey Panteleev [50%] | 760h |  | 29,114.83 |  | DD | IFS |
| 118 | 1.3.3.2.4 | Mechanical design | 160.82d? | 2010-05-21 | 2011-01-03 | 117FS-60d |  |  | 0d |  |  | Sean Adkins [50%]; ME - Jim Bell [50%] | 680h |  | 41,880 |  | DD | IFS |
| 119 | 1.3.3.2.5 | Electronic design | 30d? | 2010-11-05 | 2010-12-17 | 117FS+60d |  |  | 10.82d | 0d |  | Sean Adkins [50%]; Electronics Engineer [50%] | 140h |  | 8,940 |  | DD | IFS |
| 120 | 1.3.3.2.6 | Software design | 23.53d? | 2010-11-05 | 2010-12-09 | 119SS |  |  | 17.29d |  |  | Sean Adkins [50%]; Instrument Scientist [50%]; Software Engineer [50%] | 200h |  | 6,670.59 |  | DD | IFS |
| 121 | 1.3.3.2.7 | Preliminary design report | 8.89d? | 2011-01-03 | 2011-01-14 | 115, 118, 119, 120 |  |  | 0d |  |  | Sean Adkins [50%]; Instrument Scientist [50%]; ME - Jim Bell [50%]; Electronics Engineer [50%]; OE - Sergey Panteleev [50%]; Software Engineer [50%] | 160h |  | 8,782.24 |  | DD | IFS |
| 122 | 1.3.3.2.8 | Preliminary design review meeting | 1.27d? | 2011-01-14 | 2011-01-17 | 121 |  |  | 0d |  |  | Sean Adkins [80%]; Instrument Scientist [80%]; ME - Jim Bell [90%]; Electronics Engineer [90%]; OE - Sergey Panteleev [90%]; Software Engineer [90%] | 48h |  | 2,801.01 |  | DD | IFS |
| 123 | 1.3.3.3 | **Near-IR Imager and IFS Preliminary Design** | 243.15d? | 2009-06-30 A | 2010-06-04 |  | 25% | 183.41d? | 161.77d |  |  |  | 2168h | 64h | 133,701.44 | 4,656 |  |  |
| 124 | 1.3.3.3.1 | **Imager Trade Studies** | 148.5d? | 2009-06-30 A | 2010-01-22 |  | 71% | 43.04d? | 256.43d |  |  |  | 104h | 16h | 6,189.44 | 696 | PD |  |
| 125 | 1.3.3.3.1.1 | Imager Wavefront Error | 4.75d? | 2009-12-28 | 2010-01-22 | 135FS+80d |  |  | 0d |  |  | Sean Adkins [80%]; Science Team; OE - Optical Engineer 2 [90%] | 40h |  | 2,421.44 |  | PD |  |
| 126 | 1.3.3.3.1.2 | Imager Pixel Scale | 14.7d? | 2009-06-30 A | 2010-01-20 |  | 90% | 1.47d? | 258.1d |  | start no earlier than 2009-06-30 | Sean Adkins [18.3%]; Science Team [62.5%]; OE - Optical Engineer 2 [62.5%] | 48h |  | 3,072 |  | PD |  |
| 127 | 1.3.3.3.1.3 | Imager Short Wavelength Cut-off | 2d? | 2009-10-05 A | 2009-10-07 A | 135FS+1mo | 100% |  |  |  |  | Sean Adkins; Science Team | 16h | 16h | 696 | 696 | PD |  |
| 128 | 1.3.3.3.2 | **Imager Performance Budgets** | 195.15d? | 2009-07-28 A | 2010-04-27 |  | 48% | 101.8d? | 189.77d |  |  |  | 124h |  | 9,268 |  | PD |  |
| 129 | 1.3.3.3.2.1 | Imager Sensitivity | 1d? | 2009-07-28 A | 2009-12-03 | 127FS+2mo | 90% | 0.1d? | 5.16d | 0d |  | Sean Adkins; OE - Optical Engineer 2 | 16h |  | 1,256 |  | PD |  |
| 130 | 1.3.3.3.2.2 | Imager Background | 5.73d? | 2009-11-05 A | 2010-01-07 | 129FS+1mo | 90% | 0.57d? | 0d |  |  | Sean Adkins [25%]; OE - Optical Engineer 2 [25%] | 16h |  | 1,256 |  | PD |  |
| 131 | 1.3.3.3.2.3 | Imager Companion Sensitivity | 4.5d? | 2010-01-08 A | 2010-01-20 | 130 | 70% | 1.35d? | 258.42d |  |  | Sean Adkins; OE - Optical Engineer 2 | 36h |  | 2,724 |  | PD |  |
| 132 | 1.3.3.3.2.4 | Imager Wavefront Error | 12d? | 2010-01-22 A | 2010-02-09 | 125 | 25% | 9d? | 352.18d |  |  | Sean Adkins [25%]; OE - Optical Engineer 2 [25%] | 32h |  | 2,376 |  | PD |  |
| 133 | 1.3.3.3.2.5 | Imager Size and Mass | 4.8d? | 2010-04-20 A | 2010-04-27 | 148 | 25% | 3.6d? | 189.77d |  |  | Sean Adkins [41.7%]; ME - Jim Bell [41.7%] | 24h |  | 1,656 |  | PD |  |
| 134 | 1.3.3.3.3 | **Optical Design** | 155.25d? | 2009-07-28 A | 2010-03-02 |  | 60% | 61.88d? | 199.67d |  |  |  | 356h | 40h | 23,880 | 3,480 |  |  |
| 135 | 1.3.3.3.3.1 | Initial Optical Design | 18.1d? | 2009-07-28 A | 2009-09-04 A |  | 100% |  |  |  |  | Sean Adkins [31.1%] | 40h | 40h | 3,480 | 3,480 |  |  |

| ID | WBS | Task | Duration | Start | Finish | Predecessors | Complete | Remaining | Total slack | Free slack | Constraint | Resources | Work | Actual work | Cost | Actual cost | Text1 |
| --- | --- | --- | --- | --- | --- | --- | --- | --- | --- | --- | --- | --- | --- | --- | --- | --- | --- |
| 136 | 1.3.3.3.3.2 | **Optical Modeling** | 61.25d? | 2009-11-30 A | 2010-02-23 |  | 50% | 30.82d? | 199.67d |  |  |  | 252h |  | 16,556 |  |  |
| 137 | 1.3.3.3.3.2.1 | Fore Optics | 20d? | 2009-11-30 A | 2010-01-15 | 135FS+8w | 90% | 2d? | 0d |  | start no earlier than 2009-11-29 | OE - Optical Engineer 2 [50%]; Sean Adkins [15.3%]; Instrument Scientist [50%] | 56h |  | 3,632 |  | PD |
| 138 | 1.3.3.3.3.2.2 | Lyot Stop | 2.5d? | 2009-12-14 A | 2010-01-04 | 135FS+8w | 50% | 1.25d? | 0d |  | start no earlier than 2009-12-13 | OE - Optical Engineer 2; Sean Adkins; Instrument Scientist | 24h |  | 1,468 |  | PD |
| 139 | 1.3.3.3.3.2.3 | Coronagraph | 1.5d? | 2010-01-04 A | 2010-01-14 | 138 | 50% | 0.75d? | 0d |  |  | OE - Optical Engineer 2; ME - Jim Bell; Instrument Scientist | 28h |  | 1,320 |  | PD |
| 140 | 1.3.3.3.3.2.4 | Imager Camera | 15d? | 2010-02-01 | 2010-02-19 |  |  |  | 0d |  | start no earlier than 2010-01-31 | OE - Optical Engineer 2 | 120h |  | 8,400 |  | PD |
| 141 | 1.3.3.3.3.2.5 | IFS Fold Mirror | 1.25d? | 2010-02-22 | 2010-02-23 | 140 |  |  | 199.67d | 0d |  | Sean Adkins [80%]; OE - Optical Engineer 2 [90%]; ME - Jim Bell [90%] | 24h |  | 1,736 |  |  |
| 142 | 1.3.3.3.3.3 | Preliminary Design Performance Analysis | 5d? | 2010-02-23 | 2010-03-02 | 141 |  |  | 199.67d | 0d |  | OE - Optical Engineer 2; Sean Adkins; Instrument Scientist | 64h |  | 3,844 |  | PD |
| 143 | 1.3.3.3.4 | **Dewar** | 79.95d? | 2010-01-15 A | 2010-05-06 |  | 5% | 75.62d? | 181.97d |  |  |  | 1072h | 8h | 64,416 | 480 |  |
| 144 | 1.3.3.3.4.1 | **Cold Assemblies** | 79.95d? | 2010-01-15 A | 2010-05-06 |  | 5% | 75.61d? | 181.97d |  |  |  | 792h | 8h | 47,536 | 480 |  |
| 145 | 1.3.3.3.4.1.1 | **Dewar Internal Structure** | 18.5d? | 2010-03-05 | 2010-03-31 |  |  |  | 13.85d |  |  |  | 188h |  | 11,280 |  |  |
| 146 | 1.3.3.3.4.1.1.1 | Interface Specification | 1d? | 2010-03-05 | 2010-03-05 | 168 |  |  | 13.85d | 0d |  | ME - Jim Bell | 8h |  | 480 |  | PD |
| 147 | 1.3.3.3.4.1.1.2 | Mechanical Model | 10d? | 2010-03-08 | 2010-03-19 | 146 |  |  | 13.85d | 0d |  | ME - Jim Bell | 80h |  | 4,800 |  | PD |
| 148 | 1.3.3.3.4.1.1.3 | FEA | 7.5d? | 2010-03-22 | 2010-03-31 | 147, 182 |  |  | 13.85d | 0d |  | ME - Jim Bell | 60h |  | 3,600 |  | PD |
| 149 | 1.3.3.3.4.1.1.4 | Thermal Analysis | 5d? | 2010-03-22 | 2010-03-26 | 147 |  |  | 175d | 0d |  | ME - Jim Bell | 40h |  | 2,400 |  | PD |
| 150 | 1.3.3.3.4.1.2 | **Fore Optics** | 40.5d? | 2010-01-15 A | 2010-03-12 |  | 14% | 34.98d? | 221.42d |  |  |  | 188h |  | 11,400 |  |  |
| 151 | 1.3.3.3.4.1.2.1 | **Input Baffle & Coronagraph** | 6.5d? | 2010-01-15 A | 2010-01-25 |  | 17% | 5.38d? | 0d |  |  |  | 52h |  | 3,120 |  |  |
| 152 | 1.3.3.3.4.1.2.1.1 | Interface Specification | 1.5d? | 2010-01-15 A | 2010-01-18 | 139 | 75% | 0.38d? | 0d |  |  | ME - Jim Bell | 12h |  | 720 |  | PD |
| 153 | 1.3.3.3.4.1.2.1.2 | Mechanical Model | 5d? | 2010-01-18 | 2010-01-25 | 152, 167 |  |  | 0d |  |  | ME - Jim Bell | 40h |  | 2,400 |  | PD |
| 154 | 1.3.3.3.4.1.2.2 | **Re-imager** | 6.5d? | 2010-01-18 A | 2010-01-26 |  | 17% | 5.38d? | 254.42d |  |  |  | 60h |  | 3,680 |  |  |
| 155 | 1.3.3.3.4.1.2.2.1 | Interface Specification | 1.5d? | 2010-01-18 A | 2010-01-19 | 137 | 75% | 0.38d? | 254.42d | 0d |  | OE - Optical Engineer 2; ME - Jim Bell | 20h |  | 1,280 |  | PD |
| 156 | 1.3.3.3.4.1.2.2.2 | Mechanical Model | 5d? | 2010-01-19 | 2010-01-26 | 155 |  |  | 288.39d |  |  | ME - Jim Bell | 40h |  | 2,400 |  | PD |
| 157 | 1.3.3.3.4.1.2.3 | **Adjustable Lyot Stop** | 9d? | 2010-03-01 A | 2010-03-12 |  | 8% | 8.25d? | 190.11d |  |  |  | 76h |  | 4,600 |  |  |
| 158 | 1.3.3.3.4.1.2.3.1 | Interface Specification | 1.5d? | 2010-03-01 A | 2010-03-02 | 138FS+8w | 50% | 0.75d? | 190.11d | 0d |  | OE - Optical Engineer 2; ME - Jim Bell | 16h |  | 1,000 |  | PD |
| 159 | 1.3.3.3.4.1.2.3.2 | Mechanical Model | 7.5d? | 2010-03-03 | 2010-03-12 | 158 |  |  | 190.11d | 35.45d |  | ME - Jim Bell | 60h |  | 3,600 |  | PD |

Notes:
- 153: Thermal analysis included in dewar structure thermal analysis task

| ID | WBS | Task | Duration | Start | Finish | Predecessors | Complete | Remaining | Total slack | Free slack | Resources | Work | Actual work | Cost | Actual cost | Text1 |
| --- | --- | --- | --- | --- | --- | --- | --- | --- | --- | --- | --- | --- | --- | --- | --- | --- |
| 160 | 1.3.3.3.4.1.3 | **Filter Wheels** | 19.76d? | 2010-02-22 A | 2010-03-19 |  | 6% | 18.51d? | 184.85d |  |  | 156h |  | 9,176 |  |  |
| 161 | 1.3.3.3.4.1.3.1 | **Mechanism** | 19.76d? | 2010-02-22 A | 2010-03-19 |  | 7% | 18.41d? | 184.85d |  |  | 132h |  | 7,920 |  |  |
| 162 | 1.3.3.3.4.1.3.1.1 | Interface Specification | 1.67d? | 2010-02-22 A | 2010-02-23 | 140 | 75% | 0.42d? | 184.85d | 0d | ME - Bob Weber [90%] | 12h |  | 720 |  | PD |
| 163 | 1.3.3.3.4.1.3.1.2 | Mechanical Model | 16.67d? | 2010-02-25 | 2010-03-19 | 164 |  |  | 184.85d | 30.19d | ME - Bob Weber [90%] | 120h |  | 7,200 |  | PD |
| 164 | 1.3.3.3.4.1.3.2 | Filter Specifications | 1.43d? | 2010-02-23 | 2010-02-25 | 162 |  |  | 184.85d | 0d | Sean Adkins; OE - Optical Engineer 2; Instrument Scientist [70%] | 24h |  | 1,256 |  | PD |
| 165 | 1.3.3.3.4.1.4 | **Imager** | 53.95d? | 2010-02-22 A | 2010-05-06 |  | 3% | 52.24d? | 181.97d |  |  | 260h | 8h | 15,680 | 480 |  |
| 166 | 1.3.3.3.4.1.4.1 | **Camera** | 9d? | 2010-02-22 | 2010-03-04 |  |  |  | 13.85d |  |  | 80h |  | 4,880 |  |  |
| 167 | 1.3.3.3.4.1.4.1.1 | Interface Specification | 1.5d? | 2010-02-22 | 2010-02-23 | 140 |  |  | 13.85d | 0d | OE - Optical Engineer 2; ME - Jim Bell | 20h |  | 1,280 |  | PD |
| 168 | 1.3.3.3.4.1.4.1.2 | Mechanical Model | 7.5d? | 2010-02-23 | 2010-03-04 | 167 |  |  | 13.85d | 0d | ME - Jim Bell | 60h |  | 3,600 |  | PD |
| 169 | 1.3.3.3.4.1.4.2 | **Detector Head** | 52.45d? | 2010-02-23 A | 2010-05-06 |  | 4% | 50.12d? | 181.97d |  |  | 180h | 8h | 10,800 | 480 |  |
| 170 | 1.3.3.3.4.1.4.2.1 | **Mount** | 6d? | 2010-02-23 A | 2010-03-03 |  | 17% | 5d? | 154.67d |  |  | 48h | 8h | 2,880 | 480 |  |
| 171 | 1.3.3.3.4.1.4.2.1.1 | Interface Specification | 1d? | 2010-02-23 A | 2010-02-24 A | 167 | 100% |  |  |  | ME - TBD | 8h | 8h | 480 | 480 | PD |
| 172 | 1.3.3.3.4.1.4.2.1.2 | Mechanical Model | 5d? | 2010-02-24 | 2010-03-03 | 171 |  |  | 154.67d | 0d | ME - TBD | 40h |  | 2,400 |  | PD |
| 173 | 1.3.3.3.4.1.4.2.2 | **Focus Mechanism** | 42.45d? | 2010-03-03 | 2010-04-30 |  |  |  | 154.67d |  |  | 100h |  | 6,000 |  |  |
| 174 | 1.3.3.3.4.1.4.2.2.1 | Interface Specification | 2.5d? | 2010-03-03 | 2010-03-30 | 172 |  |  | 154.67d | 0d | ME - TBD | 20h |  | 1,200 |  | PD |
| 175 | 1.3.3.3.4.1.4.2.2.2 | Mechanical Model | 10d? | 2010-03-30 | 2010-04-30 | 174 |  |  | 154.67d | 0d | ME - TBD | 80h |  | 4,800 |  | PD |
| 176 | 1.3.3.3.4.1.4.2.3 | **Cooling Interface** | 4d? | 2010-04-30 | 2010-05-06 |  |  |  | 181.97d |  |  | 32h |  | 1,920 |  |  |
| 177 | 1.3.3.3.4.1.4.2.3.1 | Interface Specification | 1d? | 2010-04-30 | 2010-05-03 | 175 |  |  | 181.97d | 0d | ME - TBD | 8h |  | 480 |  | PD |
| 178 | 1.3.3.3.4.1.4.2.3.2 | Mechanical Model | 3d? | 2010-05-03 | 2010-05-06 | 177 |  |  | 181.97d |  | ME - TBD | 24h |  | 1,440 |  | PD |
| 179 | 1.3.3.3.4.2 | **Warm Assemblies** | 53.5d? | 2010-01-25 A | 2010-04-08 |  | 5% | 50.61d? | 201.92d |  |  | 280h |  | 16,880 |  |  |
| 180 | 1.3.3.3.4.2.1 | **Dewar Shell** | 53.5d? | 2010-01-25 A | 2010-04-08 |  | 7% | 49.95d? | 201.92d |  |  | 228h |  | 13,760 |  |  |
| 181 | 1.3.3.3.4.2.1.1 | Interface Specification | 2.78d? | 2010-01-26 A | 2010-01-29 | 183 | 50% | 1.39d? | 27.35d | 0d | ME - Bob Weber [90%] | 20h |  | 1,200 |  | PD |
| 182 | 1.3.3.3.4.2.1.2 | Mechanical Model | 22.22d? | 2010-01-29 | 2010-03-02 | 181 |  |  | 27.35d | 13.5d | ME - Bob Weber [90%] | 160h |  | 9,600 |  | PD |
| 183 | 1.3.3.3.4.2.1.3 | Window Specifications | 1d? | 2010-01-25 A | 2010-01-26 | 153 | 50% | 0.5d? | 0d |  | OE - Optical Engineer 2 | 8h |  | 560 |  | PD |
| 184 | 1.3.3.3.4.2.1.4 | External Connections | 2.5d? | 2010-04-06 | 2010-04-08 | 185 |  |  | 201.92d |  | ME - Bob Weber; Electronics Engineer | 40h |  | 2,400 |  | PD |
| 185 | 1.3.3.3.4.2.2 | Vacuum System Requirements | 1.5d? | 2010-04-05 | 2010-04-06 | 186 |  |  | 201.92d | 0d | ME - Bob Weber | 12h |  | 720 |  | PD |
| 186 | 1.3.3.3.4.2.3 | Cryogenic System Requirements | 5d? | 2010-03-29 | 2010-04-02 | 182, 149 |  |  | 201.92d | 0d | ME - Bob Weber | 40h |  | 2,400 |  | PD |

| ID | WBS | Task | Duration | Start | Finish | Predecessors | Total slack | Free slack | Resources | Work | Cost | Text1 |
| --- | --- | --- | --- | --- | --- | --- | --- | --- | --- | --- | --- | --- |
| 187 | 1.3.3.3.5 | **Electronics** | 11.25d? | 2010-04-30 | 2010-05-18 |  | 156.47d |  |  | 144h | 8,856 |  |
| 188 | 1.3.3.3.5.1 | **Motion Control** | 7.5d? | 2010-04-30 | 2010-05-12 |  | 156.47d |  |  | 84h | 5,256 |  |
| 189 | 1.3.3.3.5.1.1 | Requirements | 5d? | 2010-04-30 | 2010-05-07 | 159, 163, 175 | 156.47d | 0d | Electronics Engineer; Software Engineer; ME - Jim Bell; Sean Adkins | 64h | 4,056 | PD |
| 190 | 1.3.3.3.5.1.2 | Initial Design | 2.5d? | 2010-05-07 | 2010-05-12 | 189 | 156.47d | 0d | Electronics Engineer | 20h | 1,200 | PD |
| 191 | 1.3.3.3.5.2 | Power Control | 1.25d? | 2010-05-12 | 2010-05-13 | 190 | 156.47d | 0d | Electronics Engineer; Software Engineer | 20h | 1,200 | PD |
| 192 | 1.3.3.3.5.3 | Pressure Monitoring | 1.25d? | 2010-05-13 | 2010-05-14 | 191 | 156.47d | 0d | Electronics Engineer; Software Engineer | 20h | 1,200 | PD |
| 193 | 1.3.3.3.5.4 | Temperature Monitoring and Control | 1.25d? | 2010-05-14 | 2010-05-18 | 192 | 161.77d | 0d | Electronics Engineer; Software Engineer | 20h | 1,200 | PD |
| 194 | 1.3.3.3.6 | **Software** | 14.55d? | 2010-04-30 | 2010-05-21 |  | 154.67d |  |  | 184h | 9,620 |  |
| 195 | 1.3.3.3.6.1 | Detector Control | 3d? | 2010-05-11 | 2010-05-14 | 200 | 172.97d | 0d | Software Engineer | 24h | 1,440 | PD |
| 196 | 1.3.3.3.6.2 | Global Server | 3d? | 2010-05-14 | 2010-05-19 | 195 | 172.97d |  | Software Engineer | 24h | 1,440 | PD |
| 197 | 1.3.3.3.6.3 | Motion Control | 2.5d? | 2010-04-30 | 2010-05-05 | 159, 163, 175 | 154.67d | 0d | Software Engineer | 20h | 1,200 | PD |
| 198 | 1.3.3.3.6.4 | Power Control | 1d? | 2010-05-05 | 2010-05-06 | 197 | 154.67d | 0d | Software Engineer | 8h | 480 | PD |
| 199 | 1.3.3.3.6.5 | Pressure Monitoring | 1d? | 2010-05-06 | 2010-05-07 | 198 | 154.67d | 0d | Software Engineer | 8h | 480 | PD |
| 200 | 1.3.3.3.6.6 | Temperature Monitoring and Control | 2.5d? | 2010-05-07 | 2010-05-11 | 149, 199 | 154.67d | 0d | Software Engineer | 20h | 1,200 | PD |
| 201 | 1.3.3.3.6.7 | User Interface Requirements | 3.33d? | 2010-05-11 | 2010-05-17 | 200 | 154.67d | 0d | Software Engineer; Sean Adkins; Instrument Scientist | 40h | 2,180 | PD |
| 202 | 1.3.3.3.6.8 | Data Reduction Tools | 5d? | 2010-05-04 | 2010-05-21 | 65FS-2w | 171.42d |  | Software Engineer; Instrument Scientist | 40h | 1,200 | PD |
| 203 | 1.3.3.3.7 | **Interfaces** | 49.15d? | 2010-03-29 | 2010-06-04 |  | 161.77d |  |  | 80h | 5,232 |  |
| 204 | 1.3.3.3.7.1 | Mechanical Interface Requirements | 2.5d? | 2010-03-29 | 2010-03-31 | 149 | 197.97d | 36.2d | ME - TBD | 20h | 1,200 | PD |
| 205 | 1.3.3.3.7.2 | Electronic Interface Requirements | 2.5d? | 2010-05-18 | 2010-05-20 | 193 | 161.77d | 0d | Electronics Engineer | 20h | 1,200 | PD |
| 206 | 1.3.3.3.7.3 | Software Interface Requirements | 2.5d? | 2010-05-17 | 2010-05-19 | 201 | 162.69d | 0.92d | Software Engineer | 20h | 1,200 | PD |
| 207 | 1.3.3.3.7.4 | Interface Control Document | 3.06d? | 2010-05-20 | 2010-06-04 | 204, 205, 206 | 161.77d |  | Sean Adkins [80%]; ME - Jim Bell [90%] | 20h | 1,632 |  |
| 208 | 1.3.3.3.8 | **Accessories** | 13d? | 2010-04-12 | 2010-04-28 |  | 174.92d |  |  | 104h | 6,240 |  |
| 209 | 1.3.3.3.8.1 | **Alignment Tooling** | 6.5d? | 2010-04-20 | 2010-04-28 |  | 187.92d |  |  | 52h | 3,120 |  |
| 210 | 1.3.3.3.8.1.1 | Initial Specifications | 1.5d? | 2010-04-20 | 2010-04-21 | 149, 214 | 187.92d | 0d | ME - TBD | 12h | 720 | PD |
| 211 | 1.3.3.3.8.1.2 | Mechanical Model | 5d? | 2010-04-22 | 2010-04-28 | 210 | 187.92d |  | ME - TBD | 40h | 2,400 | PD |

| ID | WBS | Task | Duration | Start | Finish | Predecessors | Total slack | Free slack | Resources | Work | Cost | Text1 |
| --- | --- | --- | --- | --- | --- | --- | --- | --- | --- | --- | --- | --- |
| 212 | 1.3.3.3.8.2 | **Assembly Tooling** | 6.5d? | 2010-04-12 | 2010-04-20 |  | 174.92d |  |  | 52h | 3,120 |  |
| 213 | 1.3.3.3.8.2.1 | Initial Specifications | 1.5d? | 2010-04-12 | 2010-04-13 | 149 | 174.92d | 0d | ME - TBD | 12h | 720 | PD |
| 214 | 1.3.3.3.8.2.2 | Mechanical Model | 5d? | 2010-04-13 | 2010-04-20 | 213 | 174.92d | 0d | ME - TBD | 40h | 2,400 | PD |
