# Imager_and_IFS_PD_Phase_v1_2_tracked_July09

Schedule from MS Project, 2009-05-01 to 2011-02-04, costs in $, A marks actual dates.
CARA

## Calendars

- Standard: Mon-Fri 08:00-12:00, 13:00-17:00; Sat-Sun off.

## Resources

| Resource | Group | Rate |
| --- | --- | --- |
| Sean Adkins | WMKO | 87 |
| Instrument Scientist | UCLA |  |
| Science Team |  |  |
| ME - Jim Bell | WMKO | 60 |
| ME - TBD | UCLA | 60 |
| Electronics Engineer | UCLA | 60 |
| Software Engineer | TBD | 60 |
| OE - Optical Engineer 2 |  | 70 |
| WMKO Support Astronomer | WMKO | 57 |
| WMKO Software Staff | WMKO | 57 |
| WMKO Instrument Staff | WMKO | 57 |
| WMKO Electronics Staff | WMKO | 57 |
| ME - Bob Weber | CIT | 60 |
| OE - Sergey Panteleev |  | 70 |

## Schedule

| ID | WBS | Task | Type | Duration | Start | Finish | Predecessors | Complete | Remaining | Total slack | Free slack | Constraint | Resources | Work | Actual work | Cost | Actual cost | Text1 |
| --- | --- | --- | --- | --- | --- | --- | --- | --- | --- | --- | --- | --- | --- | --- | --- | --- | --- | --- |
| 1 | 0 | **Milestones** |  | 293.76d? | 2009-05-01 | 2010-06-16 |  |  |  | 166.65d |  |  |  |  |  |  |  |  |
| 2 | 0.1 | Project Start | milestone | 0d? | 2009-05-01 | 2009-05-01 |  |  |  | 298.91d | 0d |  |  |  |  |  |  | PD |
| 3 | 0.2 | Imager Preliminary Design Review | milestone | 0d? | 2010-06-16 | 2010-06-16 | 62FS-1d |  |  | 166.65d |  |  |  |  |  |  |  | PD |
| 4 | 0.3 | IFS System Design Review | milestone | 0d | 2010-04-05 | 2010-04-05 | 118FS-1d |  |  | 218.87d |  |  |  |  |  |  |  |  |
| 5 | 1 | **Near-IR Imager and IFS** |  | 436.41d? | 2009-06-04 A | 2011-02-04 |  | 3% | 421.49d? | 0d |  |  |  | 7974.4h | 38.4h | 447,011.03 | 3,340.8 |  |
| 6 | 1.1 | **Management** |  | 377.5d? | 2009-06-04 A | 2010-11-15 |  | 4% | 363.62d? | 58.91d |  |  |  | 1260.4h | 38.4h | 81,944 | 3,340.8 |  |
| 7 | 1.1.1 | **Monthly Reports** |  | 371d | 2009-06-05 A | 2010-11-05 |  | 17% | 309.17d | 64.41d |  |  |  | 115.2h | 19.2h | 10,022.4 | 1,670.4 |  |
| 8 | 1.1.1.1 | Monthly Reports 1 |  | 1d | 2009-06-05 A | 2009-06-05 A |  | 100% |  |  |  | start no earlier than 2009-06-05 | Sean Adkins [80%] | 6.4h | 6.4h | 556.8 | 556.8 |  |
| 9 | 1.1.1.2 | Monthly Reports 2 |  | 1d | 2009-07-06 A | 2009-07-06 A |  | 100% |  |  |  | start no earlier than 2009-07-05 | Sean Adkins [80%] | 6.4h | 6.4h | 556.8 | 556.8 |  |
| 10 | 1.1.1.3 | Monthly Reports 3 |  | 1d | 2009-08-05 A | 2009-08-05 A |  | 100% |  |  |  | start no earlier than 2009-08-05 | Sean Adkins [80%] | 6.4h | 6.4h | 556.8 | 556.8 |  |
| 11 | 1.1.1.4 | Monthly Reports 4 |  | 1d | 2009-09-07 | 2009-09-07 |  |  |  | 368.41d |  | start no earlier than 2009-09-05 | Sean Adkins [80%] | 6.4h |  | 556.8 |  |  |
| 12 | 1.1.1.5 | Monthly Reports 5 |  | 1d | 2009-10-05 | 2009-10-05 |  |  |  | 348.41d |  | start no earlier than 2009-10-05 | Sean Adkins [80%] | 6.4h |  | 556.8 |  |  |
| 13 | 1.1.1.6 | Monthly Reports 6 |  | 1d | 2009-11-05 | 2009-11-05 |  |  |  | 325.41d |  | start no earlier than 2009-11-05 | Sean Adkins [80%] | 6.4h |  | 556.8 |  |  |
| 14 | 1.1.1.7 | Monthly Reports 7 |  | 1d | 2009-12-07 | 2009-12-07 |  |  |  | 303.41d |  | start no earlier than 2009-12-05 | Sean Adkins [80%] | 6.4h |  | 556.8 |  |  |
| 15 | 1.1.1.8 | Monthly Reports 8 |  | 1d | 2010-01-05 | 2010-01-05 |  |  |  | 282.41d |  | start no earlier than 2010-01-05 | Sean Adkins [80%] | 6.4h |  | 556.8 |  |  |
| 16 | 1.1.1.9 | Monthly Reports 9 |  | 1d | 2010-02-05 | 2010-02-05 |  |  |  | 259.41d |  | start no earlier than 2010-02-05 | Sean Adkins [80%] | 6.4h |  | 556.8 |  |  |
| 17 | 1.1.1.10 | Monthly Reports 10 |  | 1d | 2010-03-05 | 2010-03-05 |  |  |  | 239.41d |  | start no earlier than 2010-03-05 | Sean Adkins [80%] | 6.4h |  | 556.8 |  |  |
| 18 | 1.1.1.11 | Monthly Reports 11 |  | 1d | 2010-04-05 | 2010-04-05 |  |  |  | 218.41d |  | start no earlier than 2010-04-05 | Sean Adkins [80%] | 6.4h |  | 556.8 |  |  |
| 19 | 1.1.1.12 | Monthly Reports 12 |  | 1d | 2010-05-05 | 2010-05-05 |  |  |  | 196.41d |  | start no earlier than 2010-05-05 | Sean Adkins [80%] | 6.4h |  | 556.8 |  |  |
| 20 | 1.1.1.13 | Monthly Reports 13 |  | 1d | 2010-06-07 | 2010-06-07 |  |  |  | 173.41d |  | start no earlier than 2010-06-05 | Sean Adkins [80%] | 6.4h |  | 556.8 |  |  |
| 21 | 1.1.1.14 | Monthly Reports 14 |  | 1d | 2010-07-05 | 2010-07-05 |  |  |  | 153.41d |  | start no earlier than 2010-07-05 | Sean Adkins [80%] | 6.4h |  | 556.8 |  |  |
| 22 | 1.1.1.15 | Monthly Reports 15 |  | 1d | 2010-08-05 | 2010-08-05 |  |  |  | 130.41d |  | start no earlier than 2010-08-05 | Sean Adkins [80%] | 6.4h |  | 556.8 |  |  |
| 23 | 1.1.1.16 | Monthly Reports 16 |  | 1d | 2010-09-06 | 2010-09-06 |  |  |  | 108.41d |  | start no earlier than 2010-09-05 | Sean Adkins [80%] | 6.4h |  | 556.8 |  |  |
| 24 | 1.1.1.17 | Monthly Reports 17 |  | 1d | 2010-10-05 | 2010-10-05 |  |  |  | 87.41d |  | start no earlier than 2010-10-05 | Sean Adkins [80%] | 6.4h |  | 556.8 |  |  |
| 25 | 1.1.1.18 | Monthly Reports 18 |  | 1d | 2010-11-05 | 2010-11-05 |  |  |  | 64.41d |  | start no earlier than 2010-11-05 | Sean Adkins [80%] | 6.4h |  | 556.8 |  |  |

| ID | WBS | Task | Duration | Start | Finish | Predecessors | Complete | Remaining | Total slack | Constraint | Resources | Work | Actual work | Cost | Actual cost | Text1 | Text2 |
| --- | --- | --- | --- | --- | --- | --- | --- | --- | --- | --- | --- | --- | --- | --- | --- | --- | --- |
| 26 | 1.1.2 | **Project Meetings** | 304.5d | 2009-09-15 | 2010-11-15 |  |  |  | 58.91d |  |  | 425.2h |  | 24,381.6 |  |  |  |
| 27 | 1.1.2.1 | Project Meetings 1 | 4h | 2009-09-15 | 2009-09-15 |  |  |  | 362.91d | start no earlier than 2009-09-15 | Sean Adkins [80%]; Instrument Scientist [70%]; OE - Optical Engineer 2 [90%]; ME - Jim Bell [90%]; ME - TBD [90%]; Software Engineer [90%]; WMKO Support Astronomer; WMKO Electronics Staff | 28.4h |  | 1,634.4 |  |  |  |
| 28 | 1.1.2.2 | Project Meetings 2 | 4h | 2009-10-15 | 2009-10-15 |  |  |  | 340.91d | start no earlier than 2009-10-15 | Sean Adkins [80%]; Instrument Scientist [70%]; ME - TBD [90%]; OE - Optical Engineer 2 [90%]; Software Engineer [90%]; WMKO Support Astronomer; WMKO Electronics Staff; ME - Jim Bell | 28.8h |  | 1,658.4 |  |  |  |
| 29 | 1.1.2.3 | Project Meetings 3 | 4h | 2009-11-16 | 2009-11-16 |  |  |  | 318.91d | start no earlier than 2009-11-15 | Sean Adkins [80%]; Instrument Scientist [70%]; ME - TBD [90%]; OE - Optical Engineer 2 [90%]; Software Engineer [90%]; WMKO Support Astronomer; WMKO Electronics Staff; ME - Jim Bell | 28.8h |  | 1,658.4 |  |  |  |
| 30 | 1.1.2.4 | Project Meetings 4 | 116h | 2009-12-15 | 2010-01-04 |  |  |  | 283.91d | start no earlier than 2009-12-15 | Sean Adkins [80%]; Instrument Scientist [70%]; ME - TBD [90%]; OE - Optical Engineer 2 [90%]; Software Engineer [90%]; WMKO Support Astronomer; WMKO Electronics Staff; ME - Jim Bell | 28.8h |  | 1,658.4 |  |  |  |
| 31 | 1.1.2.5 | Project Meetings 5 | 4h | 2010-01-15 | 2010-01-15 |  |  |  | 274.91d | start no earlier than 2010-01-15 | Sean Adkins [80%]; Instrument Scientist [70%]; ME - TBD [90%]; OE - Optical Engineer 2 [90%]; Software Engineer [90%]; WMKO Support Astronomer; WMKO Electronics Staff; ME - Jim Bell | 28.8h |  | 1,658.4 |  |  |  |
| 32 | 1.1.2.6 | Project Meetings 6 | 4h | 2010-02-15 | 2010-02-15 |  |  |  | 253.91d | start no earlier than 2010-02-15 | Sean Adkins [80%]; Instrument Scientist [70%]; ME - TBD [90%]; OE - Optical Engineer 2 [90%]; Software Engineer [90%]; WMKO Support Astronomer; WMKO Electronics Staff; ME - Jim Bell | 28.8h |  | 1,658.4 |  |  |  |
| 33 | 1.1.2.7 | Project Meetings 7 | 4h | 2010-03-15 | 2010-03-15 |  |  |  | 233.91d | start no earlier than 2010-03-15 | Sean Adkins [80%]; Instrument Scientist [70%]; ME - TBD [90%]; OE - Optical Engineer 2 [90%]; Software Engineer [90%]; WMKO Support Astronomer; WMKO Electronics Staff; ME - Jim Bell | 25.6h |  | 1,380 |  |  |  |
| 34 | 1.1.2.8 | Project Meetings 8 | 4h | 2010-04-15 | 2010-04-15 |  |  |  | 210.91d | start no earlier than 2010-04-15 | Sean Adkins [80%]; Instrument Scientist [70%]; ME - Jim Bell [90%]; ME - TBD [90%]; OE - Optical Engineer 2 [90%]; Software Engineer [90%]; WMKO Support Astronomer; WMKO Electronics Staff | 28.4h |  | 1,634.4 |  |  |  |
| 35 | 1.1.2.9 | Project Meetings 9 | 4h | 2010-05-17 | 2010-05-17 |  |  |  | 188.91d | start no earlier than 2010-05-15 | Sean Adkins [80%]; Instrument Scientist [70%]; ME - Jim Bell [90%]; ME - TBD [90%]; OE - Optical Engineer 2 [90%]; Software Engineer [90%]; WMKO Support Astronomer; WMKO Electronics Staff | 28.4h |  | 1,634.4 |  |  |  |
| 36 | 1.1.2.10 | Project Meetings 10 | 4h | 2010-06-15 | 2010-06-15 |  |  |  | 167.91d | start no earlier than 2010-06-15 | Sean Adkins [80%]; Instrument Scientist [70%]; ME - Jim Bell [90%]; ME - TBD [90%]; OE - Optical Engineer 2 [90%]; Software Engineer [90%]; WMKO Support Astronomer; WMKO Electronics Staff | 28.4h |  | 1,634.4 |  |  |  |
| 37 | 1.1.2.11 | Project Meetings 11 | 4h | 2010-07-15 | 2010-07-15 |  |  |  | 145.91d | start no earlier than 2010-07-15 | Sean Adkins [80%]; Instrument Scientist [70%]; ME - Jim Bell [90%]; ME - TBD [90%]; OE - Optical Engineer 2 [90%]; Software Engineer [90%]; WMKO Support Astronomer; WMKO Electronics Staff | 28.4h |  | 1,634.4 |  |  |  |
| 38 | 1.1.2.12 | Project Meetings 12 | 4h | 2010-08-16 | 2010-08-16 |  |  |  | 123.91d | start no earlier than 2010-08-15 | Sean Adkins [80%]; Instrument Scientist [70%]; ME - Jim Bell [90%]; ME - TBD [90%]; OE - Optical Engineer 2 [90%]; Software Engineer [90%]; WMKO Support Astronomer; WMKO Electronics Staff | 28.4h |  | 1,634.4 |  |  |  |
| 39 | 1.1.2.13 | Project Meetings 13 | 4h | 2010-09-15 | 2010-09-15 |  |  |  | 101.91d | start no earlier than 2010-09-15 | Sean Adkins [80%]; Instrument Scientist [70%]; ME - Jim Bell [90%]; ME - TBD [90%]; OE - Optical Engineer 2 [90%]; Software Engineer [90%]; WMKO Support Astronomer; WMKO Electronics Staff | 28.4h |  | 1,634.4 |  |  |  |
| 40 | 1.1.2.14 | Project Meetings 14 | 4h | 2010-10-15 | 2010-10-15 |  |  |  | 79.91d | start no earlier than 2010-10-15 | Sean Adkins [80%]; Instrument Scientist [70%]; ME - Jim Bell [90%]; ME - TBD [90%]; OE - Optical Engineer 2 [90%]; Software Engineer [90%]; WMKO Support Astronomer; WMKO Electronics Staff | 28.4h |  | 1,634.4 |  |  |  |
| 41 | 1.1.2.15 | Project Meetings 15 | 4h | 2010-11-15 | 2010-11-15 |  |  |  | 58.91d | start no earlier than 2010-11-15 | Sean Adkins [80%]; Instrument Scientist [70%]; ME - Jim Bell [90%]; ME - TBD [90%]; OE - Optical Engineer 2 [90%]; Software Engineer [90%]; WMKO Support Astronomer; WMKO Electronics Staff | 28.4h |  | 1,634.4 |  |  |  |
| 42 | 1.1.3 | System Engineering Management Plan | 12.5d | 2010-02-15 | 2010-03-03 |  |  |  | 241.84d | start no earlier than 2010-02-14 | Sean Adkins [20%] | 20h |  | 1,740 |  | PD | IFS |
| 43 | 1.1.4 | Proposals to Fund Future Phases (ATI, MRI would be early 2010) | 43d? | 2010-05-03 | 2010-06-30 |  |  |  | 156.41d | start no earlier than 2010-05-02 | Sean Adkins [11.6%] | 40h |  | 3,480 |  | PD |  |
| 44 | 1.1.5 | Cost Review | 25d? | 2010-03-12 | 2010-04-27 | 153 |  |  | 202.79d |  | Sean Adkins [20%] | 40h |  | 3,480 |  | PD |  |
| 45 | 1.1.6 | **Project Plan Maintenance** | 328d | 2009-06-04 A | 2010-09-06 |  | 33% | 218.67d | 108.41d |  |  | 38.4h | 12.8h | 3,340.8 | 1,113.6 |  |  |
| 46 | 1.1.6.1 | Project Plan Maintenance 1 | 1d | 2009-06-04 A | 2009-06-04 A |  | 100% |  |  | start no earlier than 2009-06-04 | Sean Adkins [80%] | 6.4h | 6.4h | 556.8 | 556.8 |  |  |
| 47 | 1.1.6.2 | Project Plan Maintenance 2 | 1d | 2009-09-04 A | 2009-09-04 A |  | 100% |  |  | start no earlier than 2009-09-04 | Sean Adkins [80%] | 6.4h | 6.4h | 556.8 | 556.8 |  |  |
| 48 | 1.1.6.3 | Project Plan Maintenance 3 | 1d | 2009-12-04 | 2009-12-04 |  |  |  | 304.41d | start no earlier than 2009-12-04 | Sean Adkins [80%] | 6.4h |  | 556.8 |  |  |  |
| 49 | 1.1.6.4 | Project Plan Maintenance 4 | 1d | 2010-03-04 | 2010-03-04 |  |  |  | 240.41d | start no earlier than 2010-03-04 | Sean Adkins [80%] | 6.4h |  | 556.8 |  |  |  |
| 50 | 1.1.6.5 | Project Plan Maintenance 5 | 1d | 2010-06-04 | 2010-06-04 |  |  |  | 174.41d | start no earlier than 2010-06-04 | Sean Adkins [80%] | 6.4h |  | 556.8 |  |  |  |
| 51 | 1.1.6.6 | Project Plan Maintenance 6 | 1d | 2010-09-06 | 2010-09-06 |  |  |  | 108.41d | start no earlier than 2010-09-04 | Sean Adkins [80%] | 6.4h |  | 556.8 |  |  |  |

| ID | WBS | Task | Duration | Start | Finish | Predecessors | Complete | Remaining | Total slack | Free slack | Constraint | Resources | Work | Actual work | Cost | Actual cost | Text1 |
| --- | --- | --- | --- | --- | --- | --- | --- | --- | --- | --- | --- | --- | --- | --- | --- | --- | --- |
| 52 | 1.1.7 | **Budget Maintenance** | 348d | 2009-06-04 A | 2010-10-04 |  | 11% | 309.33d | 88.41d |  |  |  | 57.6h | 6.4h | 5,011.2 | 556.8 |  |
| 53 | 1.1.7.1 | Budget Maintenance 1 | 1d | 2009-06-04 A | 2009-06-04 A |  | 100% |  |  |  | start no earlier than 2009-06-04 | Sean Adkins [80%] | 6.4h | 6.4h | 556.8 | 556.8 |  |
| 54 | 1.1.7.2 | Budget Maintenance 2 | 1d | 2009-08-04 | 2009-08-04 |  |  |  | 392.41d |  | start no earlier than 2009-08-04 | Sean Adkins [80%] | 6.4h |  | 556.8 |  |  |
| 55 | 1.1.7.3 | Budget Maintenance 3 | 1d | 2009-10-05 | 2009-10-05 |  |  |  | 348.41d |  | start no earlier than 2009-10-04 | Sean Adkins [80%] | 6.4h |  | 556.8 |  |  |
| 56 | 1.1.7.4 | Budget Maintenance 4 | 1d | 2009-12-04 | 2009-12-04 |  |  |  | 304.41d |  | start no earlier than 2009-12-04 | Sean Adkins [80%] | 6.4h |  | 556.8 |  |  |
| 57 | 1.1.7.5 | Budget Maintenance 5 | 1d | 2010-02-04 | 2010-02-04 |  |  |  | 260.41d |  | start no earlier than 2010-02-04 | Sean Adkins [80%] | 6.4h |  | 556.8 |  |  |
| 58 | 1.1.7.6 | Budget Maintenance 6 | 1d | 2010-04-05 | 2010-04-05 |  |  |  | 218.41d |  | start no earlier than 2010-04-04 | Sean Adkins [80%] | 6.4h |  | 556.8 |  |  |
| 59 | 1.1.7.7 | Budget Maintenance 7 | 1d | 2010-06-04 | 2010-06-04 |  |  |  | 174.41d |  | start no earlier than 2010-06-04 | Sean Adkins [80%] | 6.4h |  | 556.8 |  |  |
| 60 | 1.1.7.8 | Budget Maintenance 8 | 1d | 2010-08-04 | 2010-08-04 |  |  |  | 131.41d |  | start no earlier than 2010-08-04 | Sean Adkins [80%] | 6.4h |  | 556.8 |  |  |
| 61 | 1.1.7.9 | Budget Maintenance 9 | 1d | 2010-10-04 | 2010-10-04 |  |  |  | 88.41d |  | start no earlier than 2010-10-04 | Sean Adkins [80%] | 6.4h |  | 556.8 |  |  |
| 62 | 1.1.8 | Preliminary Design Review | 28.18d | 2010-04-16 | 2010-06-17 | 69, 197, 219, 153FS-2w |  |  | 165.65d | 0d |  | Sean Adkins; Instrument Scientist; ME - Jim Bell; ME - TBD; Software Engineer; Electronics Engineer; WMKO Support Astronomer; WMKO Software Staff; WMKO Instrument Staff; WMKO Electronics Staff; OE - Optical Engineer 2 | 524h |  | 30,488 |  | PD |
| 63 | 1.2 | **Science** | 150.16d? | 2009-09-18 | 2010-04-16 |  |  |  | 210.25d |  |  |  | 224h |  | 8,178 |  |  |
| 64 | 1.2.1 | **Science Team Meetings** | 76.5d? | 2009-09-18 | 2010-01-04 |  |  |  | 283.91d |  |  |  | 64h |  | 2,088 |  |  |
| 65 | 1.2.1.1 | Meeting 1 | 1.5d? | 2009-09-18 | 2009-09-21 | 2FS+5mo |  |  | 358.91d |  |  | Sean Adkins; Instrument Scientist; Science Team | 32h |  | 1,044 |  | PD |
| 66 | 1.2.1.2 | Meeting 2 | 2d? | 2009-12-11 | 2010-01-04 | 2FS+8mo |  |  | 283.91d |  |  | Sean Adkins; Instrument Scientist; Science Team | 32h |  | 1,044 |  | PD |
| 67 | 1.2.2 | **Common Observing Operations Concept Document** | 150.16d? | 2009-09-18 | 2010-04-16 |  |  |  | 210.25d |  |  |  | 160h |  | 6,090 |  |  |
| 68 | 1.2.2.1 | Initial Draft | 19.75d? | 2009-09-18 | 2009-10-15 | 2FS+5mo |  |  | 340.66d |  |  | Sean Adkins [20%]; Instrument Scientist [20%]; Science Team [20%] | 70h |  | 2,610 |  | PD |
| 69 | 1.2.2.2 | Final Version | 31.09d? | 2010-03-03 | 2010-04-16 | 187, 206FS-2w |  |  | 165.65d | 0d |  | Sean Adkins [20%]; Instrument Scientist [20%]; Science Team [20%] | 90h |  | 3,480 |  | PD |
| 70 | 1.3 | **Instrument Design and Fabrication** | 426.41d? | 2009-06-18 A | 2011-02-04 |  | 4% | 411.2d? | 0d |  |  |  | 6490h |  | 356,889.03 |  |  |
| 71 | 1.3.1 | **AO System to Instrument Interface Definitions** | 14d? | 2009-09-14 | 2009-10-02 |  |  |  | 350.4d |  |  |  | 136h |  | 9,708 |  | PD |
| 72 | 1.3.1.1 | Optical | 2.6d? | 2009-09-14 | 2009-09-16 | 80 |  |  | 350.4d | 0d |  | Sean Adkins; OE - Optical Engineer 2 | 28h |  | 2,096 |  | PD |
| 73 | 1.3.1.2 | Mechanical | 3.5d? | 2009-09-16 | 2009-09-24 | 72 |  |  | 350.4d | 0d |  | Sean Adkins; ME - Jim Bell | 28h |  | 1,896 |  | PD |
| 74 | 1.3.1.3 | Electronic/Electrical | 1.5d? | 2009-09-24 | 2009-09-25 | 73 |  |  | 350.4d | 0d |  | Sean Adkins | 12h |  | 1,044 |  | PD |
| 75 | 1.3.1.4 | Software | 2.5d? | 2009-09-25 | 2009-09-30 | 74 |  |  | 350.4d | 0d |  | Sean Adkins; Software Engineer | 28h |  | 1,896 |  | PD |
| 76 | 1.3.1.5 | Alignment and Calibration Concept for Instrument on AO System | 2d? | 2009-09-30 | 2009-10-02 | 75 |  |  | 350.4d |  |  | Sean Adkins; OE - Optical Engineer 2; ME - Jim Bell | 40h |  | 2,776 |  | PD |

Notes:
- 62: Effort for team members includes writing PD report.

| ID | WBS | Task | Duration | Start | Finish | Predecessors | Complete | Remaining | Total slack | Free slack | Constraint | Resources | Work | Cost | Text1 | Text2 |
| --- | --- | --- | --- | --- | --- | --- | --- | --- | --- | --- | --- | --- | --- | --- | --- | --- |
| 77 | 1.3.2 | **Shared Facilities** | 121.49d? | 2009-06-18 A | 2009-12-04 |  | 16% | 101.51d? | 304.92d |  |  |  | 216h | 15,706 |  |  |
| 78 | 1.3.2.1 | **AO System** | 121.49d? | 2009-06-18 A | 2009-12-04 |  | 20% | 97.21d? | 304.92d |  |  |  | 176h | 13,036 |  |  |
| 79 | 1.3.2.1.1 | **High Order AO Relay** | 79.5d? | 2009-06-18 A | 2009-10-07 |  | 45% | 43.35d? | 346.91d |  |  |  | 68h | 5,916 |  |  |
| 80 | 1.3.2.1.1.1 | Design Liason | 38.47d? | 2009-06-18 A | 2009-09-14 |  | 60% | 15.29d? | 304.92d | 0d | start no earlier than 2009-06-18 | Sean Adkins [16.1%] | 48h | 4,176 | PD |  |
| 81 | 1.3.2.1.1.2 | RTC and Control Liason | 12.5d? | 2009-09-21 | 2009-10-07 | 80 |  |  | 346.91d |  |  | Sean Adkins [20%] | 20h | 1,740 | PD |  |
| 82 | 1.3.2.1.2 | **ADC** | 35d? | 2009-09-21 | 2009-11-06 |  |  |  | 324.41d |  |  |  | 56h | 4,464 |  |  |
| 83 | 1.3.2.1.2.1 | Requirements Liason | 20d? | 2009-09-21 | 2009-10-16 | 80 |  |  | 324.41d | 0d |  | Sean Adkins [20%] | 32h | 2,784 | PD |  |
| 84 | 1.3.2.1.2.2 | Design Liason | 15d? | 2009-10-19 | 2009-11-06 | 83 |  |  | 324.41d |  |  | OE - Optical Engineer 2 [20%] | 24h | 1,680 | PD |  |
| 85 | 1.3.2.1.3 | **Calibration Faciltiy** | 30d? | 2009-10-23 | 2009-12-04 |  |  |  | 304.92d |  |  |  | 52h | 2,656 |  |  |
| 86 | 1.3.2.1.3.1 | Requirements Liason | 10d? | 2009-10-23 | 2009-11-06 | 90 |  |  | 304.92d | 0d |  | Sean Adkins [20%]; Instrument Scientist [20%]; OE - Optical Engineer 2 [20%] | 28h | 1,536 | PD |  |
| 87 | 1.3.2.1.3.2 | Design Liason | 20d? | 2009-11-06 | 2009-12-04 | 86 |  |  | 304.92d |  |  | Instrument Scientist [10%]; OE - Optical Engineer 2 [10%] | 24h | 1,120 | PD |  |
| 88 | 1.3.2.2 | **Nasmyth Enclosure** | 29.48d? | 2009-09-14 | 2009-10-23 |  |  |  | 304.92d |  |  |  | 40h | 2,670 |  |  |
| 89 | 1.3.2.2.1 | Requirements Liason | 12.5d? | 2009-09-14 | 2009-10-06 | 80 |  |  | 304.92d | 0d |  | Sean Adkins [20%]; ME - Jim Bell [20%] | 20h | 1,470 | PD |  |
| 90 | 1.3.2.2.2 | Design Liason | 12.5d? | 2009-10-06 | 2009-10-23 | 89 |  |  | 304.92d | 0d |  | ME - Jim Bell [20%] | 20h | 1,200 | PD |  |
| 91 | 1.3.3 | **Instrument** | 418.41d? | 2009-06-30 A | 2011-02-04 |  | 1% | 412.57d? | 0d |  |  |  | 6138h | 331,475.03 |  |  |
| 92 | 1.3.3.1 | **IFS System Design Phase** | 151.54d? | 2009-09-07 | 2010-04-06 |  |  |  | 0d |  |  |  | 1762h | 86,375.69 | PD | IFS |
| 93 | 1.3.3.1.1 | **IFS Performance Budgets** | 56.34d | 2009-09-07 | 2009-11-24 |  |  |  | 0d |  |  |  | 260h | 11,576.17 | PD | IFS |
| 94 | 1.3.3.1.1.1 | Throughput | 6.67d | 2009-09-07 | 2009-09-15 | 140 |  |  | 0d |  |  | Sean Adkins [50%]; Instrument Scientist [50%]; OE - Sergey Panteleev [50%] | 60h | 2,446.67 | PD | IFS |
| 95 | 1.3.3.1.1.2 | Background | 5d | 2009-09-15 | 2009-10-01 | 94 |  |  | 0d |  |  | Sean Adkins [50%]; Instrument Scientist [50%]; OE - Sergey Panteleev [50%] | 40h | 1,980 | PD | IFS |
| 96 | 1.3.3.1.1.3 | Wavefront error | 6.67d | 2009-10-01 | 2009-10-09 | 95 |  |  | 0d |  |  | Sean Adkins [50%]; Instrument Scientist [50%]; OE - Sergey Panteleev [50%] | 60h | 2,446.67 | PD | IFS |
| 97 | 1.3.3.1.1.4 | Spectroscopic performance | 14.27d | 2009-10-09 | 2009-11-17 | 96 |  |  | 0d |  |  | Sean Adkins [50%]; Instrument Scientist [50%]; OE - Sergey Panteleev [38%] | 80h | 3,390.34 | PD | IFS |
| 98 | 1.3.3.1.1.5 | Size and mass | 5.21d | 2009-11-17 | 2009-11-24 | 97 |  |  | 313.06d |  |  | Sean Adkins [50%]; ME - Jim Bell [38%] | 20h | 1,312.5 | PD | IFS |
| 99 | 1.3.3.1.2 | **Trade Studies** | 93.95d | 2009-11-17 | 2010-03-29 |  |  |  | 224.32d |  |  |  | 420h | 19,087.58 | PD | IFS |
| 100 | 1.3.3.1.2.1 | FOV and spatial sampling | 14.31d | 2009-11-17 | 2009-12-17 | 97 |  |  | 224.32d | 0d |  | Sean Adkins [33.3%]; Instrument Scientist [50%]; OE - Sergey Panteleev [33%] | 90h | 4,461.53 | PD | IFS |
| 101 | 1.3.3.1.2.2 | Wavelength coverage and spatial sampling | 15.39d | 2009-12-17 | 2010-01-19 | 97, 100 |  |  | 224.32d | 0d |  | Sean Adkins [50%]; Instrument Scientist [50%]; OE - Sergey Panteleev [33%] | 70h | 3,202.78 | PD | IFS |
| 102 | 1.3.3.1.2.3 | Optimization of image slicing formats and spectrograph formats | 20.25d | 2010-01-19 | 2010-02-26 | 97, 101 |  |  | 224.32d | 0d |  | Sean Adkins [33.3%]; Instrument Scientist [50%]; OE - Sergey Panteleev [33%]; ME - TBD [50%] | 110h | 5,784.33 | PD | IFS |
| 103 | 1.3.3.1.2.4 | Separate or combined capability above and below 1 micron | 8.78d | 2010-02-26 | 2010-03-11 | 102 |  |  | 224.32d | 0d |  | Sean Adkins [50%]; Instrument Scientist [50%]; OE - Sergey Panteleev [33%] | 70h | 2,640.8 | PD | IFS |
| 104 | 1.3.3.1.2.5 | Wavefront error allocations | 7.17d | 2010-03-11 | 2010-03-22 | 103 |  |  | 224.32d | 0d |  | Sean Adkins [50%]; Instrument Scientist [50%]; OE - Sergey Panteleev [33%] | 50h | 1,532.99 | PD | IFS |
| 105 | 1.3.3.1.2.6 | Trade study report | 4.21d | 2010-03-22 | 2010-03-29 | 104 |  |  | 224.32d |  |  | Sean Adkins [16.7%]; Instrument Scientist [50%]; OE - Sergey Panteleev [50%] | 30h | 1,465.15 | PD | IFS |

| ID | WBS | Task | Duration | Start | Finish | Predecessors | Complete | Remaining | Total slack | Free slack | Constraint | Resources | Work | Cost | Text1 | Text2 |
| --- | --- | --- | --- | --- | --- | --- | --- | --- | --- | --- | --- | --- | --- | --- | --- | --- |
| 106 | 1.3.3.1.3 | **Conceptual Designs** | 94.79d? | 2009-11-17 | 2010-03-29 |  |  |  | 0d |  |  |  | 980h | 50,071.46 | PD | IFS |
| 107 | 1.3.3.1.3.1 | Development of design options | 46.07d | 2009-11-17 | 2010-01-20 | 97 |  |  | 0d |  |  | Sean Adkins [50%]; Instrument Scientist [50%]; OE - Sergey Panteleev [17%]; ME - TBD [50%] | 380h | 16,556.94 | PD | IFS |
| 108 | 1.3.3.1.3.2 | Evaluation of design options | 9.74d? | 2010-01-20 | 2010-02-03 | 107 |  |  | 0d |  |  | Sean Adkins [50%]; Instrument Scientist [50%]; OE - Sergey Panteleev [50%]; ME - TBD [50%] | 140h | 7,678.05 | PD | IFS |
| 109 | 1.3.3.1.3.3 | Calibration and alignment issues | 5.58d? | 2010-02-03 | 2010-02-11 | 108 |  |  | 0d |  |  | Sean Adkins [50%]; Instrument Scientist [50%]; OE - Sergey Panteleev [50%]; ME - TBD [50%] | 60h | 3,122.46 | PD | IFS |
| 110 | 1.3.3.1.3.4 | Downselect of conceptual design | 5d? | 2010-02-11 | 2010-02-18 | 109 |  |  | 0d |  |  | Sean Adkins [50%]; Instrument Scientist [50%]; OE - Sergey Panteleev [50%]; ME - TBD [50%] | 80h | 4,340 | PD | IFS |
| 111 | 1.3.3.1.3.5 | Revised performance budgets | 4d? | 2010-02-18 | 2010-02-24 | 110 |  |  | 243.5d | 0d |  | Sean Adkins [50%]; Instrument Scientist [50%]; OE - Sergey Panteleev [50%] | 40h | 1,816 | PD | IFS |
| 112 | 1.3.3.1.3.6 | Performance budget report | 3.75d? | 2010-02-24 | 2010-03-01 | 111 |  |  | 243.5d |  |  | Sean Adkins [50%]; OE - Sergey Panteleev [50%] | 30h | 2,355 | PD | IFS |
| 113 | 1.3.3.1.3.7 | Performance estimates | 4.38d? | 2010-02-18 | 2010-03-03 | 110 |  |  | 0d |  |  | Sean Adkins [50%]; Instrument Scientist [50%]; OE - Sergey Panteleev [50%]; ME - TBD [50%] | 60h | 3,308.13 | PD | IFS |
| 114 | 1.3.3.1.3.8 | System requirements document | 4.38d? | 2010-03-03 | 2010-03-09 | 113 |  |  | 0d |  |  | Sean Adkins [50%]; Instrument Scientist [50%]; OE - Sergey Panteleev [50%]; ME - TBD [50%] | 70h | 3,797.5 | PD | IFS |
| 115 | 1.3.3.1.3.9 | System design manual | 7.28d? | 2010-03-09 | 2010-03-29 | 114 |  |  | 0d |  |  | Sean Adkins [75%]; Instrument Scientist [75%]; OE - Sergey Panteleev [75%]; ME - TBD [75%] | 120h | 7,097.38 | PD | IFS |
| 116 | 1.3.3.1.4 | **System Design Review** | 5.61d? | 2010-03-29 | 2010-04-06 | 113 |  |  | 0d |  |  |  | 102h | 5,640.47 | PD | IFS |
| 117 | 1.3.3.1.4.1 | System design report | 4.38d? | 2010-03-29 | 2010-04-05 | 115 |  |  | 0d |  |  | Sean Adkins [50%]; Instrument Scientist [50%]; OE - Sergey Panteleev [50%]; ME - TBD [50%] | 70h | 3,797.5 | PD | IFS |
| 118 | 1.3.3.1.4.2 | System design review meeting | 1.23d? | 2010-04-05 | 2010-04-06 | 117 |  |  | 0d |  |  | Sean Adkins [80%]; Instrument Scientist [80%]; OE - Sergey Panteleev [90%]; ME - TBD [90%] | 32h | 1,842.97 | PD | IFS |
| 119 | 1.3.3.2 | **IFS Preliminary Design Phase** | 217.87d? | 2010-04-06 | 2011-02-04 |  |  |  | 0d |  |  |  | 2148h | 107,197.9 | DD | IFS |
| 120 | 1.3.3.2.1 | Initial AO system to instrument interface definitions | 5.39d? | 2010-04-06 | 2010-04-15 | 118 |  |  | 0d |  |  | Sean Adkins [50%]; OE - Sergey Panteleev [50%]; ME - Jim Bell [50%] | 60h | 4,340 | DD | IFS |
| 121 | 1.3.3.2.2 | Alignment and calibration concept | 8.19d? | 2010-04-15 | 2010-04-27 | 120 |  |  | 0d |  |  | Sean Adkins [50%]; Instrument Scientist [50%]; OE - Sergey Panteleev [50%]; ME - Jim Bell [50%] | 100h | 4,669.23 | DD | IFS |
| 122 | 1.3.3.2.3 | Optical design | 91.7d? | 2010-04-27 | 2010-09-02 | 121 |  |  | 0d |  |  | Sean Adkins [50%]; Instrument Scientist [50%]; OE - Sergey Panteleev [50%] | 760h | 29,114.83 | DD | IFS |
| 123 | 1.3.3.2.4 | Mechanical design | 160.82d? | 2010-06-10 | 2011-01-21 | 122FS-60d |  |  | 0d |  |  | Sean Adkins [50%]; ME - Jim Bell [50%] | 680h | 41,880 | DD | IFS |
| 124 | 1.3.3.2.5 | Electronic design | 30d? | 2010-11-25 | 2011-01-06 | 122FS+60d |  |  | 10.82d | 0d |  | Sean Adkins [50%]; Electronics Engineer [50%] | 140h | 8,940 | DD | IFS |
| 125 | 1.3.3.2.6 | Software design | 23.53d? | 2010-11-25 | 2010-12-28 | 124SS |  |  | 17.29d |  |  | Sean Adkins [50%]; Instrument Scientist [50%]; Software Engineer [50%] | 200h | 6,670.59 | DD | IFS |
| 126 | 1.3.3.2.7 | Preliminary design report | 8.89d? | 2011-01-21 | 2011-02-03 | 120, 123, 124, 125 |  |  | 0d |  |  | Sean Adkins [50%]; Instrument Scientist [50%]; ME - Jim Bell [50%]; Electronics Engineer [50%]; OE - Sergey Panteleev [50%]; Software Engineer [50%] | 160h | 8,782.24 | DD | IFS |
| 127 | 1.3.3.2.8 | Preliminary design review meeting | 1.27d? | 2011-02-03 | 2011-02-04 | 126 |  |  | 0d |  |  | Sean Adkins [80%]; Instrument Scientist [80%]; ME - Jim Bell [90%]; Electronics Engineer [90%]; OE - Sergey Panteleev [90%]; Software Engineer [90%] | 48h | 2,801.01 | DD | IFS |
| 128 | 1.3.3.3 | **Near-IR Imager and IFS Preliminary Design** | 210.9d? | 2009-06-30 A | 2010-04-20 |  | 4% | 202.4d? | 207.5d |  |  |  | 2228h | 137,901.44 |  |  |
| 129 | 1.3.3.3.1 | **Imager Trade Studies** | 68.5d? | 2009-06-30 A | 2009-10-02 |  | 15% | 57.96d? | 349.91d |  |  |  | 104h | 6,189.44 | PD |  |
| 130 | 1.3.3.3.1.1 | Imager Wavefront Error | 4.75d? | 2009-09-07 | 2009-10-02 | 140 |  |  | 337.91d | 0d |  | Sean Adkins [80%]; Science Team; OE - Optical Engineer 2 [90%] | 40h | 2,421.44 | PD |  |
| 131 | 1.3.3.3.1.2 | Imager Pixel Scale | 7.1d? | 2009-06-30 A | 2009-09-15 |  | 30% | 4.97d? | 362.77d |  | start no earlier than 2009-06-30 | Sean Adkins [62.5%]; Science Team [62.5%]; OE - Optical Engineer 2 [62.5%] | 48h | 3,072 | PD |  |
| 132 | 1.3.3.3.1.3 | Imager Short Wavelength Cut-off | 2d? | 2009-09-07 | 2009-09-09 | 140 |  |  | 353.34d | 0d |  | Sean Adkins; Science Team | 16h | 696 | PD |  |

| ID | WBS | Task | Duration | Start | Finish | Predecessors | Complete | Remaining | Total slack | Free slack | Resources | Work | Cost | Text1 |
| --- | --- | --- | --- | --- | --- | --- | --- | --- | --- | --- | --- | --- | --- | --- |
| 133 | 1.3.3.3.2 | **Imager Performance Budgets** | 168.15d? | 2009-07-28 A | 2010-03-19 |  | 1% | 166.9d? | 230.25d |  |  | 124h | 9,268 | PD |
| 134 | 1.3.3.3.2.1 | Imager Sensitivity | 1d? | 2009-07-28 A | 2009-09-10 | 132 | 20% | 0.8d? | 353.14d | 0d | Sean Adkins; OE - Optical Engineer 2 | 16h | 1,256 | PD |
| 135 | 1.3.3.3.2.2 | Imager Background | 4.5d? | 2009-09-10 | 2009-09-16 | 134 |  |  | 353.14d | 0d | Sean Adkins [25%]; OE - Optical Engineer 2 [25%] | 16h | 1,256 | PD |
| 136 | 1.3.3.3.2.3 | Imager Companion Sensitivity | 4.5d? | 2009-09-16 | 2009-09-29 | 135 |  |  | 353.14d |  | Sean Adkins; OE - Optical Engineer 2 | 36h | 2,724 | PD |
| 137 | 1.3.3.3.2.4 | Imager Wavefront Error | 12d? | 2009-10-02 | 2009-10-20 | 130 |  |  | 337.91d |  | Sean Adkins [25%]; OE - Optical Engineer 2 [25%] | 32h | 2,376 | PD |
| 138 | 1.3.3.3.2.5 | Imager Size and Mass | 4.8d? | 2010-03-12 | 2010-03-19 | 153 |  |  | 230.25d |  | Sean Adkins [41.7%]; ME - Jim Bell [41.7%] | 24h | 1,656 | PD |
| 139 | 1.3.3.3.3 | **Optical Design** | 84.65d? | 2009-07-28 A | 2009-11-23 |  | 17% | 70.42d? | 313.75d |  |  | 416h | 28,080 |  |
| 140 | 1.3.3.3.3.1 | Initial Optical Design | 18.1d? | 2009-07-28 A | 2009-09-04 |  | 50% | 9.05d? | 0d |  | Sean Adkins [31.1%]; OE - Optical Engineer 2 [90%] | 60h | 4,880 |  |
| 141 | 1.3.3.3.3.2 | **Optical Modeling** | 40.65d? | 2009-09-21 | 2009-11-16 |  |  |  | 165.65d |  |  | 292h | 19,356 |  |
| 142 | 1.3.3.3.3.2.1 | Fore Optics | 6d? | 2009-09-21 | 2009-10-01 | 140FS+2w |  |  | 165.65d | 0d | OE - Optical Engineer 2; Sean Adkins; Instrument Scientist | 56h | 3,632 | PD |
| 143 | 1.3.3.3.3.2.2 | Lyot Stop | 2d? | 2009-10-01 | 2009-10-05 | 142 |  |  | 165.65d | 0d | OE - Optical Engineer 2; Sean Adkins; Instrument Scientist | 24h | 1,468 | PD |
| 144 | 1.3.3.3.3.2.3 | Coronagraph | 1.5d? | 2009-10-05 | 2009-10-16 | 143 |  |  | 165.65d | 0d | OE - Optical Engineer 2; ME - Jim Bell; Instrument Scientist | 28h | 1,320 | PD |
| 145 | 1.3.3.3.3.2.4 | Imager Camera | 20d? | 2009-10-16 | 2009-11-13 | 144 |  |  | 165.65d | 0d | OE - Optical Engineer 2 | 160h | 11,200 | PD |
| 146 | 1.3.3.3.3.2.5 | IFS Fold Mirror | 1.25d? | 2009-11-13 | 2009-11-16 | 145 |  |  | 313.75d | 0d | Sean Adkins [80%]; OE - Optical Engineer 2 [90%]; ME - Jim Bell [90%] | 24h | 1,736 |  |
| 147 | 1.3.3.3.3.3 | Preliminary Design Performance Analysis | 5d? | 2009-11-16 | 2009-11-23 | 146 |  |  | 313.75d |  | OE - Optical Engineer 2; Sean Adkins; Instrument Scientist | 64h | 3,844 | PD |
| 148 | 1.3.3.3.4 | **Dewar** | 121.95d? | 2009-10-01 | 2010-03-22 |  |  |  | 196.15d |  |  | 1072h | 64,416 |  |
| 149 | 1.3.3.3.4.1 | **Cold Assemblies** | 115.45d? | 2009-10-01 | 2010-03-12 |  |  |  | 196.15d |  |  | 792h | 47,536 |  |
| 150 | 1.3.3.3.4.1.1 | **Dewar Internal Structure** | 18.5d? | 2010-02-15 | 2010-03-12 |  |  |  | 165.65d |  |  | 188h | 11,280 |  |
| 151 | 1.3.3.3.4.1.1.1 | Interface Specification | 1d? | 2010-02-15 | 2010-02-16 | 183 |  |  | 165.65d | 0d | ME - Jim Bell | 8h | 480 | PD |
| 152 | 1.3.3.3.4.1.1.2 | Mechanical Model | 10d? | 2010-02-16 | 2010-03-02 | 151 |  |  | 165.65d | 0d | ME - Jim Bell | 80h | 4,800 | PD |
| 153 | 1.3.3.3.4.1.1.3 | FEA | 7.5d? | 2010-03-02 | 2010-03-12 | 152, 187 |  |  | 200.45d | 0d | ME - Jim Bell | 60h | 3,600 | PD |
| 154 | 1.3.3.3.4.1.1.4 | Thermal Analysis | 5d? | 2010-03-02 | 2010-03-09 | 152 |  |  | 165.65d | 0d | ME - Jim Bell | 40h | 2,400 | PD |
| 155 | 1.3.3.3.4.1.2 | **Fore Optics** | 37d? | 2009-10-01 | 2009-11-23 |  |  |  | 241.93d |  |  | 188h | 11,400 |  |
| 156 | 1.3.3.3.4.1.2.1 | **Input Baffle & Coronagraph** | 26.5d? | 2009-10-16 | 2009-11-23 |  |  |  | 211.43d |  |  | 52h | 3,120 |  |
| 157 | 1.3.3.3.4.1.2.1.1 | Interface Specification | 1.5d? | 2009-10-16 | 2009-10-19 | 144 |  |  | 231.43d | 20d | ME - Jim Bell | 12h | 720 | PD |
| 158 | 1.3.3.3.4.1.2.1.2 | Mechanical Model | 5d? | 2009-11-16 | 2009-11-23 | 157, 172 |  |  | 211.43d | 0d | ME - Jim Bell | 40h | 2,400 | PD |

Notes:
- 158: Thermal analysis included in dewar structure thermal analysis task

| ID | WBS | Task | Duration | Start | Finish | Predecessors | Total slack | Free slack | Resources | Work | Cost | Text1 |
| --- | --- | --- | --- | --- | --- | --- | --- | --- | --- | --- | --- | --- |
| 159 | 1.3.3.3.4.1.2.2 | **Re-imager** | 6.5d? | 2009-10-01 | 2009-10-12 |  | 344d |  |  | 60h | 3,680 |  |
| 160 | 1.3.3.3.4.1.2.2.1 | Interface Specification | 1.5d? | 2009-10-01 | 2009-10-05 | 142 | 344d | 0d | OE - Optical Engineer 2; ME - Jim Bell | 20h | 1,280 | PD |
| 161 | 1.3.3.3.4.1.2.2.2 | Mechanical Model | 5d? | 2009-10-05 | 2009-10-12 | 160 | 344d |  | ME - Jim Bell | 40h | 2,400 | PD |
| 162 | 1.3.3.3.4.1.2.3 | **Adjustable Lyot Stop** | 9d? | 2009-10-05 | 2009-10-16 |  | 263.1d |  |  | 76h | 4,600 |  |
| 163 | 1.3.3.3.4.1.2.3.1 | Interface Specification | 1.5d? | 2009-10-05 | 2009-10-07 | 143 | 263.1d | 0d | OE - Optical Engineer 2; ME - Jim Bell | 16h | 1,000 | PD |
| 164 | 1.3.3.3.4.1.2.3.2 | Mechanical Model | 7.5d? | 2009-10-07 | 2009-10-16 | 163 | 263.1d | 76.95d | ME - Jim Bell | 60h | 3,600 | PD |
| 165 | 1.3.3.3.4.1.3 | **Filter Wheels** | 19.76d? | 2009-11-13 | 2009-12-11 |  | 223.83d |  |  | 156h | 9,176 |  |
| 166 | 1.3.3.3.4.1.3.1 | **Mechanism** | 19.76d? | 2009-11-13 | 2009-12-11 |  | 223.83d |  |  | 132h | 7,920 |  |
| 167 | 1.3.3.3.4.1.3.1.1 | Interface Specification | 1.67d? | 2009-11-13 | 2009-11-17 | 145 | 223.83d | 0d | ME - Bob Weber [90%] | 12h | 720 | PD |
| 168 | 1.3.3.3.4.1.3.1.2 | Mechanical Model | 16.67d? | 2009-11-18 | 2009-12-11 | 169 | 223.83d | 37.69d | ME - Bob Weber [90%] | 120h | 7,200 | PD |
| 169 | 1.3.3.3.4.1.3.2 | Filter Specifications | 1.43d? | 2009-11-17 | 2009-11-18 | 167 | 223.83d | 0d | Sean Adkins; OE - Optical Engineer 2; Instrument Scientist [70%] | 24h | 1,256 | PD |
| 170 | 1.3.3.3.4.1.4 | **Imager** | 61.45d? | 2009-11-13 | 2010-02-08 |  | 165.65d |  |  | 260h | 15,680 |  |
| 171 | 1.3.3.3.4.1.4.1 | **Camera** | 9d? | 2009-11-13 | 2009-11-26 |  | 165.65d |  |  | 80h | 4,880 |  |
| 172 | 1.3.3.3.4.1.4.1.1 | Interface Specification | 1.5d? | 2009-11-13 | 2009-11-16 | 145 | 165.65d | 0d | OE - Optical Engineer 2; ME - Jim Bell | 20h | 1,280 | PD |
| 173 | 1.3.3.3.4.1.4.1.2 | Mechanical Model | 7.5d? | 2009-11-16 | 2009-11-26 | 172 | 165.65d | 0d | ME - Jim Bell | 60h | 3,600 | PD |
| 174 | 1.3.3.3.4.1.4.2 | **Detector Head** | 52.45d? | 2009-11-26 | 2010-02-08 |  | 165.65d |  |  | 180h | 10,800 |  |
| 175 | 1.3.3.3.4.1.4.2.1 | **Mount** | 6d? | 2009-11-26 | 2009-12-04 |  | 165.65d |  |  | 48h | 2,880 |  |
| 176 | 1.3.3.3.4.1.4.2.1.1 | Interface Specification | 1d? | 2009-11-26 | 2009-11-27 | 173 | 165.65d | 0d | ME - TBD | 8h | 480 | PD |
| 177 | 1.3.3.3.4.1.4.2.1.2 | Mechanical Model | 5d? | 2009-11-27 | 2009-12-04 | 176 | 165.65d | 0d | ME - TBD | 40h | 2,400 | PD |
| 178 | 1.3.3.3.4.1.4.2.2 | **Focus Mechanism** | 42.45d? | 2009-12-04 | 2010-02-02 |  | 165.65d |  |  | 100h | 6,000 |  |
| 179 | 1.3.3.3.4.1.4.2.2.1 | Interface Specification | 2.5d? | 2009-12-04 | 2009-12-31 | 177 | 165.65d | 0d | ME - TBD | 20h | 1,200 | PD |
| 180 | 1.3.3.3.4.1.4.2.2.2 | Mechanical Model | 10d? | 2009-12-31 | 2010-02-02 | 179 | 165.65d | 0d | ME - TBD | 80h | 4,800 | PD |
| 181 | 1.3.3.3.4.1.4.2.3 | **Cooling Interface** | 4d? | 2010-02-02 | 2010-02-08 |  | 165.65d |  |  | 32h | 1,920 |  |
| 182 | 1.3.3.3.4.1.4.2.3.1 | Interface Specification | 1d? | 2010-02-02 | 2010-02-03 | 180 | 165.65d | 0d | ME - TBD | 8h | 480 | PD |
| 183 | 1.3.3.3.4.1.4.2.3.2 | Mechanical Model | 3d? | 2010-02-03 | 2010-02-08 | 182 | 165.65d | 0d | ME - TBD | 24h | 1,440 | PD |

| ID | WBS | Task | Duration | Start | Finish | Predecessors | Total slack | Free slack | Resources | Work | Cost | Text1 |
| --- | --- | --- | --- | --- | --- | --- | --- | --- | --- | --- | --- | --- |
| 184 | 1.3.3.3.4.2 | **Warm Assemblies** | 84.95d? | 2009-11-23 | 2010-03-22 |  | 211.43d |  |  | 280h | 16,880 |  |
| 185 | 1.3.3.3.4.2.1 | **Dewar Shell** | 84.95d? | 2009-11-23 | 2010-03-22 |  | 211.43d |  |  | 228h | 13,760 |  |
| 186 | 1.3.3.3.4.2.1.1 | Interface Specification | 2.78d? | 2009-11-24 | 2009-11-27 | 188 | 211.43d | 0d | ME - Bob Weber [90%] | 20h | 1,200 | PD |
| 187 | 1.3.3.3.4.2.1.2 | Mechanical Model | 22.22d? | 2009-11-27 | 2009-12-29 | 186 | 211.43d | 44.95d | ME - Bob Weber [90%] | 160h | 9,600 | PD |
| 188 | 1.3.3.3.4.2.1.3 | Window Specifications | 1d? | 2009-11-23 | 2009-11-24 | 158 | 211.43d | 0d | OE - Optical Engineer 2 | 8h | 560 | PD |
| 189 | 1.3.3.3.4.2.1.4 | External Connections | 2.5d? | 2010-03-18 | 2010-03-22 | 190 | 228.55d |  | ME - Bob Weber; Electronics Engineer | 40h | 2,400 | PD |
| 190 | 1.3.3.3.4.2.2 | Vacuum System Requirements | 1.5d? | 2010-03-16 | 2010-03-18 | 191 | 228.55d | 0d | ME - Bob Weber | 12h | 720 | PD |
| 191 | 1.3.3.3.4.2.3 | Cryogenic System Requirements | 5d? | 2010-03-09 | 2010-03-16 | 187, 154 | 228.55d | 0d | ME - Bob Weber | 40h | 2,400 | PD |
| 192 | 1.3.3.3.5 | **Electronics** | 11.25d? | 2010-02-02 | 2010-02-18 |  | 207.95d |  |  | 144h | 8,856 |  |
| 193 | 1.3.3.3.5.1 | **Motion Control** | 7.5d? | 2010-02-02 | 2010-02-12 |  | 207.95d |  |  | 84h | 5,256 |  |
| 194 | 1.3.3.3.5.1.1 | Requirements | 5d? | 2010-02-02 | 2010-02-09 | 164, 168, 180 | 207.95d | 0d | Electronics Engineer; Software Engineer; ME - Jim Bell; Sean Adkins | 64h | 4,056 | PD |
| 195 | 1.3.3.3.5.1.2 | Initial Design | 2.5d? | 2010-02-09 | 2010-02-12 | 194 | 207.95d | 0d | Electronics Engineer | 20h | 1,200 | PD |
| 196 | 1.3.3.3.5.2 | Power Control | 1.25d? | 2010-02-12 | 2010-02-15 | 195 | 207.95d | 0d | Electronics Engineer; Software Engineer | 20h | 1,200 | PD |
| 197 | 1.3.3.3.5.3 | Pressure Monitoring | 1.25d? | 2010-02-15 | 2010-02-16 | 196 | 207.95d | 0d | Electronics Engineer; Software Engineer | 20h | 1,200 | PD |
| 198 | 1.3.3.3.5.4 | Temperature Monitoring and Control | 1.25d? | 2010-02-16 | 2010-02-18 | 197 | 238.36d | 0d | Electronics Engineer; Software Engineer | 20h | 1,200 | PD |
| 199 | 1.3.3.3.6 | **Software** | 55.05d? | 2010-02-02 | 2010-04-20 |  | 186.15d |  |  | 184h | 9,620 |  |
| 200 | 1.3.3.3.6.1 | Detector Control | 3d? | 2010-03-12 | 2010-03-17 | 205 | 229.05d | 0d | Software Engineer | 24h | 1,440 | PD |
| 201 | 1.3.3.3.6.2 | Global Server | 3d? | 2010-03-17 | 2010-03-22 | 200 | 229.05d |  | Software Engineer | 24h | 1,440 | PD |
| 202 | 1.3.3.3.6.3 | Motion Control | 2.5d? | 2010-02-02 | 2010-02-05 | 164, 168, 180 | 186.15d | 0d | Software Engineer | 20h | 1,200 | PD |
| 203 | 1.3.3.3.6.4 | Power Control | 1d? | 2010-02-05 | 2010-02-08 | 202 | 186.15d | 0d | Software Engineer | 8h | 480 | PD |
| 204 | 1.3.3.3.6.5 | Pressure Monitoring | 1d? | 2010-02-08 | 2010-02-09 | 203 | 186.15d | 20.5d | Software Engineer | 8h | 480 | PD |
| 205 | 1.3.3.3.6.6 | Temperature Monitoring and Control | 2.5d? | 2010-03-09 | 2010-03-12 | 154, 204 | 165.65d | 0d | Software Engineer | 20h | 1,200 | PD |
| 206 | 1.3.3.3.6.7 | User Interface Requirements | 3.33d? | 2010-03-12 | 2010-03-17 | 205 | 165.65d | 0d | Software Engineer; Sean Adkins; Instrument Scientist | 40h | 2,180 | PD |
| 207 | 1.3.3.3.6.8 | Data Reduction Tools | 5d? | 2010-04-02 | 2010-04-20 | 69FS-2w | 207.5d |  | Software Engineer; Instrument Scientist | 40h | 1,200 | PD |

| ID | WBS | Task | Duration | Start | Finish | Predecessors | Total slack | Free slack | Resources | Work | Cost | Text1 |
| --- | --- | --- | --- | --- | --- | --- | --- | --- | --- | --- | --- | --- |
| 208 | 1.3.3.3.7 | **Interfaces** | 35.85d? | 2010-02-18 | 2010-04-08 |  | 215.46d |  |  | 80h | 5,232 |  |
| 209 | 1.3.3.3.7.1 | Mechanical Interface Requirements | 2.5d? | 2010-03-23 | 2010-03-25 | 154 | 215.46d | 0d | ME - TBD | 20h | 1,200 | PD |
| 210 | 1.3.3.3.7.2 | Electronic Interface Requirements | 2.5d? | 2010-02-18 | 2010-02-22 | 198 | 238.36d | 22.9d | Electronics Engineer | 20h | 1,200 | PD |
| 211 | 1.3.3.3.7.3 | Software Interface Requirements | 2.5d? | 2010-03-17 | 2010-03-22 | 206 | 218.77d | 3.31d | Software Engineer | 20h | 1,200 | PD |
| 212 | 1.3.3.3.7.4 | Interface Control Document | 3.06d? | 2010-03-25 | 2010-04-08 | 209, 210, 211 | 215.46d |  | Sean Adkins [80%]; ME - Jim Bell [90%] | 20h | 1,632 |  |
| 213 | 1.3.3.3.8 | **Accessories** | 13d? | 2010-03-23 | 2010-04-08 |  | 177.31d |  |  | 104h | 6,240 |  |
| 214 | 1.3.3.3.8.1 | **Alignment Tooling** | 6.5d? | 2010-03-31 | 2010-04-08 |  | 215.41d |  |  | 52h | 3,120 |  |
| 215 | 1.3.3.3.8.1.1 | Initial Specifications | 1.5d? | 2010-03-31 | 2010-04-01 | 154, 219 | 215.41d | 0d | ME - TBD | 12h | 720 | PD |
| 216 | 1.3.3.3.8.1.2 | Mechanical Model | 5d? | 2010-04-02 | 2010-04-08 | 215 | 215.41d |  | ME - TBD | 40h | 2,400 | PD |
| 217 | 1.3.3.3.8.2 | **Assembly Tooling** | 6.5d? | 2010-03-23 | 2010-03-31 |  | 177.31d |  |  | 52h | 3,120 |  |
| 218 | 1.3.3.3.8.2.1 | Initial Specifications | 1.5d? | 2010-03-23 | 2010-03-24 | 154 | 177.31d | 0d | ME - TBD | 12h | 720 | PD |
| 219 | 1.3.3.3.8.2.2 | Mechanical Model | 5d? | 2010-03-24 | 2010-03-31 | 218 | 177.31d | 0d | ME - TBD | 40h | 2,400 | PD |
