# Imager and IFS PD Phase v1_2

Schedule from MS Project, 2009-05-01 to 2010-12-28, costs in $, A marks actual dates.
CARA

## Calendars

- Standard: Mon-Fri 08:00-12:00, 13:00-17:00; Sat-Sun off.

## Resources

| Resource | Group | Rate |
| --- | --- | --- |
| Sean Adkins | WMKO | 87 |
| Instrument Scientist | UCLA |  |
| Science Team |  |  |
| ME - Jim Bell | WMKO | 60 |
| ME - John Canfield | UCLA | 60 |
| Electronics Engineer | UCLA | 60 |
| Software Engineer | UCLA | 60 |
| OE - Optical Engineer 2 |  | 70 |
| WMKO Support Astronomer | WMKO | 57 |
| WMKO Software Staff | WMKO | 57 |
| WMKO Instrument Staff | WMKO | 57 |
| WMKO Electronics Staff | WMKO | 57 |
| ME - Bob Weber | CIT | 60 |
| OE - Sergey Panteleev |  | 70 |

## Schedule

| ID | WBS | Task | Type | Duration | Start | Finish | Predecessors | Complete | Remaining | Total slack | Constraint | Resources | Work | Cost | Text1 |
| --- | --- | --- | --- | --- | --- | --- | --- | --- | --- | --- | --- | --- | --- | --- | --- |
| 1 | 0 | **Milestones** |  | 303.1d? | 2009-05-01 | 2010-06-30 |  |  |  | 0d |  |  |  |  |  |
| 2 | 0.1 | Project Start | milestone | 0d? | 2009-05-01 | 2009-05-01 |  |  |  | 0d |  |  |  |  | PD |
| 3 | 0.2 | Imager Preliminary Design Review | milestone | 0d? | 2010-06-30 | 2010-06-30 | 65FS-1d |  |  | 129.15d |  |  |  |  | PD |
| 4 | 0.3 | IFS System Design Review | milestone | 0d | 2010-02-24 | 2010-02-24 | 121FS-1d |  |  | 218.87d |  |  |  |  |  |
| 5 | 1 | **Near-IR Imager and IFS** |  | 432.25d? | 2009-05-01 A | 2010-12-28 |  | 2% | 425.77d? | 0d |  |  | 8043.6h | 450,522.23 |  |
| 6 | 1.1 | **Management** |  | 379.5d? | 2009-06-02 | 2010-11-15 |  |  |  | 30.75d |  |  | 1345.6h | 86,847.2 |  |
| 7 | 1.1.1 | **Monthly Reports** |  | 371d | 2009-06-05 | 2010-11-05 |  |  |  | 36.25d |  |  | 115.2h | 10,022.4 |  |
| 8 | 1.1.1.1 | Monthly Reports 1 |  | 1d | 2009-06-05 | 2009-06-05 |  |  |  | 406.25d | start no earlier than 2009-06-05 | Sean Adkins [80%] | 6.4h | 556.8 |  |
| 9 | 1.1.1.2 | Monthly Reports 2 |  | 1d | 2009-07-06 | 2009-07-06 |  |  |  | 385.25d | start no earlier than 2009-07-05 | Sean Adkins [80%] | 6.4h | 556.8 |  |
| 10 | 1.1.1.3 | Monthly Reports 3 |  | 1d | 2009-08-05 | 2009-08-05 |  |  |  | 363.25d | start no earlier than 2009-08-05 | Sean Adkins [80%] | 6.4h | 556.8 |  |
| 11 | 1.1.1.4 | Monthly Reports 4 |  | 1d | 2009-09-07 | 2009-09-07 |  |  |  | 340.25d | start no earlier than 2009-09-05 | Sean Adkins [80%] | 6.4h | 556.8 |  |
| 12 | 1.1.1.5 | Monthly Reports 5 |  | 1d | 2009-10-05 | 2009-10-05 |  |  |  | 320.25d | start no earlier than 2009-10-05 | Sean Adkins [80%] | 6.4h | 556.8 |  |
| 13 | 1.1.1.6 | Monthly Reports 6 |  | 1d | 2009-11-05 | 2009-11-05 |  |  |  | 297.25d | start no earlier than 2009-11-05 | Sean Adkins [80%] | 6.4h | 556.8 |  |
| 14 | 1.1.1.7 | Monthly Reports 7 |  | 1d | 2009-12-07 | 2009-12-07 |  |  |  | 275.25d | start no earlier than 2009-12-05 | Sean Adkins [80%] | 6.4h | 556.8 |  |
| 15 | 1.1.1.8 | Monthly Reports 8 |  | 1d | 2010-01-05 | 2010-01-05 |  |  |  | 254.25d | start no earlier than 2010-01-05 | Sean Adkins [80%] | 6.4h | 556.8 |  |
| 16 | 1.1.1.9 | Monthly Reports 9 |  | 1d | 2010-02-05 | 2010-02-05 |  |  |  | 231.25d | start no earlier than 2010-02-05 | Sean Adkins [80%] | 6.4h | 556.8 |  |
| 17 | 1.1.1.10 | Monthly Reports 10 |  | 1d | 2010-03-05 | 2010-03-05 |  |  |  | 211.25d | start no earlier than 2010-03-05 | Sean Adkins [80%] | 6.4h | 556.8 |  |
| 18 | 1.1.1.11 | Monthly Reports 11 |  | 1d | 2010-04-05 | 2010-04-05 |  |  |  | 190.25d | start no earlier than 2010-04-05 | Sean Adkins [80%] | 6.4h | 556.8 |  |
| 19 | 1.1.1.12 | Monthly Reports 12 |  | 1d | 2010-05-05 | 2010-05-05 |  |  |  | 168.25d | start no earlier than 2010-05-05 | Sean Adkins [80%] | 6.4h | 556.8 |  |
| 20 | 1.1.1.13 | Monthly Reports 13 |  | 1d | 2010-06-07 | 2010-06-07 |  |  |  | 145.25d | start no earlier than 2010-06-05 | Sean Adkins [80%] | 6.4h | 556.8 |  |
| 21 | 1.1.1.14 | Monthly Reports 14 |  | 1d | 2010-07-05 | 2010-07-05 |  |  |  | 125.25d | start no earlier than 2010-07-05 | Sean Adkins [80%] | 6.4h | 556.8 |  |
| 22 | 1.1.1.15 | Monthly Reports 15 |  | 1d | 2010-08-05 | 2010-08-05 |  |  |  | 102.25d | start no earlier than 2010-08-05 | Sean Adkins [80%] | 6.4h | 556.8 |  |
| 23 | 1.1.1.16 | Monthly Reports 16 |  | 1d | 2010-09-06 | 2010-09-06 |  |  |  | 80.25d | start no earlier than 2010-09-05 | Sean Adkins [80%] | 6.4h | 556.8 |  |
| 24 | 1.1.1.17 | Monthly Reports 17 |  | 1d | 2010-10-05 | 2010-10-05 |  |  |  | 59.25d | start no earlier than 2010-10-05 | Sean Adkins [80%] | 6.4h | 556.8 |  |
| 25 | 1.1.1.18 | Monthly Reports 18 |  | 1d | 2010-11-05 | 2010-11-05 |  |  |  | 36.25d | start no earlier than 2010-11-05 | Sean Adkins [80%] | 6.4h | 556.8 |  |

| ID | WBS | Task | Duration | Start | Finish | Predecessors | Total slack | Constraint | Resources | Work | Cost | Text1 | Text2 |
| --- | --- | --- | --- | --- | --- | --- | --- | --- | --- | --- | --- | --- | --- |
| 26 | 1.1.2 | **Project Meetings** | 370.5d | 2009-06-15 | 2010-11-15 |  | 30.75d |  |  | 510.4h | 29,284.8 |  |  |
| 27 | 1.1.2.1 | Project Meetings 1 | 4h | 2009-06-15 | 2009-06-15 |  | 400.75d | start no earlier than 2009-06-15 | Sean Adkins [80%]; Instrument Scientist [70%]; OE - Optical Engineer 2 [90%]; ME - Jim Bell [90%]; ME - John Canfield [90%]; Software Engineer [90%]; WMKO Support Astronomer; WMKO Electronics Staff | 28.4h | 1,634.4 |  |  |
| 28 | 1.1.2.2 | Project Meetings 2 | 4h | 2009-07-15 | 2009-07-15 |  | 378.75d | start no earlier than 2009-07-15 | Sean Adkins [80%]; Instrument Scientist [70%]; ME - John Canfield [90%]; OE - Optical Engineer 2 [90%]; Software Engineer [90%]; WMKO Support Astronomer; WMKO Electronics Staff; ME - Jim Bell | 28.8h | 1,658.4 |  |  |
| 29 | 1.1.2.3 | Project Meetings 3 | 4h | 2009-08-17 | 2009-08-17 |  | 355.75d | start no earlier than 2009-08-15 | Sean Adkins [80%]; Instrument Scientist [70%]; ME - John Canfield [90%]; OE - Optical Engineer 2 [90%]; Software Engineer [90%]; WMKO Support Astronomer; WMKO Electronics Staff; ME - Jim Bell | 28.8h | 1,658.4 |  |  |
| 30 | 1.1.2.4 | Project Meetings 4 | 4h | 2009-09-15 | 2009-09-15 |  | 334.75d | start no earlier than 2009-09-15 | Sean Adkins [80%]; Instrument Scientist [70%]; ME - John Canfield [90%]; OE - Optical Engineer 2 [90%]; Software Engineer [90%]; WMKO Support Astronomer; WMKO Electronics Staff; ME - Jim Bell | 28.8h | 1,658.4 |  |  |
| 31 | 1.1.2.5 | Project Meetings 5 | 4h | 2009-10-15 | 2009-10-15 |  | 312.75d | start no earlier than 2009-10-15 | Sean Adkins [80%]; Instrument Scientist [70%]; ME - John Canfield [90%]; OE - Optical Engineer 2 [90%]; Software Engineer [90%]; WMKO Support Astronomer; WMKO Electronics Staff; ME - Jim Bell | 28.8h | 1,658.4 |  |  |
| 32 | 1.1.2.6 | Project Meetings 6 | 4h | 2009-11-16 | 2009-11-16 |  | 290.75d | start no earlier than 2009-11-15 | Sean Adkins [80%]; Instrument Scientist [70%]; ME - John Canfield [90%]; OE - Optical Engineer 2 [90%]; Software Engineer [90%]; WMKO Support Astronomer; WMKO Electronics Staff; ME - Jim Bell | 28.8h | 1,658.4 |  |  |
| 33 | 1.1.2.7 | Project Meetings 7 | 4h | 2009-12-15 | 2009-12-15 |  | 269.75d | start no earlier than 2009-12-15 | Sean Adkins [80%]; Instrument Scientist [70%]; ME - John Canfield [90%]; OE - Optical Engineer 2 [90%]; Software Engineer [90%]; WMKO Support Astronomer; WMKO Electronics Staff; ME - Jim Bell | 25.6h | 1,380 |  |  |
| 34 | 1.1.2.8 | Project Meetings 8 | 4h | 2010-01-15 | 2010-01-15 |  | 246.75d | start no earlier than 2010-01-15 | Sean Adkins [80%]; Instrument Scientist [70%]; ME - Jim Bell [90%]; ME - John Canfield [90%]; OE - Optical Engineer 2 [90%]; Software Engineer [90%]; WMKO Support Astronomer; WMKO Electronics Staff | 28.4h | 1,634.4 |  |  |
| 35 | 1.1.2.9 | Project Meetings 9 | 4h | 2010-02-15 | 2010-02-15 |  | 225.75d | start no earlier than 2010-02-15 | Sean Adkins [80%]; Instrument Scientist [70%]; ME - Jim Bell [90%]; ME - John Canfield [90%]; OE - Optical Engineer 2 [90%]; Software Engineer [90%]; WMKO Support Astronomer; WMKO Electronics Staff | 28.4h | 1,634.4 |  |  |
| 36 | 1.1.2.10 | Project Meetings 10 | 4h | 2010-03-15 | 2010-03-15 |  | 205.75d | start no earlier than 2010-03-15 | Sean Adkins [80%]; Instrument Scientist [70%]; ME - Jim Bell [90%]; ME - John Canfield [90%]; OE - Optical Engineer 2 [90%]; Software Engineer [90%]; WMKO Support Astronomer; WMKO Electronics Staff | 28.4h | 1,634.4 |  |  |
| 37 | 1.1.2.11 | Project Meetings 11 | 4h | 2010-04-15 | 2010-04-15 |  | 182.75d | start no earlier than 2010-04-15 | Sean Adkins [80%]; Instrument Scientist [70%]; ME - Jim Bell [90%]; ME - John Canfield [90%]; OE - Optical Engineer 2 [90%]; Software Engineer [90%]; WMKO Support Astronomer; WMKO Electronics Staff | 28.4h | 1,634.4 |  |  |
| 38 | 1.1.2.12 | Project Meetings 12 | 4h | 2010-05-17 | 2010-05-17 |  | 160.75d | start no earlier than 2010-05-15 | Sean Adkins [80%]; Instrument Scientist [70%]; ME - Jim Bell [90%]; ME - John Canfield [90%]; OE - Optical Engineer 2 [90%]; Software Engineer [90%]; WMKO Support Astronomer; WMKO Electronics Staff | 28.4h | 1,634.4 |  |  |
| 39 | 1.1.2.13 | Project Meetings 13 | 4h | 2010-06-15 | 2010-06-15 |  | 139.75d | start no earlier than 2010-06-15 | Sean Adkins [80%]; Instrument Scientist [70%]; ME - Jim Bell [90%]; ME - John Canfield [90%]; OE - Optical Engineer 2 [90%]; Software Engineer [90%]; WMKO Support Astronomer; WMKO Electronics Staff | 28.4h | 1,634.4 |  |  |
| 40 | 1.1.2.14 | Project Meetings 14 | 4h | 2010-07-15 | 2010-07-15 |  | 117.75d | start no earlier than 2010-07-15 | Sean Adkins [80%]; Instrument Scientist [70%]; ME - Jim Bell [90%]; ME - John Canfield [90%]; OE - Optical Engineer 2 [90%]; Software Engineer [90%]; WMKO Support Astronomer; WMKO Electronics Staff | 28.4h | 1,634.4 |  |  |
| 41 | 1.1.2.15 | Project Meetings 15 | 4h | 2010-08-16 | 2010-08-16 |  | 95.75d | start no earlier than 2010-08-15 | Sean Adkins [80%]; Instrument Scientist [70%]; ME - Jim Bell [90%]; ME - John Canfield [90%]; OE - Optical Engineer 2 [90%]; Software Engineer [90%]; WMKO Support Astronomer; WMKO Electronics Staff | 28.4h | 1,634.4 |  |  |
| 42 | 1.1.2.16 | Project Meetings 16 | 4h | 2010-09-15 | 2010-09-15 |  | 73.75d | start no earlier than 2010-09-15 | Sean Adkins [80%]; Instrument Scientist [70%]; ME - Jim Bell [90%]; ME - John Canfield [90%]; OE - Optical Engineer 2 [90%]; Software Engineer [90%]; WMKO Support Astronomer; WMKO Electronics Staff | 28.4h | 1,634.4 |  |  |
| 43 | 1.1.2.17 | Project Meetings 17 | 4h | 2010-10-15 | 2010-10-15 |  | 51.75d | start no earlier than 2010-10-15 | Sean Adkins [80%]; Instrument Scientist [70%]; ME - Jim Bell [90%]; ME - John Canfield [90%]; OE - Optical Engineer 2 [90%]; Software Engineer [90%]; WMKO Support Astronomer; WMKO Electronics Staff | 28.4h | 1,634.4 |  |  |
| 44 | 1.1.2.18 | Project Meetings 18 | 4h | 2010-11-15 | 2010-11-15 |  | 30.75d | start no earlier than 2010-11-15 | Sean Adkins [80%]; Instrument Scientist [70%]; ME - Jim Bell [90%]; ME - John Canfield [90%]; OE - Optical Engineer 2 [90%]; Software Engineer [90%]; WMKO Support Astronomer; WMKO Electronics Staff | 28.4h | 1,634.4 |  |  |
| 45 | 1.1.3 | System Engineering Management Plan | 12.5d | 2009-06-02 | 2009-06-22 | 2FS+20d | 395.69d |  | Sean Adkins [20%] | 20h | 1,740 | PD | IFS |
| 46 | 1.1.4 | Proposals to Fund Future Phases (ATI, MRI would be early 2010) | 43d? | 2009-09-02 | 2009-10-30 |  | 301.25d | start no earlier than 2009-09-02 | Sean Adkins [11.6%] | 40h | 3,480 | PD |  |
| 47 | 1.1.5 | Cost Review | 25d? | 2010-02-18 | 2010-04-05 | 156 | 190.54d |  | Sean Adkins [20%] | 40h | 3,480 | PD |  |
| 48 | 1.1.6 | **Project Plan Maintenance** | 328d | 2009-06-04 | 2010-09-06 |  | 80.25d |  |  | 38.4h | 3,340.8 |  |  |
| 49 | 1.1.6.1 | Project Plan Maintenance 1 | 1d | 2009-06-04 | 2009-06-04 |  | 377.18d | start no earlier than 2009-06-04 | Sean Adkins [80%] | 6.4h | 556.8 |  |  |
| 50 | 1.1.6.2 | Project Plan Maintenance 2 | 1d | 2009-09-04 | 2009-09-04 |  | 311.18d | start no earlier than 2009-09-04 | Sean Adkins [80%] | 6.4h | 556.8 |  |  |
| 51 | 1.1.6.3 | Project Plan Maintenance 3 | 1d | 2009-12-04 | 2009-12-04 |  | 246.18d | start no earlier than 2009-12-04 | Sean Adkins [80%] | 6.4h | 556.8 |  |  |
| 52 | 1.1.6.4 | Project Plan Maintenance 4 | 1d | 2010-03-04 | 2010-03-04 |  | 182.18d | start no earlier than 2010-03-04 | Sean Adkins [80%] | 6.4h | 556.8 |  |  |
| 53 | 1.1.6.5 | Project Plan Maintenance 5 | 1d | 2010-06-04 | 2010-06-04 |  | 116.18d | start no earlier than 2010-06-04 | Sean Adkins [80%] | 6.4h | 556.8 |  |  |
| 54 | 1.1.6.6 | Project Plan Maintenance 6 | 1d | 2010-09-06 | 2010-09-06 |  | 50.18d | start no earlier than 2010-09-04 | Sean Adkins [80%] | 6.4h | 556.8 |  |  |

| ID | WBS | Task | Duration | Start | Finish | Predecessors | Complete | Remaining | Total slack | Free slack | Constraint | Resources | Work | Cost | Text1 |
| --- | --- | --- | --- | --- | --- | --- | --- | --- | --- | --- | --- | --- | --- | --- | --- |
| 55 | 1.1.7 | **Budget Maintenance** | 348d | 2009-06-04 | 2010-10-04 |  |  |  | 60.25d |  |  |  | 57.6h | 5,011.2 |  |
| 56 | 1.1.7.1 | Budget Maintenance 1 | 1d | 2009-06-04 | 2009-06-04 |  |  |  | 377.18d |  | start no earlier than 2009-06-04 | Sean Adkins [80%] | 6.4h | 556.8 |  |
| 57 | 1.1.7.2 | Budget Maintenance 2 | 1d | 2009-08-04 | 2009-08-04 |  |  |  | 334.18d |  | start no earlier than 2009-08-04 | Sean Adkins [80%] | 6.4h | 556.8 |  |
| 58 | 1.1.7.3 | Budget Maintenance 3 | 1d | 2009-10-05 | 2009-10-05 |  |  |  | 290.18d |  | start no earlier than 2009-10-04 | Sean Adkins [80%] | 6.4h | 556.8 |  |
| 59 | 1.1.7.4 | Budget Maintenance 4 | 1d | 2009-12-04 | 2009-12-04 |  |  |  | 246.18d |  | start no earlier than 2009-12-04 | Sean Adkins [80%] | 6.4h | 556.8 |  |
| 60 | 1.1.7.5 | Budget Maintenance 5 | 1d | 2010-02-04 | 2010-02-04 |  |  |  | 202.18d |  | start no earlier than 2010-02-04 | Sean Adkins [80%] | 6.4h | 556.8 |  |
| 61 | 1.1.7.6 | Budget Maintenance 6 | 1d | 2010-04-05 | 2010-04-05 |  |  |  | 160.18d |  | start no earlier than 2010-04-04 | Sean Adkins [80%] | 6.4h | 556.8 |  |
| 62 | 1.1.7.7 | Budget Maintenance 7 | 1d | 2010-06-04 | 2010-06-04 |  |  |  | 116.18d |  | start no earlier than 2010-06-04 | Sean Adkins [80%] | 6.4h | 556.8 |  |
| 63 | 1.1.7.8 | Budget Maintenance 8 | 1d | 2010-08-04 | 2010-08-04 |  |  |  | 73.18d |  | start no earlier than 2010-08-04 | Sean Adkins [80%] | 6.4h | 556.8 |  |
| 64 | 1.1.7.9 | Budget Maintenance 9 | 1d | 2010-10-04 | 2010-10-04 |  |  |  | 30.18d |  | start no earlier than 2010-10-04 | Sean Adkins [80%] | 6.4h | 556.8 |  |
| 65 | 1.1.8 | Preliminary Design Review | 28.18d | 2010-04-29 | 2010-07-01 | 72, 200, 210, 222, 156 |  |  | 128.15d | 0d |  | Sean Adkins; Instrument Scientist; ME - Jim Bell; ME - John Canfield; Software Engineer; Electronics Engineer; WMKO Support Astronomer; WMKO Software Staff; WMKO Instrument Staff; WMKO Electronics Staff; OE - Optical Engineer 2 | 524h | 30,488 | PD |
| 66 | 1.2 | **Science** | 206.76d? | 2009-06-26 | 2010-04-12 |  |  |  | 185.5d |  |  |  | 224h | 8,178 |  |
| 67 | 1.2.1 | **Science Team Meetings** | 136.5d? | 2009-06-26 | 2010-01-04 |  |  |  | 255.75d |  |  |  | 64h | 2,088 |  |
| 68 | 1.2.1.1 | Meeting 1 | 1.5d? | 2009-06-26 | 2009-06-29 | 2FS+2mo |  |  | 390.75d |  |  | Sean Adkins; Instrument Scientist; Science Team | 32h | 1,044 | PD |
| 69 | 1.2.1.2 | Meeting 2 | 2d? | 2009-12-11 | 2010-01-04 | 2FS+8mo |  |  | 255.75d |  |  | Sean Adkins; Instrument Scientist; Science Team | 32h | 1,044 | PD |
| 70 | 1.2.2 | **Common Observing Operations Concept Document** | 186.76d? | 2009-07-24 | 2010-04-12 |  |  |  | 128.15d |  |  |  | 160h | 6,090 |  |
| 71 | 1.2.2.1 | Initial Draft | 19.75d? | 2009-07-24 | 2009-08-20 | 2FS+3mo |  |  | 247.35d | 0d |  | Sean Adkins [20%]; Instrument Scientist [20%]; Science Team [20%] | 70h | 2,610 | PD |
| 72 | 1.2.2.2 | Final Version | 31.09d? | 2010-02-26 | 2010-04-12 | 190, 209 |  |  | 128.15d | 0d |  | Sean Adkins [20%]; Instrument Scientist [20%]; Science Team [20%] | 90h | 3,480 | PD |
| 73 | 1.3 | **Instrument Design and Fabrication** | 432.25d? | 2009-05-01 A | 2010-12-28 |  | 2% | 424.37d? | 0d |  |  |  | 6474h | 355,497.03 |  |
| 74 | 1.3.1 | **AO System to Instrument Interface Definitions** | 34d? | 2009-05-01 | 2009-06-17 |  |  |  | 0d |  |  |  | 136h | 9,708 | PD |
| 75 | 1.3.1.1 | Optical | 2.6d? | 2009-05-01 | 2009-06-02 | 2 |  |  | 0d |  |  | Sean Adkins; OE - Optical Engineer 2 | 28h | 2,096 | PD |
| 76 | 1.3.1.2 | Mechanical | 3.5d? | 2009-06-02 | 2009-06-09 | 75 |  |  | 0d |  |  | Sean Adkins; ME - Jim Bell | 28h | 1,896 | PD |
| 77 | 1.3.1.3 | Electronic/Electrical | 1.5d? | 2009-06-10 | 2009-06-11 | 76 |  |  | 0d |  |  | Sean Adkins | 12h | 1,044 | PD |
| 78 | 1.3.1.4 | Software | 2.5d? | 2009-06-11 | 2009-06-15 | 77 |  |  | 0d |  |  | Sean Adkins; Software Engineer | 28h | 1,896 | PD |
| 79 | 1.3.1.5 | Alignment and Calibration Concept for Instrument on AO System | 2d? | 2009-06-16 | 2009-06-17 | 78 |  |  | 0d |  |  | Sean Adkins; OE - Optical Engineer 2; ME - Jim Bell | 40h | 2,776 | PD |

Notes:
- 65: Effort for team members includes writing PD report.

| ID | WBS | Task | Duration | Start | Finish | Predecessors | Complete | Remaining | Total slack | Free slack | Resources | Work | Cost | Text1 | Text2 |
| --- | --- | --- | --- | --- | --- | --- | --- | --- | --- | --- | --- | --- | --- | --- | --- |
| 80 | 1.3.2 | **Shared Facilities** | 96.11d? | 2009-05-01 A | 2009-09-14 |  | 12% | 84.84d? | 336.15d |  |  | 200h | 14,314 |  |  |
| 81 | 1.3.2.1 | **AO System** | 96.11d? | 2009-05-01 A | 2009-09-14 |  | 15% | 82.11d? | 336.15d |  |  | 160h | 11,644 |  |  |
| 82 | 1.3.2.1.1 | **High Order AO Relay** | 40.5d? | 2009-06-18 A | 2009-08-13 |  | 46% | 21.81d? | 357.75d |  |  | 52h | 4,524 |  |  |
| 83 | 1.3.2.1.1.1 | Design Liason | 20d? | 2009-06-18 A | 2009-07-21 | 79 | 75% | 5d? | 336.06d | 0d | Sean Adkins [20%] | 32h | 2,784 | PD |  |
| 84 | 1.3.2.1.1.2 | RTC and Control Liason | 12.5d? | 2009-07-28 | 2009-08-13 | 83 |  |  | 357.75d |  | Sean Adkins [20%] | 20h | 1,740 | PD |  |
| 85 | 1.3.2.1.2 | **ADC** | 35d? | 2009-07-27 | 2009-09-14 |  |  |  | 336.15d |  |  | 56h | 4,464 |  |  |
| 86 | 1.3.2.1.2.1 | Requirements Liason | 20d? | 2009-07-27 | 2009-08-24 | 83 |  |  | 336.15d | 0d | Sean Adkins [20%] | 32h | 2,784 | PD |  |
| 87 | 1.3.2.1.2.2 | Design Liason | 15d? | 2009-08-24 | 2009-09-14 | 86 |  |  | 336.15d |  | OE - Optical Engineer 2 [20%] | 24h | 1,680 | PD |  |
| 88 | 1.3.2.1.3 | **Calibration Faciltiy** | 50d? | 2009-05-01 | 2009-07-09 |  |  |  | 352.77d |  |  | 52h | 2,656 |  |  |
| 89 | 1.3.2.1.3.1 | Requirements Liason | 15.5d? | 2009-05-01 | 2009-06-11 |  |  |  | 352.77d | 0d | Sean Adkins [20%]; Instrument Scientist [20%]; OE - Optical Engineer 2 [20%] | 28h | 1,536 | PD |  |
| 90 | 1.3.2.1.3.2 | Design Liason | 20d? | 2009-06-12 | 2009-07-09 | 89 |  |  | 352.77d | 0d | Instrument Scientist [10%]; OE - Optical Engineer 2 [10%] | 24h | 1,120 | PD |  |
| 91 | 1.3.2.2 | **Nasmyth Enclosure** | 29.48d? | 2009-07-10 | 2009-08-20 |  |  |  | 352.77d |  |  | 40h | 2,670 |  |  |
| 92 | 1.3.2.2.1 | Requirements Liason | 12.5d? | 2009-07-10 | 2009-08-03 | 90 |  |  | 352.77d | 0d | Sean Adkins [20%]; ME - Jim Bell [20%] | 20h | 1,470 | PD |  |
| 93 | 1.3.2.2.2 | Design Liason | 12.5d? | 2009-08-03 | 2009-08-20 | 92 |  |  | 352.77d |  | ME - Jim Bell [20%] | 20h | 1,200 | PD |  |
| 94 | 1.3.3 | **Instrument** | 432.25d? | 2009-05-01 A | 2010-12-28 |  |  | 431.01d? | 0d |  |  | 6138h | 331,475.03 |  |  |
| 95 | 1.3.3.1 | **IFS System Design Phase** | 193.39d? | 2009-06-01 | 2010-02-25 |  |  |  | 0.54d |  |  | 1762h | 86,375.69 | PD | IFS |
| 96 | 1.3.3.1.1 | **IFS Performance Budgets** | 56.34d | 2009-06-01 | 2009-08-18 |  |  |  | 0.54d |  |  | 260h | 11,576.17 | PD | IFS |
| 97 | 1.3.3.1.1.1 | Throughput | 6.67d | 2009-06-01 | 2009-06-09 | 2FS+21d |  |  | 0.54d | 0d | Sean Adkins [50%]; Instrument Scientist [50%]; OE - Sergey Panteleev [50%] | 60h | 2,446.67 | PD | IFS |
| 98 | 1.3.3.1.1.2 | Background | 5d | 2009-06-09 | 2009-06-25 | 97 |  |  | 0.54d | 0d | Sean Adkins [50%]; Instrument Scientist [50%]; OE - Sergey Panteleev [50%] | 40h | 1,980 | PD | IFS |
| 99 | 1.3.3.1.1.3 | Wavefront error | 6.67d | 2009-06-25 | 2009-07-03 | 98 |  |  | 0.54d | 0d | Sean Adkins [50%]; Instrument Scientist [50%]; OE - Sergey Panteleev [50%] | 60h | 2,446.67 | PD | IFS |
| 100 | 1.3.3.1.1.4 | Spectroscopic performance | 14.27d | 2009-07-03 | 2009-08-11 | 99 |  |  | 0.54d | 0d | Sean Adkins [50%]; Instrument Scientist [50%]; OE - Sergey Panteleev [38%] | 80h | 3,390.34 | PD | IFS |
| 101 | 1.3.3.1.1.5 | Size and mass | 5.21d | 2009-08-11 | 2009-08-18 | 100 |  |  | 354.91d |  | Sean Adkins [50%]; ME - Jim Bell [38%] | 20h | 1,312.5 | PD | IFS |
| 102 | 1.3.3.1.2 | **Trade Studies** | 106.33d | 2009-08-11 | 2010-01-06 |  |  |  | 253.79d |  |  | 420h | 19,087.58 | PD | IFS |
| 103 | 1.3.3.1.2.1 | FOV and spatial sampling | 14.31d | 2009-08-11 | 2009-09-10 | 100 |  |  | 266.17d | 0d | Sean Adkins [33.3%]; Instrument Scientist [50%]; OE - Sergey Panteleev [33%] | 90h | 4,461.53 | PD | IFS |
| 104 | 1.3.3.1.2.2 | Wavelength coverage and spatial sampling | 13.19d | 2009-09-10 | 2009-10-13 | 100, 103 |  |  | 266.17d | 0d | Sean Adkins [50%]; Instrument Scientist [50%]; OE - Sergey Panteleev [33%] | 70h | 3,202.78 | PD | IFS |
| 105 | 1.3.3.1.2.3 | Optimization of image slicing formats and spectrograph formats | 20.25d | 2009-10-13 | 2009-11-20 | 100, 104 |  |  | 266.17d | 0d | Sean Adkins [33.3%]; Instrument Scientist [50%]; OE - Sergey Panteleev [33%]; ME - John Canfield [50%] | 110h | 5,784.33 | PD | IFS |
| 106 | 1.3.3.1.2.4 | Separate or combined capability above and below 1 micron | 8.78d | 2009-11-20 | 2009-12-03 | 105 |  |  | 266.17d | 0d | Sean Adkins [50%]; Instrument Scientist [50%]; OE - Sergey Panteleev [33%] | 70h | 2,640.8 | PD | IFS |
| 107 | 1.3.3.1.2.5 | Wavefront error allocations | 7.17d | 2009-12-03 | 2009-12-14 | 106 |  |  | 266.17d | 0d | Sean Adkins [50%]; Instrument Scientist [50%]; OE - Sergey Panteleev [33%] | 50h | 1,532.99 | PD | IFS |
| 108 | 1.3.3.1.2.6 | Trade study report | 6.68d | 2009-12-14 | 2010-01-06 | 107 |  |  | 253.79d |  | Sean Adkins [16.7%]; Instrument Scientist [50%]; OE - Sergey Panteleev [50%] | 30h | 1,465.15 | PD | IFS |

| ID | WBS | Task | Duration | Start | Finish | Predecessors | Complete | Remaining | Total slack | Free slack | Resources | Work | Cost | Text1 | Text2 |
| --- | --- | --- | --- | --- | --- | --- | --- | --- | --- | --- | --- | --- | --- | --- | --- |
| 109 | 1.3.3.1.3 | **Conceptual Designs** | 106.64d? | 2009-09-22 | 2010-02-17 |  |  |  | 0.54d |  |  | 980h | 50,071.46 | PD | IFS |
| 110 | 1.3.3.1.3.1 | Development of design options | 46.07d | 2009-09-22 | 2009-11-25 | 100FS+6w |  |  | 0.54d | 0d | Sean Adkins [50%]; Instrument Scientist [50%]; OE - Sergey Panteleev [17%]; ME - John Canfield [50%] | 380h | 16,556.94 | PD | IFS |
| 111 | 1.3.3.1.3.2 | Evaluation of design options | 9.74d? | 2009-11-25 | 2009-12-09 | 110 |  |  | 0.54d | 0d | Sean Adkins [50%]; Instrument Scientist [50%]; OE - Sergey Panteleev [50%]; ME - John Canfield [50%] | 140h | 7,678.05 | PD | IFS |
| 112 | 1.3.3.1.3.3 | Calibration and alignment issues | 5.58d? | 2009-12-09 | 2009-12-17 | 111 |  |  | 0.54d | 0d | Sean Adkins [50%]; Instrument Scientist [50%]; OE - Sergey Panteleev [50%]; ME - John Canfield [50%] | 60h | 3,122.46 | PD | IFS |
| 113 | 1.3.3.1.3.4 | Downselect of conceptual design | 10d? | 2009-12-17 | 2010-01-08 | 112 |  |  | 0d |  | Sean Adkins [50%]; Instrument Scientist [50%]; OE - Sergey Panteleev [50%]; ME - John Canfield [50%] | 80h | 4,340 | PD | IFS |
| 114 | 1.3.3.1.3.5 | Revised performance budgets | 4d? | 2010-01-11 | 2010-01-14 | 113 |  |  | 243.5d | 0d | Sean Adkins [50%]; Instrument Scientist [50%]; OE - Sergey Panteleev [50%] | 40h | 1,816 | PD | IFS |
| 115 | 1.3.3.1.3.6 | Performance budget report | 3.75d? | 2010-01-15 | 2010-01-20 | 114 |  |  | 243.5d |  | Sean Adkins [50%]; OE - Sergey Panteleev [50%] | 30h | 2,355 | PD | IFS |
| 116 | 1.3.3.1.3.7 | Performance estimates | 4.38d? | 2010-01-11 | 2010-01-22 | 113 |  |  | 0d |  | Sean Adkins [50%]; Instrument Scientist [50%]; OE - Sergey Panteleev [50%]; ME - John Canfield [50%] | 60h | 3,308.13 | PD | IFS |
| 117 | 1.3.3.1.3.8 | System requirements document | 4.38d? | 2010-01-22 | 2010-01-28 | 116 |  |  | 0d |  | Sean Adkins [50%]; Instrument Scientist [50%]; OE - Sergey Panteleev [50%]; ME - John Canfield [50%] | 70h | 3,797.5 | PD | IFS |
| 118 | 1.3.3.1.3.9 | System design manual | 7.28d? | 2010-01-28 | 2010-02-17 | 117 |  |  | 0d |  | Sean Adkins [75%]; Instrument Scientist [75%]; OE - Sergey Panteleev [75%]; ME - John Canfield [75%] | 120h | 7,097.38 | PD | IFS |
| 119 | 1.3.3.1.4 | **System Design Review** | 5.61d? | 2010-02-17 | 2010-02-25 | 116 |  |  | 0d |  |  | 102h | 5,640.47 | PD | IFS |
| 120 | 1.3.3.1.4.1 | System design report | 4.38d? | 2010-02-17 | 2010-02-24 | 118 |  |  | 0d |  | Sean Adkins [50%]; Instrument Scientist [50%]; OE - Sergey Panteleev [50%]; ME - John Canfield [50%] | 70h | 3,797.5 | PD | IFS |
| 121 | 1.3.3.1.4.2 | System design review meeting | 1.23d? | 2010-02-24 | 2010-02-25 | 120 |  |  | 0d |  | Sean Adkins [80%]; Instrument Scientist [80%]; OE - Sergey Panteleev [90%]; ME - John Canfield [90%] | 32h | 1,842.97 | PD | IFS |
| 122 | 1.3.3.2 | **IFS Preliminary Design Phase** | 217.87d? | 2010-02-25 | 2010-12-28 |  |  |  | 0d |  |  | 2148h | 107,197.9 | DD | IFS |
| 123 | 1.3.3.2.1 | Initial AO system to instrument interface definitions | 5.39d? | 2010-02-25 | 2010-03-08 | 121 |  |  | 0d |  | Sean Adkins [50%]; OE - Sergey Panteleev [50%]; ME - Jim Bell [50%] | 60h | 4,340 | DD | IFS |
| 124 | 1.3.3.2.2 | Alignment and calibration concept | 8.19d? | 2010-03-08 | 2010-03-18 | 123 |  |  | 0d |  | Sean Adkins [50%]; Instrument Scientist [50%]; OE - Sergey Panteleev [50%]; ME - Jim Bell [50%] | 100h | 4,669.23 | DD | IFS |
| 125 | 1.3.3.2.3 | Optical design | 91.7d? | 2010-03-18 | 2010-07-26 | 124 |  |  | 0d |  | Sean Adkins [50%]; Instrument Scientist [50%]; OE - Sergey Panteleev [50%] | 760h | 29,114.83 | DD | IFS |
| 126 | 1.3.3.2.4 | Mechanical design | 160.82d? | 2010-05-03 | 2010-12-14 | 125FS-60d |  |  | 0d |  | Sean Adkins [50%]; ME - Jim Bell [50%] | 680h | 41,880 | DD | IFS |
| 127 | 1.3.3.2.5 | Electronic design | 30d? | 2010-10-18 | 2010-11-29 | 125FS+60d |  |  | 10.82d | 0d | Sean Adkins [50%]; Electronics Engineer [50%] | 140h | 8,940 | DD | IFS |
| 128 | 1.3.3.2.6 | Software design | 23.53d? | 2010-10-18 | 2010-11-18 | 127SS |  |  | 17.29d |  | Sean Adkins [50%]; Instrument Scientist [50%]; Software Engineer [50%] | 200h | 6,670.59 | DD | IFS |
| 129 | 1.3.3.2.7 | Preliminary design report | 8.89d? | 2010-12-14 | 2010-12-24 | 123, 126, 127, 128 |  |  | 0d |  | Sean Adkins [50%]; Instrument Scientist [50%]; ME - Jim Bell [50%]; Electronics Engineer [50%]; OE - Sergey Panteleev [50%]; Software Engineer [50%] | 160h | 8,782.24 | DD | IFS |
| 130 | 1.3.3.2.8 | Preliminary design review meeting | 1.27d? | 2010-12-24 | 2010-12-28 | 129 |  |  | 0d |  | Sean Adkins [80%]; Instrument Scientist [80%]; ME - Jim Bell [90%]; Electronics Engineer [90%]; OE - Sergey Panteleev [90%]; Software Engineer [90%] | 48h | 2,801.01 | DD | IFS |
| 131 | 1.3.3.3 | **Near-IR Imager and IFS Preliminary Design** | 259.5d? | 2009-05-01 A | 2010-04-29 |  | 1% | 257.27d? | 172.75d |  |  | 2228h | 137,901.44 |  |  |
| 132 | 1.3.3.3.1 | **Imager Trade Studies** | 39.4d? | 2009-06-02 A | 2009-07-27 |  | 15% | 33.34d? | 0d |  |  | 104h | 6,189.44 | PD |  |
| 133 | 1.3.3.3.1.1 | Imager Wavefront Error | 4.75d? | 2009-06-02 | 2009-06-30 | 75 |  |  | 0d |  | Sean Adkins [80%]; Science Team; OE - Optical Engineer 2 [90%] | 40h | 2,421.44 | PD |  |
| 134 | 1.3.3.3.1.2 | Imager Pixel Scale | 7.1d? | 2009-06-30 A | 2009-07-23 | 133 | 30% | 4.97d? | 0d |  | Sean Adkins [62.5%]; Science Team [62.5%]; OE - Optical Engineer 2 [62.5%] | 48h | 3,072 | PD |  |
| 135 | 1.3.3.3.1.3 | Imager Short Wavelength Cut-off | 2d? | 2009-07-23 | 2009-07-27 | 134 |  |  | 0d |  | Sean Adkins; Science Team | 16h | 696 | PD |  |

| ID | WBS | Task | Duration | Start | Finish | Predecessors | Complete | Remaining | Total slack | Free slack | Resources | Work | Cost | Text1 |
| --- | --- | --- | --- | --- | --- | --- | --- | --- | --- | --- | --- | --- | --- | --- |
| 136 | 1.3.3.3.2 | **Imager Performance Budgets** | 76d? | 2009-05-01 A | 2009-08-14 |  | 1% | 75.44d? | 356.25d |  |  | 124h | 9,268 | PD |
| 137 | 1.3.3.3.2.1 | Imager Sensitivity | 1d? | 2009-07-28 A | 2009-07-28 | 135 | 20% | 0.8d? | 356.25d | 0d | Sean Adkins; OE - Optical Engineer 2 | 16h | 1,256 | PD |
| 138 | 1.3.3.3.2.2 | Imager Background | 4.5d? | 2009-07-29 | 2009-08-04 | 137 |  |  | 356.25d | 0d | Sean Adkins [25%]; OE - Optical Engineer 2 [25%] | 16h | 1,256 | PD |
| 139 | 1.3.3.3.2.3 | Imager Companion Sensitivity | 4.5d? | 2009-08-04 | 2009-08-14 | 138 |  |  | 356.25d |  | Sean Adkins; OE - Optical Engineer 2 | 36h | 2,724 | PD |
| 140 | 1.3.3.3.2.4 | Imager Wavefront Error | 12d? | 2009-06-30 | 2009-07-16 | 133 |  |  | 128.15d | 0d | Sean Adkins [25%]; OE - Optical Engineer 2 [25%] | 32h | 2,376 | PD |
| 141 | 1.3.3.3.2.5 | Imager Size and Mass | 5.2d? | 2009-05-01 | 2009-05-18 |  |  |  | 420.85d |  | Sean Adkins [41.7%]; ME - Jim Bell [41.7%] | 24h | 1,656 | PD |
| 142 | 1.3.3.3.3 | **Optical Design** | 45.65d? | 2009-07-16 | 2009-09-17 |  |  |  | 128.15d |  |  | 416h | 28,080 |  |
| 143 | 1.3.3.3.3.1 | Initial Optical Design | 6.25d? | 2009-07-28 | 2009-08-05 | 135 |  |  | 364d |  | Sean Adkins [80%]; OE - Optical Engineer 2 [90%] | 60h | 4,880 |  |
| 144 | 1.3.3.3.3.2 | **Optical Modeling** | 40.65d? | 2009-07-16 | 2009-09-10 |  |  |  | 128.15d |  |  | 292h | 19,356 |  |
| 145 | 1.3.3.3.3.2.1 | Fore Optics | 6d? | 2009-07-16 | 2009-07-28 | 140 |  |  | 128.15d | 0d | OE - Optical Engineer 2; Sean Adkins; Instrument Scientist | 56h | 3,632 | PD |
| 146 | 1.3.3.3.3.2.2 | Lyot Stop | 2d? | 2009-07-29 | 2009-07-30 | 145 |  |  | 128.15d | 0d | OE - Optical Engineer 2; Sean Adkins; Instrument Scientist | 24h | 1,468 | PD |
| 147 | 1.3.3.3.3.2.3 | Coronagraph | 1.5d? | 2009-07-31 | 2009-08-12 | 146 |  |  | 128.15d | 0d | OE - Optical Engineer 2; ME - Jim Bell; Instrument Scientist | 28h | 1,320 | PD |
| 148 | 1.3.3.3.3.2.4 | Imager Camera | 20d? | 2009-08-12 | 2009-09-09 | 147 |  |  | 128.15d | 0d | OE - Optical Engineer 2 | 160h | 11,200 | PD |
| 149 | 1.3.3.3.3.2.5 | IFS Fold Mirror | 1.25d? | 2009-09-09 | 2009-09-10 | 148 |  |  | 332.5d | 0d | Sean Adkins [80%]; OE - Optical Engineer 2 [90%]; ME - Jim Bell [90%] | 24h | 1,736 |  |
| 150 | 1.3.3.3.3.3 | Preliminary Design Performance Analysis | 5d? | 2009-09-10 | 2009-09-17 | 149 |  |  | 332.5d |  | OE - Optical Engineer 2; Sean Adkins; Instrument Scientist | 64h | 3,844 | PD |
| 151 | 1.3.3.3.4 | **Dewar** | 147.95d? | 2009-07-29 | 2010-02-19 |  |  |  | 158.65d |  |  | 1072h | 64,416 |  |
| 152 | 1.3.3.3.4.1 | **Cold Assemblies** | 146.45d? | 2009-07-29 | 2010-02-18 |  |  |  | 158.65d |  |  | 792h | 47,536 |  |
| 153 | 1.3.3.3.4.1.1 | **Dewar Internal Structure** | 49.5d? | 2009-12-10 | 2010-02-18 |  |  |  | 128.15d |  |  | 188h | 11,280 |  |
| 154 | 1.3.3.3.4.1.1.1 | Interface Specification | 1d? | 2009-12-10 | 2009-12-11 | 186 |  |  | 128.15d | 0d | ME - Jim Bell | 8h | 480 | PD |
| 155 | 1.3.3.3.4.1.1.2 | Mechanical Model | 10d? | 2009-12-11 | 2009-12-25 | 154 |  |  | 128.15d | 0d | ME - Jim Bell | 80h | 4,800 | PD |
| 156 | 1.3.3.3.4.1.1.3 | FEA | 7.5d? | 2010-02-08 | 2010-02-18 | 155, 190 |  |  | 178.21d | 0d | ME - Jim Bell | 60h | 3,600 | PD |
| 157 | 1.3.3.3.4.1.1.4 | Thermal Analysis | 5d? | 2009-12-25 | 2010-01-01 | 155 |  |  | 154.15d | 0d | ME - Jim Bell | 40h | 2,400 | PD |
| 158 | 1.3.3.3.4.1.2 | **Fore Optics** | 112.95d? | 2009-07-29 | 2010-01-01 |  |  |  | 234.6d |  |  | 188h | 11,400 |  |
| 159 | 1.3.3.3.4.1.2.1 | **Input Baffle & Coronagraph** | 102.45d? | 2009-08-12 | 2010-01-01 |  |  |  | 128.15d |  |  | 52h | 3,120 |  |
| 160 | 1.3.3.3.4.1.2.1.1 | Interface Specification | 1.5d? | 2009-08-12 | 2009-08-13 | 147 |  |  | 224.1d | 95.95d | ME - Jim Bell | 12h | 720 | PD |
| 161 | 1.3.3.3.4.1.2.1.2 | Mechanical Model | 5d? | 2009-12-25 | 2010-01-01 | 160, 155 |  |  | 128.15d | 0d | ME - Jim Bell | 40h | 2,400 | PD |

Notes:
- 161: Thermal analysis included in dewar structure thermal analysis task

| ID | WBS | Task | Duration | Start | Finish | Predecessors | Total slack | Free slack | Resources | Work | Cost | Text1 |
| --- | --- | --- | --- | --- | --- | --- | --- | --- | --- | --- | --- | --- |
| 162 | 1.3.3.3.4.1.2.2 | **Re-imager** | 6.5d? | 2009-07-29 | 2009-08-06 |  | 362.75d |  |  | 60h | 3,680 |  |
| 163 | 1.3.3.3.4.1.2.2.1 | Interface Specification | 1.5d? | 2009-07-29 | 2009-07-30 | 145 | 362.75d | 0d | OE - Optical Engineer 2; ME - Jim Bell | 20h | 1,280 | PD |
| 164 | 1.3.3.3.4.1.2.2.2 | Mechanical Model | 5d? | 2009-07-30 | 2009-08-06 | 163 | 362.75d |  | ME - Jim Bell | 40h | 2,400 | PD |
| 165 | 1.3.3.3.4.1.2.3 | **Adjustable Lyot Stop** | 9d? | 2009-07-31 | 2009-08-12 |  | 256.1d |  |  | 76h | 4,600 |  |
| 166 | 1.3.3.3.4.1.2.3.1 | Interface Specification | 1.5d? | 2009-07-31 | 2009-08-03 | 146 | 256.1d | 0d | OE - Optical Engineer 2; ME - Jim Bell | 16h | 1,000 | PD |
| 167 | 1.3.3.3.4.1.2.3.2 | Mechanical Model | 7.5d? | 2009-08-03 | 2009-08-12 | 166 | 256.1d | 76.95d | ME - Jim Bell | 60h | 3,600 | PD |
| 168 | 1.3.3.3.4.1.3 | **Filter Wheels** | 19.76d? | 2009-09-09 | 2009-10-07 |  | 216.84d |  |  | 156h | 9,176 |  |
| 169 | 1.3.3.3.4.1.3.1 | **Mechanism** | 19.76d? | 2009-09-09 | 2009-10-07 |  | 216.84d |  |  | 132h | 7,920 |  |
| 170 | 1.3.3.3.4.1.3.1.1 | Interface Specification | 1.67d? | 2009-09-09 | 2009-09-11 | 148 | 216.84d | 0d | ME - Bob Weber [90%] | 12h | 720 | PD |
| 171 | 1.3.3.3.4.1.3.1.2 | Mechanical Model | 16.67d? | 2009-09-14 | 2009-10-07 | 172 | 216.84d | 37.69d | ME - Bob Weber [90%] | 120h | 7,200 | PD |
| 172 | 1.3.3.3.4.1.3.2 | Filter Specifications | 1.43d? | 2009-09-11 | 2009-09-14 | 170 | 216.84d | 0d | Sean Adkins; OE - Optical Engineer 2; Instrument Scientist [70%] | 24h | 1,256 | PD |
| 173 | 1.3.3.3.4.1.4 | **Imager** | 61.45d? | 2009-09-09 | 2009-12-03 |  | 128.15d |  |  | 260h | 15,680 |  |
| 174 | 1.3.3.3.4.1.4.1 | **Camera** | 9d? | 2009-09-09 | 2009-09-22 |  | 128.15d |  |  | 80h | 4,880 |  |
| 175 | 1.3.3.3.4.1.4.1.1 | Interface Specification | 1.5d? | 2009-09-09 | 2009-09-10 | 148 | 128.15d | 0d | OE - Optical Engineer 2; ME - Jim Bell | 20h | 1,280 | PD |
| 176 | 1.3.3.3.4.1.4.1.2 | Mechanical Model | 7.5d? | 2009-09-11 | 2009-09-22 | 175 | 128.15d | 0d | ME - Jim Bell | 60h | 3,600 | PD |
| 177 | 1.3.3.3.4.1.4.2 | **Detector Head** | 52.45d? | 2009-09-22 | 2009-12-03 |  | 128.15d |  |  | 180h | 10,800 |  |
| 178 | 1.3.3.3.4.1.4.2.1 | **Mount** | 6d? | 2009-09-22 | 2009-09-30 |  | 128.15d |  |  | 48h | 2,880 |  |
| 179 | 1.3.3.3.4.1.4.2.1.1 | Interface Specification | 1d? | 2009-09-22 | 2009-09-23 | 176 | 128.15d | 0d | ME - John Canfield | 8h | 480 | PD |
| 180 | 1.3.3.3.4.1.4.2.1.2 | Mechanical Model | 5d? | 2009-09-23 | 2009-09-30 | 179 | 128.15d | 0d | ME - John Canfield | 40h | 2,400 | PD |
| 181 | 1.3.3.3.4.1.4.2.2 | **Focus Mechanism** | 42.45d? | 2009-09-30 | 2009-11-27 |  | 128.15d |  |  | 100h | 6,000 |  |
| 182 | 1.3.3.3.4.1.4.2.2.1 | Interface Specification | 2.5d? | 2009-09-30 | 2009-10-27 | 180 | 128.15d | 0d | ME - John Canfield | 20h | 1,200 | PD |
| 183 | 1.3.3.3.4.1.4.2.2.2 | Mechanical Model | 10d? | 2009-10-27 | 2009-11-27 | 182 | 128.15d | 0d | ME - John Canfield | 80h | 4,800 | PD |
| 184 | 1.3.3.3.4.1.4.2.3 | **Cooling Interface** | 4d? | 2009-11-27 | 2009-12-03 |  | 128.15d |  |  | 32h | 1,920 |  |
| 185 | 1.3.3.3.4.1.4.2.3.1 | Interface Specification | 1d? | 2009-11-27 | 2009-11-30 | 183 | 128.15d | 0d | ME - John Canfield | 8h | 480 | PD |
| 186 | 1.3.3.3.4.1.4.2.3.2 | Mechanical Model | 3d? | 2009-11-30 | 2009-12-03 | 185 | 128.15d | 0d | ME - John Canfield | 24h | 1,440 | PD |

| ID | WBS | Task | Duration | Start | Finish | Predecessors | Total slack | Free slack | Resources | Work | Cost | Text1 |
| --- | --- | --- | --- | --- | --- | --- | --- | --- | --- | --- | --- | --- |
| 187 | 1.3.3.3.4.2 | **Warm Assemblies** | 35d? | 2010-01-01 | 2010-02-19 |  | 128.15d |  |  | 280h | 16,880 |  |
| 188 | 1.3.3.3.4.2.1 | **Dewar Shell** | 35d? | 2010-01-01 | 2010-02-19 |  | 128.15d |  |  | 228h | 13,760 |  |
| 189 | 1.3.3.3.4.2.1.1 | Interface Specification | 2.78d? | 2010-01-04 | 2010-01-07 | 191 | 128.15d | 0d | ME - Bob Weber [90%] | 20h | 1,200 | PD |
| 190 | 1.3.3.3.4.2.1.2 | Mechanical Model | 22.22d? | 2010-01-07 | 2010-02-08 | 189 | 128.15d | 0d | ME - Bob Weber [90%] | 160h | 9,600 | PD |
| 191 | 1.3.3.3.4.2.1.3 | Window Specifications | 1d? | 2010-01-01 | 2010-01-04 | 161 | 128.15d | 0d | OE - Optical Engineer 2 | 8h | 560 | PD |
| 192 | 1.3.3.3.4.2.1.4 | External Connections | 2.5d? | 2010-02-17 | 2010-02-19 | 193 | 221.31d |  | ME - Bob Weber; Electronics Engineer | 40h | 2,400 | PD |
| 193 | 1.3.3.3.4.2.2 | Vacuum System Requirements | 1.5d? | 2010-02-15 | 2010-02-17 | 194 | 128.15d | 0d | ME - Bob Weber | 12h | 720 | PD |
| 194 | 1.3.3.3.4.2.3 | Cryogenic System Requirements | 5d? | 2010-02-08 | 2010-02-15 | 190, 157 | 128.15d | 0d | ME - Bob Weber | 40h | 2,400 | PD |
| 195 | 1.3.3.3.5 | **Electronics** | 11.25d? | 2009-11-27 | 2009-12-15 |  | 226.71d |  |  | 144h | 8,856 |  |
| 196 | 1.3.3.3.5.1 | **Motion Control** | 7.5d? | 2009-11-27 | 2009-12-09 |  | 226.71d |  |  | 84h | 5,256 |  |
| 197 | 1.3.3.3.5.1.1 | Requirements | 5d? | 2009-11-27 | 2009-12-04 | 167, 171, 183 | 226.71d | 0d | Electronics Engineer; Software Engineer; ME - Jim Bell; Sean Adkins | 64h | 4,056 | PD |
| 198 | 1.3.3.3.5.1.2 | Initial Design | 2.5d? | 2009-12-04 | 2009-12-09 | 197 | 226.71d | 0d | Electronics Engineer | 20h | 1,200 | PD |
| 199 | 1.3.3.3.5.2 | Power Control | 1.25d? | 2009-12-09 | 2009-12-10 | 198 | 226.71d | 0d | Electronics Engineer; Software Engineer | 20h | 1,200 | PD |
| 200 | 1.3.3.3.5.3 | Pressure Monitoring | 1.25d? | 2009-12-10 | 2009-12-11 | 199 | 226.71d | 0d | Electronics Engineer; Software Engineer | 20h | 1,200 | PD |
| 201 | 1.3.3.3.5.4 | Temperature Monitoring and Control | 1.25d? | 2009-12-11 | 2009-12-15 | 200 | 257.11d | 0d | Electronics Engineer; Software Engineer | 20h | 1,200 | PD |
| 202 | 1.3.3.3.6 | **Software** | 179.75d? | 2009-08-20 | 2010-04-29 |  | 128.15d |  |  | 184h | 9,620 |  |
| 203 | 1.3.3.3.6.1 | Detector Control | 3d? | 2009-12-02 | 2009-12-07 | 204, 205 | 179.15d | 0d | Software Engineer | 24h | 1,440 | PD |
| 204 | 1.3.3.3.6.2 | Global Server | 3d? | 2009-08-20 | 2009-08-25 | 71 | 247.35d | 68.2d | Software Engineer | 24h | 1,440 | PD |
| 205 | 1.3.3.3.6.3 | Motion Control | 2.5d? | 2009-11-27 | 2009-12-02 | 167, 171, 183, 204 | 179.15d | 0d | Software Engineer | 20h | 1,200 | PD |
| 206 | 1.3.3.3.6.4 | Power Control | 1d? | 2009-12-07 | 2009-12-08 | 204, 203, 205 | 179.15d | 51d | Software Engineer | 8h | 480 | PD |
| 207 | 1.3.3.3.6.5 | Pressure Monitoring | 1d? | 2010-02-17 | 2010-02-18 | 193, 206 | 128.15d | 0d | Software Engineer | 8h | 480 | PD |
| 208 | 1.3.3.3.6.6 | Temperature Monitoring and Control | 2.5d? | 2010-02-18 | 2010-02-22 | 157, 207 | 128.15d | 0d | Software Engineer | 20h | 1,200 | PD |
| 209 | 1.3.3.3.6.7 | User Interface Requirements | 3.33d? | 2010-02-22 | 2010-02-26 | 208 | 128.15d | 0d | Software Engineer; Sean Adkins; Instrument Scientist | 40h | 2,180 | PD |
| 210 | 1.3.3.3.6.8 | Data Reduction Tools | 5d? | 2010-04-12 | 2010-04-29 | 72 | 128.15d | 0d | Software Engineer; Instrument Scientist | 40h | 1,200 | PD |

| ID | WBS | Task | Duration | Start | Finish | Predecessors | Total slack | Free slack | Resources | Work | Cost | Text1 |
| --- | --- | --- | --- | --- | --- | --- | --- | --- | --- | --- | --- | --- |
| 211 | 1.3.3.3.7 | **Interfaces** | 66.03d? | 2009-12-15 | 2010-03-17 |  | 204.02d |  |  | 80h | 5,232 |  |
| 212 | 1.3.3.3.7.1 | Mechanical Interface Requirements | 2.5d? | 2010-01-15 | 2010-01-19 | 157 | 234.31d | 30.28d | ME - John Canfield | 20h | 1,200 | PD |
| 213 | 1.3.3.3.7.2 | Electronic Interface Requirements | 2.5d? | 2009-12-15 | 2009-12-17 | 201 | 257.11d | 53.08d | Electronics Engineer | 20h | 1,200 | PD |
| 214 | 1.3.3.3.7.3 | Software Interface Requirements | 2.5d? | 2010-02-26 | 2010-03-02 | 209 | 204.02d | 0d | Software Engineer | 20h | 1,200 | PD |
| 215 | 1.3.3.3.7.4 | Interface Control Document | 3.06d? | 2010-03-02 | 2010-03-17 | 212, 213, 214 | 204.02d |  | Sean Adkins [80%]; ME - Jim Bell [90%] | 20h | 1,632 |  |
| 216 | 1.3.3.3.8 | **Accessories** | 13d? | 2010-01-15 | 2010-02-02 |  | 196.15d |  |  | 104h | 6,240 |  |
| 217 | 1.3.3.3.8.1 | **Alignment Tooling** | 6.5d? | 2010-01-25 | 2010-02-02 |  | 234.25d |  |  | 52h | 3,120 |  |
| 218 | 1.3.3.3.8.1.1 | Initial Specifications | 1.5d? | 2010-01-25 | 2010-01-26 | 157, 222 | 234.25d | 0d | ME - John Canfield | 12h | 720 | PD |
| 219 | 1.3.3.3.8.1.2 | Mechanical Model | 5d? | 2010-01-27 | 2010-02-02 | 218 | 234.25d |  | ME - John Canfield | 40h | 2,400 | PD |
| 220 | 1.3.3.3.8.2 | **Assembly Tooling** | 6.5d? | 2010-01-15 | 2010-01-25 |  | 196.15d |  |  | 52h | 3,120 |  |
| 221 | 1.3.3.3.8.2.1 | Initial Specifications | 1.5d? | 2010-01-15 | 2010-01-18 | 157 | 196.15d | 0d | ME - John Canfield | 12h | 720 | PD |
| 222 | 1.3.3.3.8.2.2 | Mechanical Model | 5d? | 2010-01-18 | 2010-01-25 | 221 | 196.15d | 0d | ME - John Canfield | 40h | 2,400 | PD |
