# Imager_and_IFS_PD_Phase_v1_2_tracked_Sept09

Schedule from MS Project, 2009-05-01 to 2011-04-22, costs in $, A marks actual dates.
CARA

## Calendars

- Standard: Mon-Fri 08:00-12:00, 13:00-17:00; Sat-Sun off.

## Resources

| Resource | Group | Rate |
| --- | --- | --- |
| Sean Adkins | WMKO | 87 |
| Instrument Scientist | UCLA |  |
| Science Team |  |  |
| ME - Jim Bell | WMKO | 60 |
| ME - TBD | UCLA | 60 |
| Electronics Engineer | UCLA | 60 |
| Software Engineer | TBD | 60 |
| OE - Optical Engineer 2 |  | 70 |
| WMKO Support Astronomer | WMKO | 57 |
| WMKO Software Staff | WMKO | 57 |
| WMKO Instrument Staff | WMKO | 57 |
| WMKO Electronics Staff | WMKO | 57 |
| ME - Bob Weber | CIT | 60 |
| OE - Sergey Panteleev |  | 70 |

## Schedule

| ID | WBS | Task | Type | Duration | Start | Finish | Predecessors | Complete | Remaining | Total slack | Constraint | Resources | Work | Actual work | Cost | Actual cost | Text1 |
| --- | --- | --- | --- | --- | --- | --- | --- | --- | --- | --- | --- | --- | --- | --- | --- | --- | --- |
| 1 | 0 | **Milestones** |  | 296.18d? | 2009-05-01 A | 2010-06-21 |  |  | 296.18d? | 218.87d |  |  |  |  |  |  |  |
| 2 | 0.1 | Project Start | milestone | 0d? | 2009-05-01 A | 2009-05-01 A |  | 100% |  |  |  |  |  |  |  |  | PD |
| 3 | 0.2 | Imager Preliminary Design Review | milestone | 0d? | 2010-06-14 | 2010-06-14 | 63FS-1d |  |  | 223.89d |  |  |  |  |  |  | PD |
| 4 | 0.3 | IFS System Design Review | milestone | 0d | 2010-06-21 | 2010-06-21 | 119FS-1d |  |  | 218.87d |  |  |  |  |  |  |  |
| 5 | 1 | **Near-IR Imager and IFS** |  | 491.05d? | 2009-06-04 A | 2011-04-22 |  | 6% | 461.02d? | 0d |  |  | 7792.4h | 145.6h | 437,434.72 | 12,667.2 |  |
| 6 | 1.1 | **Management** |  | 377.5d? | 2009-06-04 A | 2010-11-15 |  | 6% | 354.31d? | 113.55d |  |  | 1148.4h | 57.6h | 76,676 | 5,011.2 |  |
| 7 | 1.1.1 | **Monthly Reports** |  | 371d | 2009-06-05 A | 2010-11-05 |  | 28% | 267.94d | 119.05d |  |  | 115.2h | 32h | 10,022.4 | 2,784 |  |
| 8 | 1.1.1.1 | Monthly Reports 1 |  | 1d | 2009-06-05 A | 2009-06-05 A |  | 100% |  |  | start no earlier than 2009-06-05 | Sean Adkins [80%] | 6.4h | 6.4h | 556.8 | 556.8 |  |
| 9 | 1.1.1.2 | Monthly Reports 2 |  | 1d | 2009-07-06 A | 2009-07-06 A |  | 100% |  |  | start no earlier than 2009-07-05 | Sean Adkins [80%] | 6.4h | 6.4h | 556.8 | 556.8 |  |
| 10 | 1.1.1.3 | Monthly Reports 3 |  | 1d | 2009-08-05 A | 2009-08-05 A |  | 100% |  |  | start no earlier than 2009-08-05 | Sean Adkins [80%] | 6.4h | 6.4h | 556.8 | 556.8 |  |
| 11 | 1.1.1.4 | Monthly Reports 4 |  | 1d | 2009-09-07 A | 2009-09-07 A |  | 100% |  |  | start no earlier than 2009-09-05 | Sean Adkins [80%] | 6.4h | 6.4h | 556.8 | 556.8 |  |
| 12 | 1.1.1.5 | Monthly Reports 5 |  | 1d | 2009-10-05 A | 2009-10-05 A |  | 100% |  |  | start no earlier than 2009-10-05 | Sean Adkins [80%] | 6.4h | 6.4h | 556.8 | 556.8 |  |
| 13 | 1.1.1.6 | Monthly Reports 6 |  | 1d | 2009-11-05 | 2009-11-05 |  |  |  | 380.05d | start no earlier than 2009-11-05 | Sean Adkins [80%] | 6.4h |  | 556.8 |  |  |
| 14 | 1.1.1.7 | Monthly Reports 7 |  | 1d | 2009-12-07 | 2009-12-07 |  |  |  | 358.05d | start no earlier than 2009-12-05 | Sean Adkins [80%] | 6.4h |  | 556.8 |  |  |
| 15 | 1.1.1.8 | Monthly Reports 8 |  | 1d | 2010-01-05 | 2010-01-05 |  |  |  | 337.05d | start no earlier than 2010-01-05 | Sean Adkins [80%] | 6.4h |  | 556.8 |  |  |
| 16 | 1.1.1.9 | Monthly Reports 9 |  | 1d | 2010-02-05 | 2010-02-05 |  |  |  | 314.05d | start no earlier than 2010-02-05 | Sean Adkins [80%] | 6.4h |  | 556.8 |  |  |
| 17 | 1.1.1.10 | Monthly Reports 10 |  | 1d | 2010-03-05 | 2010-03-05 |  |  |  | 294.05d | start no earlier than 2010-03-05 | Sean Adkins [80%] | 6.4h |  | 556.8 |  |  |
| 18 | 1.1.1.11 | Monthly Reports 11 |  | 1d | 2010-04-05 | 2010-04-05 |  |  |  | 273.05d | start no earlier than 2010-04-05 | Sean Adkins [80%] | 6.4h |  | 556.8 |  |  |
| 19 | 1.1.1.12 | Monthly Reports 12 |  | 1d | 2010-05-05 | 2010-05-05 |  |  |  | 251.05d | start no earlier than 2010-05-05 | Sean Adkins [80%] | 6.4h |  | 556.8 |  |  |
| 20 | 1.1.1.13 | Monthly Reports 13 |  | 1d | 2010-06-07 | 2010-06-07 |  |  |  | 228.05d | start no earlier than 2010-06-05 | Sean Adkins [80%] | 6.4h |  | 556.8 |  |  |
| 21 | 1.1.1.14 | Monthly Reports 14 |  | 1d | 2010-07-05 | 2010-07-05 |  |  |  | 208.05d | start no earlier than 2010-07-05 | Sean Adkins [80%] | 6.4h |  | 556.8 |  |  |
| 22 | 1.1.1.15 | Monthly Reports 15 |  | 1d | 2010-08-05 | 2010-08-05 |  |  |  | 185.05d | start no earlier than 2010-08-05 | Sean Adkins [80%] | 6.4h |  | 556.8 |  |  |
| 23 | 1.1.1.16 | Monthly Reports 16 |  | 1d | 2010-09-06 | 2010-09-06 |  |  |  | 163.05d | start no earlier than 2010-09-05 | Sean Adkins [80%] | 6.4h |  | 556.8 |  |  |
| 24 | 1.1.1.17 | Monthly Reports 17 |  | 1d | 2010-10-05 | 2010-10-05 |  |  |  | 142.05d | start no earlier than 2010-10-05 | Sean Adkins [80%] | 6.4h |  | 556.8 |  |  |
| 25 | 1.1.1.18 | Monthly Reports 18 |  | 1d | 2010-11-05 | 2010-11-05 |  |  |  | 119.05d | start no earlier than 2010-11-05 | Sean Adkins [80%] | 6.4h |  | 556.8 |  |  |

| ID | WBS | Task | Duration | Start | Finish | Predecessors | Complete | Remaining | Total slack | Constraint | Resources | Work | Actual work | Cost | Actual cost | Text1 | Text2 |
| --- | --- | --- | --- | --- | --- | --- | --- | --- | --- | --- | --- | --- | --- | --- | --- | --- | --- |
| 26 | 1.1.2 | **Project Meetings** | 294.5d | 2009-09-29 | 2010-11-15 |  |  |  | 113.55d |  |  | 425.2h |  | 24,381.6 |  |  |  |
| 27 | 1.1.2.1 | Project Meetings 1 | 4h | 2009-09-29 | 2009-09-29 |  |  |  | 407.55d | start no earlier than 2009-09-29 | Sean Adkins [80%]; Instrument Scientist [70%]; OE - Optical Engineer 2 [90%]; ME - Jim Bell [90%]; ME - TBD [90%]; Software Engineer [90%]; WMKO Support Astronomer; WMKO Electronics Staff | 28.4h |  | 1,634.4 |  |  |  |
| 28 | 1.1.2.2 | Project Meetings 2 | 4h | 2009-10-15 | 2009-10-15 |  |  |  | 395.55d | start no earlier than 2009-10-15 | Sean Adkins [80%]; Instrument Scientist [70%]; ME - TBD [90%]; OE - Optical Engineer 2 [90%]; Software Engineer [90%]; WMKO Support Astronomer; WMKO Electronics Staff; ME - Jim Bell | 28.8h |  | 1,658.4 |  |  |  |
| 29 | 1.1.2.3 | Project Meetings 3 | 4h | 2009-11-16 | 2009-11-16 |  |  |  | 373.55d | start no earlier than 2009-11-15 | Sean Adkins [80%]; Instrument Scientist [70%]; ME - TBD [90%]; OE - Optical Engineer 2 [90%]; Software Engineer [90%]; WMKO Support Astronomer; WMKO Electronics Staff; ME - Jim Bell | 28.8h |  | 1,658.4 |  |  |  |
| 30 | 1.1.2.4 | Project Meetings 4 | 116h | 2009-12-15 | 2010-01-04 |  |  |  | 338.55d | start no earlier than 2009-12-15 | Sean Adkins [80%]; Instrument Scientist [70%]; ME - TBD [90%]; OE - Optical Engineer 2 [90%]; Software Engineer [90%]; WMKO Support Astronomer; WMKO Electronics Staff; ME - Jim Bell | 28.8h |  | 1,658.4 |  |  |  |
| 31 | 1.1.2.5 | Project Meetings 5 | 4h | 2010-01-15 | 2010-01-15 |  |  |  | 329.55d | start no earlier than 2010-01-15 | Sean Adkins [80%]; Instrument Scientist [70%]; ME - TBD [90%]; OE - Optical Engineer 2 [90%]; Software Engineer [90%]; WMKO Support Astronomer; WMKO Electronics Staff; ME - Jim Bell | 28.8h |  | 1,658.4 |  |  |  |
| 32 | 1.1.2.6 | Project Meetings 6 | 4h | 2010-02-15 | 2010-02-15 |  |  |  | 308.55d | start no earlier than 2010-02-15 | Sean Adkins [80%]; Instrument Scientist [70%]; ME - TBD [90%]; OE - Optical Engineer 2 [90%]; Software Engineer [90%]; WMKO Support Astronomer; WMKO Electronics Staff; ME - Jim Bell | 28.8h |  | 1,658.4 |  |  |  |
| 33 | 1.1.2.7 | Project Meetings 7 | 4h | 2010-03-15 | 2010-03-15 |  |  |  | 288.55d | start no earlier than 2010-03-15 | Sean Adkins [80%]; Instrument Scientist [70%]; ME - TBD [90%]; OE - Optical Engineer 2 [90%]; Software Engineer [90%]; WMKO Support Astronomer; WMKO Electronics Staff; ME - Jim Bell | 25.6h |  | 1,380 |  |  |  |
| 34 | 1.1.2.8 | Project Meetings 8 | 4h | 2010-04-15 | 2010-04-15 |  |  |  | 265.55d | start no earlier than 2010-04-15 | Sean Adkins [80%]; Instrument Scientist [70%]; ME - Jim Bell [90%]; ME - TBD [90%]; OE - Optical Engineer 2 [90%]; Software Engineer [90%]; WMKO Support Astronomer; WMKO Electronics Staff | 28.4h |  | 1,634.4 |  |  |  |
| 35 | 1.1.2.9 | Project Meetings 9 | 4h | 2010-05-17 | 2010-05-17 |  |  |  | 243.55d | start no earlier than 2010-05-15 | Sean Adkins [80%]; Instrument Scientist [70%]; ME - Jim Bell [90%]; ME - TBD [90%]; OE - Optical Engineer 2 [90%]; Software Engineer [90%]; WMKO Support Astronomer; WMKO Electronics Staff | 28.4h |  | 1,634.4 |  |  |  |
| 36 | 1.1.2.10 | Project Meetings 10 | 4h | 2010-06-15 | 2010-06-15 |  |  |  | 222.55d | start no earlier than 2010-06-15 | Sean Adkins [80%]; Instrument Scientist [70%]; ME - Jim Bell [90%]; ME - TBD [90%]; OE - Optical Engineer 2 [90%]; Software Engineer [90%]; WMKO Support Astronomer; WMKO Electronics Staff | 28.4h |  | 1,634.4 |  |  |  |
| 37 | 1.1.2.11 | Project Meetings 11 | 4h | 2010-07-15 | 2010-07-15 |  |  |  | 200.55d | start no earlier than 2010-07-15 | Sean Adkins [80%]; Instrument Scientist [70%]; ME - Jim Bell [90%]; ME - TBD [90%]; OE - Optical Engineer 2 [90%]; Software Engineer [90%]; WMKO Support Astronomer; WMKO Electronics Staff | 28.4h |  | 1,634.4 |  |  |  |
| 38 | 1.1.2.12 | Project Meetings 12 | 4h | 2010-08-16 | 2010-08-16 |  |  |  | 178.55d | start no earlier than 2010-08-15 | Sean Adkins [80%]; Instrument Scientist [70%]; ME - Jim Bell [90%]; ME - TBD [90%]; OE - Optical Engineer 2 [90%]; Software Engineer [90%]; WMKO Support Astronomer; WMKO Electronics Staff | 28.4h |  | 1,634.4 |  |  |  |
| 39 | 1.1.2.13 | Project Meetings 13 | 4h | 2010-09-15 | 2010-09-15 |  |  |  | 156.55d | start no earlier than 2010-09-15 | Sean Adkins [80%]; Instrument Scientist [70%]; ME - Jim Bell [90%]; ME - TBD [90%]; OE - Optical Engineer 2 [90%]; Software Engineer [90%]; WMKO Support Astronomer; WMKO Electronics Staff | 28.4h |  | 1,634.4 |  |  |  |
| 40 | 1.1.2.14 | Project Meetings 14 | 4h | 2010-10-15 | 2010-10-15 |  |  |  | 134.55d | start no earlier than 2010-10-15 | Sean Adkins [80%]; Instrument Scientist [70%]; ME - Jim Bell [90%]; ME - TBD [90%]; OE - Optical Engineer 2 [90%]; Software Engineer [90%]; WMKO Support Astronomer; WMKO Electronics Staff | 28.4h |  | 1,634.4 |  |  |  |
| 41 | 1.1.2.15 | Project Meetings 15 | 4h | 2010-11-15 | 2010-11-15 |  |  |  | 113.55d | start no earlier than 2010-11-15 | Sean Adkins [80%]; Instrument Scientist [70%]; ME - Jim Bell [90%]; ME - TBD [90%]; OE - Optical Engineer 2 [90%]; Software Engineer [90%]; WMKO Support Astronomer; WMKO Electronics Staff | 28.4h |  | 1,634.4 |  |  |  |
| 42 | 1.1.3 | System Engineering Management Plan | 12.5d | 2010-02-15 | 2010-03-03 |  |  |  | 296.48d | start no earlier than 2010-02-14 | Sean Adkins [20%] | 20h |  | 1,740 |  | PD | IFS |
| 43 | 1.1.4 | Proposals to Fund Future Phases (ATI, MRI would be early 2010) | 43d? | 2010-05-03 | 2010-06-30 |  |  |  | 211.05d | start no earlier than 2010-05-02 | Sean Adkins [11.6%] | 40h |  | 3,480 |  | PD |  |
| 44 | 1.1.5 | Cost Review | 25d? | 2010-04-09 | 2010-05-25 | 154 |  |  | 237.43d |  | Sean Adkins [20%] | 40h |  | 3,480 |  | PD |  |
| 45 | 1.1.6 | **Project Plan Maintenance** | 328d | 2009-06-04 A | 2010-09-06 |  | 33% | 218.67d | 163.05d |  |  | 38.4h | 12.8h | 3,340.8 | 1,113.6 |  |  |
| 46 | 1.1.6.1 | Project Plan Maintenance 1 | 1d | 2009-06-04 A | 2009-06-04 A |  | 100% |  |  | start no earlier than 2009-06-04 | Sean Adkins [80%] | 6.4h | 6.4h | 556.8 | 556.8 |  |  |
| 47 | 1.1.6.2 | Project Plan Maintenance 2 | 1d | 2009-09-04 A | 2009-09-04 A |  | 100% |  |  | start no earlier than 2009-09-04 | Sean Adkins [80%] | 6.4h | 6.4h | 556.8 | 556.8 |  |  |
| 48 | 1.1.6.3 | Project Plan Maintenance 3 | 1d | 2009-12-04 | 2009-12-04 |  |  |  | 359.05d | start no earlier than 2009-12-04 | Sean Adkins [80%] | 6.4h |  | 556.8 |  |  |  |
| 49 | 1.1.6.4 | Project Plan Maintenance 4 | 1d | 2010-03-04 | 2010-03-04 |  |  |  | 295.05d | start no earlier than 2010-03-04 | Sean Adkins [80%] | 6.4h |  | 556.8 |  |  |  |
| 50 | 1.1.6.5 | Project Plan Maintenance 5 | 1d | 2010-06-04 | 2010-06-04 |  |  |  | 229.05d | start no earlier than 2010-06-04 | Sean Adkins [80%] | 6.4h |  | 556.8 |  |  |  |
| 51 | 1.1.6.6 | Project Plan Maintenance 6 | 1d | 2010-09-06 | 2010-09-06 |  |  |  | 163.05d | start no earlier than 2010-09-04 | Sean Adkins [80%] | 6.4h |  | 556.8 |  |  |  |

| ID | WBS | Task | Duration | Start | Finish | Predecessors | Complete | Remaining | Total slack | Free slack | Constraint | Resources | Work | Actual work | Cost | Actual cost | Text1 |
| --- | --- | --- | --- | --- | --- | --- | --- | --- | --- | --- | --- | --- | --- | --- | --- | --- | --- |
| 52 | 1.1.7 | **Budget Maintenance** | 348d | 2009-06-04 A | 2010-10-04 |  | 22% | 270.67d | 143.05d |  |  |  | 57.6h | 12.8h | 5,011.2 | 1,113.6 |  |
| 53 | 1.1.7.1 | Budget Maintenance 1 | 1d | 2009-06-04 A | 2009-06-04 A |  | 100% |  |  |  | start no earlier than 2009-06-04 | Sean Adkins [80%] | 6.4h | 6.4h | 556.8 | 556.8 |  |
| 54 | 1.1.7.2 | Budget Maintenance 2 | 1d | 2009-08-04 A | 2009-08-04 A |  | 100% |  |  |  | start no earlier than 2009-08-04 | Sean Adkins [80%] | 6.4h | 6.4h | 556.8 | 556.8 |  |
| 55 | 1.1.7.3 | Budget Maintenance 3 | 1d | 2009-10-05 | 2009-10-05 |  |  |  | 391.73d |  | start no earlier than 2009-10-04 | Sean Adkins [80%] | 6.4h |  | 556.8 |  |  |
| 56 | 1.1.7.4 | Budget Maintenance 4 | 1d | 2009-12-04 | 2009-12-04 |  |  |  | 347.73d |  | start no earlier than 2009-12-04 | Sean Adkins [80%] | 6.4h |  | 556.8 |  |  |
| 57 | 1.1.7.5 | Budget Maintenance 5 | 1d | 2010-02-04 | 2010-02-04 |  |  |  | 303.73d |  | start no earlier than 2010-02-04 | Sean Adkins [80%] | 6.4h |  | 556.8 |  |  |
| 58 | 1.1.7.6 | Budget Maintenance 6 | 1d | 2010-04-05 | 2010-04-05 |  |  |  | 261.73d |  | start no earlier than 2010-04-04 | Sean Adkins [80%] | 6.4h |  | 556.8 |  |  |
| 59 | 1.1.7.7 | Budget Maintenance 7 | 1d | 2010-06-04 | 2010-06-04 |  |  |  | 217.73d |  | start no earlier than 2010-06-04 | Sean Adkins [80%] | 6.4h |  | 556.8 |  |  |
| 60 | 1.1.7.8 | Budget Maintenance 8 | 1d | 2010-08-04 | 2010-08-04 |  |  |  | 174.73d |  | start no earlier than 2010-08-04 | Sean Adkins [80%] | 6.4h |  | 556.8 |  |  |
| 61 | 1.1.7.9 | Budget Maintenance 9 | 1d | 2010-10-04 | 2010-10-04 |  |  |  | 131.73d |  | start no earlier than 2010-10-04 | Sean Adkins [80%] | 6.4h |  | 556.8 |  |  |
| 62 | 1.1.8 | Preliminary Design Report | 10d | 2010-05-14 | 2010-05-28 | 70, 198, 220, 154 |  |  | 222.89d | 0d |  | Sean Adkins; Instrument Scientist; ME - Jim Bell; ME - TBD; Software Engineer; Electronics Engineer; WMKO Support Astronomer; WMKO Software Staff; WMKO Instrument Staff; WMKO Electronics Staff; OE - Optical Engineer 2 | 280h |  | 17,720 |  | PD |
| 63 | 1.1.9 | Preliminary Design Review | 1.5d | 2010-06-11 | 2010-06-15 | 62FS+2w |  |  | 222.89d | 0d |  | Sean Adkins; Instrument Scientist; ME - Jim Bell; ME - TBD; Software Engineer; Electronics Engineer; WMKO Support Astronomer; WMKO Software Staff; WMKO Instrument Staff; WMKO Electronics Staff; OE - Optical Engineer 2 | 132h |  | 7,500 |  |  |
| 64 | 1.2 | **Science** | 130.16d? | 2009-11-13 | 2010-05-14 |  |  |  | 244.89d |  |  |  | 224h |  | 8,178 |  |  |
| 65 | 1.2.1 | **Science Team Meetings** | 36.5d? | 2009-11-13 | 2010-01-04 |  |  |  | 338.55d |  |  |  | 64h |  | 2,088 |  |  |
| 66 | 1.2.1.1 | Meeting 1 | 1.5d? | 2009-11-13 | 2009-11-16 | 2FS+7mo |  |  | 373.55d |  |  | Sean Adkins; Instrument Scientist; Science Team | 32h |  | 1,044 |  | PD |
| 67 | 1.2.1.2 | Meeting 2 | 2d? | 2009-12-11 | 2010-01-04 | 2FS+8mo |  |  | 338.55d |  |  | Sean Adkins; Instrument Scientist; Science Team | 32h |  | 1,044 |  | PD |
| 68 | 1.2.2 | **Common Observing Operations Concept Document** | 130.16d? | 2009-11-13 | 2010-05-14 |  |  |  | 244.89d |  |  |  | 160h |  | 6,090 |  |  |
| 69 | 1.2.2.1 | Initial Draft | 19.75d? | 2009-11-13 | 2009-12-10 | 2FS+7mo |  |  | 355.3d |  |  | Sean Adkins [20%]; Instrument Scientist [20%]; Science Team [20%] | 70h |  | 2,610 |  | PD |
| 70 | 1.2.2.2 | Final Version | 31.09d? | 2010-03-31 | 2010-05-14 | 188, 207FS-2w |  |  | 222.89d | 0d |  | Sean Adkins [20%]; Instrument Scientist [20%]; Science Team [20%] | 90h |  | 3,480 |  | PD |
| 71 | 1.3 | **Instrument Design and Fabrication** | 481.05d? | 2009-06-18 A | 2011-04-22 |  | 6% | 449.99d? | 0d |  |  |  | 6420h | 88h | 352,580.72 | 7,656 |  |
| 72 | 1.3.1 | **AO System to Instrument Interface Definitions** | 14d? | 2009-09-14 | 2009-10-02 |  |  |  | 405.05d |  |  |  | 136h |  | 9,708 |  | PD |
| 73 | 1.3.1.1 | Optical | 2.6d? | 2009-09-14 | 2009-09-16 | 81 |  |  | 405.05d | 0d |  | Sean Adkins; OE - Optical Engineer 2 | 28h |  | 2,096 |  | PD |
| 74 | 1.3.1.2 | Mechanical | 3.5d? | 2009-09-16 | 2009-09-24 | 73 |  |  | 405.05d | 0d |  | Sean Adkins; ME - Jim Bell | 28h |  | 1,896 |  | PD |
| 75 | 1.3.1.3 | Electronic/Electrical | 1.5d? | 2009-09-24 | 2009-09-25 | 74 |  |  | 405.05d | 0d |  | Sean Adkins | 12h |  | 1,044 |  | PD |
| 76 | 1.3.1.4 | Software | 2.5d? | 2009-09-25 | 2009-09-30 | 75 |  |  | 405.05d | 0d |  | Sean Adkins; Software Engineer | 28h |  | 1,896 |  | PD |
| 77 | 1.3.1.5 | Alignment and Calibration Concept for Instrument on AO System | 2d? | 2009-09-30 | 2009-10-02 | 76 |  |  | 405.05d |  |  | Sean Adkins; OE - Optical Engineer 2; ME - Jim Bell | 40h |  | 2,776 |  | PD |

Notes:
- 62: Effort for team members includes writing PD report.

| ID | WBS | Task | Duration | Start | Finish | Predecessors | Complete | Remaining | Total slack | Free slack | Constraint | Resources | Work | Actual work | Cost | Actual cost | Text1 | Text2 |
| --- | --- | --- | --- | --- | --- | --- | --- | --- | --- | --- | --- | --- | --- | --- | --- | --- | --- | --- |
| 78 | 1.3.2 | **Shared Facilities** | 223.85d? | 2009-06-18 A | 2010-04-27 |  | 27% | 162.76d? | 257.2d |  |  |  | 216h | 48h | 15,706 | 4,176 |  |  |
| 79 | 1.3.2.1 | **AO System** | 223.85d? | 2009-06-18 A | 2010-04-27 |  | 33% | 149.6d? | 257.2d |  |  |  | 176h | 48h | 13,036 | 4,176 |  |  |
| 80 | 1.3.2.1.1 | **High Order AO Relay** | 223.85d? | 2009-06-18 A | 2010-04-27 |  | 75% | 54.9d? | 257.2d |  |  |  | 68h | 48h | 5,916 | 4,176 |  |  |
| 81 | 1.3.2.1.1.1 | Design Liason | 38.47d? | 2009-06-18 A | 2009-09-14 A |  | 100% |  |  |  | start no earlier than 2009-06-18 | Sean Adkins [16.1%] | 48h | 48h | 4,176 | 4,176 | PD |  |
| 82 | 1.3.2.1.1.2 | RTC and Control Liason | 12.5d? | 2010-04-09 | 2010-04-27 | 207SS |  |  | 257.2d |  |  | Sean Adkins [20%] | 20h |  | 1,740 |  | PD |  |
| 83 | 1.3.2.1.2 | **ADC** | 35d? | 2009-10-05 | 2009-11-20 |  |  |  | 369.05d |  |  |  | 56h |  | 4,464 |  |  |  |
| 84 | 1.3.2.1.2.1 | Requirements Liason | 20d? | 2009-10-05 | 2009-10-30 | 81FS+2w |  |  | 369.05d | 0d |  | Sean Adkins [20%] | 32h |  | 2,784 |  | PD |  |
| 85 | 1.3.2.1.2.2 | Design Liason | 15d? | 2009-11-02 | 2009-11-20 | 84 |  |  | 369.05d |  |  | OE - Optical Engineer 2 [20%] | 24h |  | 1,680 |  | PD |  |
| 86 | 1.3.2.1.3 | **Calibration Faciltiy** | 30d? | 2010-01-11 | 2010-02-22 |  |  |  | 303.4d |  |  |  | 52h |  | 2,656 |  |  |  |
| 87 | 1.3.2.1.3.1 | Requirements Liason | 10d? | 2010-01-11 | 2010-01-25 | 148, 91 |  |  | 303.4d | 0d |  | Sean Adkins [20%]; Instrument Scientist [20%]; OE - Optical Engineer 2 [20%] | 28h |  | 1,536 |  | PD |  |
| 88 | 1.3.2.1.3.2 | Design Liason | 20d? | 2010-01-25 | 2010-02-22 | 87 |  |  | 303.4d |  |  | Instrument Scientist [10%]; OE - Optical Engineer 2 [10%] | 24h |  | 1,120 |  | PD |  |
| 89 | 1.3.2.2 | **Nasmyth Enclosure** | 29.48d? | 2010-03-16 | 2010-04-27 |  |  |  | 257.71d |  |  |  | 40h |  | 2,670 |  |  |  |
| 90 | 1.3.2.2.1 | Requirements Liason | 12.5d? | 2010-03-16 | 2010-04-08 | 152, 81FS+7d |  |  | 257.71d | 0d |  | Sean Adkins [20%]; ME - Jim Bell [20%] | 20h |  | 1,470 |  | PD |  |
| 91 | 1.3.2.2.2 | Design Liason | 12.5d? | 2010-04-08 | 2010-04-27 | 90 |  |  | 257.71d |  |  | ME - Jim Bell [20%] | 20h |  | 1,200 |  | PD |  |
| 92 | 1.3.3 | **Instrument** | 473.05d? | 2009-06-30 A | 2011-04-22 |  | 3% | 459.13d? | 0d |  |  |  | 6068h | 40h | 327,166.72 | 3,480 |  |  |
| 93 | 1.3.3.1 | **IFS System Design Phase** | 166.18d? | 2009-11-02 | 2010-06-22 |  |  |  | 0d |  |  |  | 1712h |  | 83,467.37 |  | PD | IFS |
| 94 | 1.3.3.1.1 | **IFS Performance Budgets** | 56.34d | 2009-11-02 | 2010-01-19 |  |  |  | 0d |  |  |  | 260h |  | 11,576.17 |  | PD | IFS |
| 95 | 1.3.3.1.1.1 | Throughput | 6.67d | 2009-11-02 | 2009-11-10 | 141FS+2mo |  |  | 0d |  |  | Sean Adkins [50%]; Instrument Scientist [50%]; OE - Sergey Panteleev [50%] | 60h |  | 2,446.67 |  | PD | IFS |
| 96 | 1.3.3.1.1.2 | Background | 5d | 2009-11-10 | 2009-11-26 | 95 |  |  | 0.85d | 0d |  | Sean Adkins [50%]; Instrument Scientist [50%]; OE - Sergey Panteleev [50%] | 40h |  | 1,980 |  | PD | IFS |
| 97 | 1.3.3.1.1.3 | Wavefront error | 6.67d | 2009-11-26 | 2009-12-04 | 96 |  |  | 0.85d | 0d |  | Sean Adkins [50%]; Instrument Scientist [50%]; OE - Sergey Panteleev [50%] | 60h |  | 2,446.67 |  | PD | IFS |
| 98 | 1.3.3.1.1.4 | Spectroscopic performance | 14.27d | 2009-12-04 | 2010-01-12 | 97 |  |  | 0.85d | 0d |  | Sean Adkins [50%]; Instrument Scientist [50%]; OE - Sergey Panteleev [38%] | 80h |  | 3,390.34 |  | PD | IFS |
| 99 | 1.3.3.1.1.5 | Size and mass | 5.21d | 2010-01-12 | 2010-01-19 | 98 |  |  | 327.71d |  |  | Sean Adkins [50%]; ME - Jim Bell [38%] | 20h |  | 1,312.5 |  | PD | IFS |
| 100 | 1.3.3.1.2 | **Trade Studies** | 93.95d | 2009-11-10 | 2010-03-22 |  |  |  | 0d |  |  |  | 420h |  | 19,087.58 |  | PD | IFS |
| 101 | 1.3.3.1.2.1 | FOV and spatial sampling | 14.31d | 2009-11-10 | 2009-12-11 | 95 |  |  | 0d |  |  | Sean Adkins [33.3%]; Instrument Scientist [50%]; OE - Sergey Panteleev [33%] | 90h |  | 4,461.53 |  | PD | IFS |
| 102 | 1.3.3.1.2.2 | Wavelength coverage and spatial sampling | 14.47d | 2009-12-11 | 2010-01-12 | 101, 95 |  |  | 0d |  |  | Sean Adkins [50%]; Instrument Scientist [50%]; OE - Sergey Panteleev [33%] | 70h |  | 3,202.78 |  | PD | IFS |
| 103 | 1.3.3.1.2.3 | Optimization of image slicing formats and spectrograph formats | 20.25d | 2010-01-12 | 2010-02-22 | 98, 102 |  |  | 0d |  |  | Sean Adkins [33.3%]; Instrument Scientist [50%]; OE - Sergey Panteleev [33%]; ME - TBD [50%] | 110h |  | 5,784.33 |  | PD | IFS |
| 104 | 1.3.3.1.2.4 | Separate or combined capability above and below 1 micron | 8.78d | 2010-02-22 | 2010-03-05 | 103 |  |  | 283.43d | 0d |  | Sean Adkins [50%]; Instrument Scientist [50%]; OE - Sergey Panteleev [33%] | 70h |  | 2,640.8 |  | PD | IFS |
| 105 | 1.3.3.1.2.5 | Wavefront error allocations | 7.17d | 2010-03-05 | 2010-03-16 | 104 |  |  | 283.43d | 0d |  | Sean Adkins [50%]; Instrument Scientist [50%]; OE - Sergey Panteleev [33%] | 50h |  | 1,532.99 |  | PD | IFS |
| 106 | 1.3.3.1.2.6 | Trade study report | 4.21d | 2010-03-16 | 2010-03-22 | 105 |  |  | 283.43d |  |  | Sean Adkins [16.7%]; Instrument Scientist [50%]; OE - Sergey Panteleev [50%] | 30h |  | 1,465.15 |  | PD | IFS |

| ID | WBS | Task | Duration | Start | Finish | Predecessors | Complete | Remaining | Total slack | Free slack | Constraint | Resources | Work | Actual work | Cost | Actual cost | Text1 | Text2 |
| --- | --- | --- | --- | --- | --- | --- | --- | --- | --- | --- | --- | --- | --- | --- | --- | --- | --- | --- |
| 107 | 1.3.3.1.3 | **Conceptual Designs** | 85.59d? | 2010-02-22 | 2010-06-22 |  |  |  | 0d |  |  |  | 940h |  | 47,705.65 |  | PD | IFS |
| 108 | 1.3.3.1.3.1 | Development of design options | 46.07d | 2010-02-22 | 2010-04-27 | 103 |  |  | 0d |  |  | Sean Adkins [50%]; Instrument Scientist [50%]; OE - Sergey Panteleev [17%]; ME - TBD [50%] | 380h |  | 16,556.94 |  | PD | IFS |
| 109 | 1.3.3.1.3.2 | Evaluation of design options | 9.74d? | 2010-04-27 | 2010-05-11 | 108 |  |  | 0d |  |  | Sean Adkins [50%]; Instrument Scientist [50%]; OE - Sergey Panteleev [50%]; ME - TBD [50%] | 140h |  | 7,678.05 |  | PD | IFS |
| 110 | 1.3.3.1.3.3 | Calibration and alignment issues | 5.58d? | 2010-05-11 | 2010-05-19 | 109 |  |  | 0d |  |  | Sean Adkins [50%]; Instrument Scientist [50%]; OE - Sergey Panteleev [50%]; ME - TBD [50%] | 60h |  | 3,122.46 |  | PD | IFS |
| 111 | 1.3.3.1.3.4 | Downselect of conceptual design | 5d? | 2010-05-19 | 2010-05-26 | 110 |  |  | 0d |  |  | Sean Adkins [50%]; Instrument Scientist [50%]; OE - Sergey Panteleev [50%]; ME - TBD [50%] | 80h |  | 4,340 |  | PD | IFS |
| 112 | 1.3.3.1.3.5 | Revised performance budgets | 4d? | 2010-05-26 | 2010-06-01 | 111 |  |  | 228.83d | 0d |  | Sean Adkins [50%]; Instrument Scientist [50%]; OE - Sergey Panteleev [50%] | 40h |  | 1,816 |  | PD | IFS |
| 113 | 1.3.3.1.3.6 | Performance budget report | 3.75d? | 2010-06-01 | 2010-06-07 | 112 |  |  | 228.83d |  |  | Sean Adkins [50%]; OE - Sergey Panteleev [50%] | 30h |  | 2,355 |  | PD | IFS |
| 114 | 1.3.3.1.3.7 | Performance estimates | 4.38d? | 2010-05-26 | 2010-06-08 | 111 |  |  | 0d |  |  | Sean Adkins [50%]; Instrument Scientist [50%]; OE - Sergey Panteleev [50%]; ME - TBD [50%] | 60h |  | 3,308.13 |  | PD | IFS |
| 115 | 1.3.3.1.3.8 | System requirements document | 4.38d? | 2010-06-08 | 2010-06-15 | 114 |  |  | 0d |  |  | Sean Adkins [50%]; Instrument Scientist [50%]; OE - Sergey Panteleev [50%]; ME - TBD [50%] | 70h |  | 3,797.5 |  | PD | IFS |
| 116 | 1.3.3.1.3.9 | System design manual | 4.85d? | 2010-06-15 | 2010-06-22 | 115 |  |  | 218d |  |  | Sean Adkins [75%]; Instrument Scientist [75%]; OE - Sergey Panteleev [75%]; ME - TBD [75%] | 80h |  | 4,731.57 |  | PD | IFS |
| 117 | 1.3.3.1.4 | **System Design Review** | 4.98d? | 2010-06-15 | 2010-06-22 | 114 |  |  | 0d |  |  |  | 92h |  | 5,097.97 |  | PD | IFS |
| 118 | 1.3.3.1.4.1 | System design report | 3.75d? | 2010-06-15 | 2010-06-18 | 115 |  |  | 0d |  |  | Sean Adkins [50%]; Instrument Scientist [50%]; OE - Sergey Panteleev [50%]; ME - TBD [50%] | 60h |  | 3,255 |  | PD | IFS |
| 119 | 1.3.3.1.4.2 | System design review meeting | 1.23d? | 2010-06-18 | 2010-06-22 | 118 |  |  | 0d |  |  | Sean Adkins [80%]; Instrument Scientist [80%]; OE - Sergey Panteleev [90%]; ME - TBD [90%] | 32h |  | 1,842.97 |  | PD | IFS |
| 120 | 1.3.3.2 | **IFS Preliminary Design Phase** | 217.87d? | 2010-06-22 | 2011-04-22 |  |  |  | 0d |  |  |  | 2148h |  | 107,197.9 |  | DD | IFS |
| 121 | 1.3.3.2.1 | Initial AO system to instrument interface definitions | 5.39d? | 2010-06-22 | 2010-07-01 | 119 |  |  | 0d |  |  | Sean Adkins [50%]; OE - Sergey Panteleev [50%]; ME - Jim Bell [50%] | 60h |  | 4,340 |  | DD | IFS |
| 122 | 1.3.3.2.2 | Alignment and calibration concept | 8.19d? | 2010-07-01 | 2010-07-13 | 121 |  |  | 0d |  |  | Sean Adkins [50%]; Instrument Scientist [50%]; OE - Sergey Panteleev [50%]; ME - Jim Bell [50%] | 100h |  | 4,669.23 |  | DD | IFS |
| 123 | 1.3.3.2.3 | Optical design | 91.7d? | 2010-07-13 | 2010-11-18 | 122 |  |  | 0d |  |  | Sean Adkins [50%]; Instrument Scientist [50%]; OE - Sergey Panteleev [50%] | 760h |  | 29,114.83 |  | DD | IFS |
| 124 | 1.3.3.2.4 | Mechanical design | 160.82d? | 2010-08-26 | 2011-04-07 | 123FS-60d |  |  | 0d |  |  | Sean Adkins [50%]; ME - Jim Bell [50%] | 680h |  | 41,880 |  | DD | IFS |
| 125 | 1.3.3.2.5 | Electronic design | 30d? | 2011-02-10 | 2011-03-24 | 123FS+60d |  |  | 10.82d | 0d |  | Sean Adkins [50%]; Electronics Engineer [50%] | 140h |  | 8,940 |  | DD | IFS |
| 126 | 1.3.3.2.6 | Software design | 23.53d? | 2011-02-10 | 2011-03-15 | 125SS |  |  | 17.29d |  |  | Sean Adkins [50%]; Instrument Scientist [50%]; Software Engineer [50%] | 200h |  | 6,670.59 |  | DD | IFS |
| 127 | 1.3.3.2.7 | Preliminary design report | 8.89d? | 2011-04-07 | 2011-04-20 | 121, 124, 125, 126 |  |  | 0d |  |  | Sean Adkins [50%]; Instrument Scientist [50%]; ME - Jim Bell [50%]; Electronics Engineer [50%]; OE - Sergey Panteleev [50%]; Software Engineer [50%] | 160h |  | 8,782.24 |  | DD | IFS |
| 128 | 1.3.3.2.8 | Preliminary design review meeting | 1.27d? | 2011-04-20 | 2011-04-22 | 127 |  |  | 0d |  |  | Sean Adkins [80%]; Instrument Scientist [80%]; ME - Jim Bell [90%]; Electronics Engineer [90%]; OE - Sergey Panteleev [90%]; Software Engineer [90%] | 48h |  | 2,801.01 |  | DD | IFS |
| 129 | 1.3.3.3 | **Near-IR Imager and IFS Preliminary Design** | 230.9d? | 2009-06-30 A | 2010-05-18 |  | 8% | 211.44d? | 242.15d |  |  |  | 2208h | 40h | 136,501.44 | 3,480 |  |  |
| 130 | 1.3.3.3.1 | **Imager Trade Studies** | 88.5d? | 2009-06-30 A | 2009-10-30 |  | 38% | 54.47d? | 384.55d |  |  |  | 104h |  | 6,189.44 |  | PD |  |
| 131 | 1.3.3.3.1.1 | Imager Wavefront Error | 4.75d? | 2009-10-05 | 2009-10-30 | 141FS+20d |  |  | 372.55d | 0d |  | Sean Adkins [80%]; Science Team; OE - Optical Engineer 2 [90%] | 40h |  | 2,421.44 |  | PD |  |
| 132 | 1.3.3.3.1.2 | Imager Pixel Scale | 7.1d? | 2009-06-30 A | 2009-10-07 |  | 75% | 1.77d? | 401.75d |  | start no earlier than 2009-06-30 | Sean Adkins [62.5%]; Science Team [62.5%]; OE - Optical Engineer 2 [62.5%] | 48h |  | 3,072 |  | PD |  |
| 133 | 1.3.3.3.1.3 | Imager Short Wavelength Cut-off | 2d? | 2009-10-05 | 2009-10-07 | 141FS+1mo |  |  | 368.28d | 0d |  | Sean Adkins; Science Team | 16h |  | 696 |  | PD |  |

| ID | WBS | Task | Duration | Start | Finish | Predecessors | Complete | Remaining | Total slack | Free slack | Resources | Work | Actual work | Cost | Actual cost | Text1 |
| --- | --- | --- | --- | --- | --- | --- | --- | --- | --- | --- | --- | --- | --- | --- | --- | --- |
| 134 | 1.3.3.3.2 | **Imager Performance Budgets** | 188.15d? | 2009-07-28 A | 2010-04-16 |  | 2% | 184.64d? | 264.9d |  |  | 124h |  | 9,268 |  | PD |
| 135 | 1.3.3.3.2.1 | Imager Sensitivity | 1d? | 2009-07-28 A | 2009-11-05 | 133FS+1mo | 50% | 0.5d? | 367.78d | 0d | Sean Adkins; OE - Optical Engineer 2 | 16h |  | 1,256 |  | PD |
| 136 | 1.3.3.3.2.2 | Imager Background | 4.5d? | 2009-11-05 | 2009-11-11 | 135 |  |  | 367.78d | 0d | Sean Adkins [25%]; OE - Optical Engineer 2 [25%] | 16h |  | 1,256 |  | PD |
| 137 | 1.3.3.3.2.3 | Imager Companion Sensitivity | 4.5d? | 2009-11-11 | 2009-11-24 | 136 |  |  | 367.78d |  | Sean Adkins; OE - Optical Engineer 2 | 36h |  | 2,724 |  | PD |
| 138 | 1.3.3.3.2.4 | Imager Wavefront Error | 12d? | 2009-10-30 | 2009-11-17 | 131 |  |  | 372.55d |  | Sean Adkins [25%]; OE - Optical Engineer 2 [25%] | 32h |  | 2,376 |  | PD |
| 139 | 1.3.3.3.2.5 | Imager Size and Mass | 4.8d? | 2010-04-09 | 2010-04-16 | 154 |  |  | 264.9d |  | Sean Adkins [41.7%]; ME - Jim Bell [41.7%] | 24h |  | 1,656 |  | PD |
| 140 | 1.3.3.3.3 | **Optical Design** | 119.65d? | 2009-07-28 A | 2010-01-11 |  | 33% | 79.81d? | 303.4d |  |  | 396h | 40h | 26,680 | 3,480 |  |
| 141 | 1.3.3.3.3.1 | Initial Optical Design | 18.1d? | 2009-07-28 A | 2009-09-04 A |  | 100% |  |  |  | Sean Adkins [31.1%] | 40h | 40h | 3,480 | 3,480 |  |
| 142 | 1.3.3.3.3.2 | **Optical Modeling** | 55.65d? | 2009-10-19 | 2010-01-04 |  |  |  | 222.89d |  |  | 292h |  | 19,356 |  |  |
| 143 | 1.3.3.3.3.2.1 | Fore Optics | 6d? | 2009-10-19 | 2009-10-29 | 141FS+6w |  |  | 222.89d | 0d | OE - Optical Engineer 2; Sean Adkins; Instrument Scientist | 56h |  | 3,632 |  | PD |
| 144 | 1.3.3.3.3.2.2 | Lyot Stop | 2d? | 2009-10-29 | 2009-11-02 | 143 |  |  | 222.89d | 0d | OE - Optical Engineer 2; Sean Adkins; Instrument Scientist | 24h |  | 1,468 |  | PD |
| 145 | 1.3.3.3.3.2.3 | Coronagraph | 1.5d? | 2009-11-02 | 2009-11-13 | 144 |  |  | 222.89d | 0d | OE - Optical Engineer 2; ME - Jim Bell; Instrument Scientist | 28h |  | 1,320 |  | PD |
| 146 | 1.3.3.3.3.2.4 | Imager Camera | 20d? | 2009-11-13 | 2009-12-11 | 145 |  |  | 222.89d | 0d | OE - Optical Engineer 2 | 160h |  | 11,200 |  | PD |
| 147 | 1.3.3.3.3.2.5 | IFS Fold Mirror | 1.76d? | 2009-12-11 | 2010-01-04 | 146 |  |  | 303.4d | 0d | Sean Adkins [80%]; OE - Optical Engineer 2 [90%]; ME - Jim Bell [90%] | 24h |  | 1,736 |  |  |
| 148 | 1.3.3.3.3.3 | Preliminary Design Performance Analysis | 5d? | 2010-01-04 | 2010-01-11 | 147 |  |  | 303.4d | 0d | OE - Optical Engineer 2; Sean Adkins; Instrument Scientist | 64h |  | 3,844 |  | PD |
| 149 | 1.3.3.3.4 | **Dewar** | 121.95d? | 2009-10-29 | 2010-04-19 |  |  |  | 253.39d |  |  | 1072h |  | 64,416 |  |  |
| 150 | 1.3.3.3.4.1 | **Cold Assemblies** | 115.45d? | 2009-10-29 | 2010-04-09 |  |  |  | 253.39d |  |  | 792h |  | 47,536 |  |  |
| 151 | 1.3.3.3.4.1.1 | **Dewar Internal Structure** | 18.5d? | 2010-03-15 | 2010-04-09 |  |  |  | 222.89d |  |  | 188h |  | 11,280 |  |  |
| 152 | 1.3.3.3.4.1.1.1 | Interface Specification | 1d? | 2010-03-15 | 2010-03-16 | 184 |  |  | 222.89d | 0d | ME - Jim Bell | 8h |  | 480 |  | PD |
| 153 | 1.3.3.3.4.1.1.2 | Mechanical Model | 10d? | 2010-03-16 | 2010-03-30 | 152 |  |  | 222.89d | 0d | ME - Jim Bell | 80h |  | 4,800 |  | PD |
| 154 | 1.3.3.3.4.1.1.3 | FEA | 7.5d? | 2010-03-30 | 2010-04-09 | 153, 188 |  |  | 237.43d | 0d | ME - Jim Bell | 60h |  | 3,600 |  | PD |
| 155 | 1.3.3.3.4.1.1.4 | Thermal Analysis | 5d? | 2010-03-30 | 2010-04-06 | 153 |  |  | 222.89d | 0d | ME - Jim Bell | 40h |  | 2,400 |  | PD |
| 156 | 1.3.3.3.4.1.2 | **Fore Optics** | 37d? | 2009-10-29 | 2009-12-21 |  |  |  | 299.17d |  |  | 188h |  | 11,400 |  |  |
| 157 | 1.3.3.3.4.1.2.1 | **Input Baffle & Coronagraph** | 26.5d? | 2009-11-13 | 2009-12-21 |  |  |  | 268.67d |  |  | 52h |  | 3,120 |  |  |
| 158 | 1.3.3.3.4.1.2.1.1 | Interface Specification | 1.5d? | 2009-11-13 | 2009-11-16 | 145 |  |  | 288.67d | 20d | ME - Jim Bell | 12h |  | 720 |  | PD |
| 159 | 1.3.3.3.4.1.2.1.2 | Mechanical Model | 5d? | 2009-12-14 | 2009-12-21 | 158, 173 |  |  | 268.67d | 0d | ME - Jim Bell | 40h |  | 2,400 |  | PD |

Notes:
- 159: Thermal analysis included in dewar structure thermal analysis task

| ID | WBS | Task | Duration | Start | Finish | Predecessors | Total slack | Free slack | Resources | Work | Cost | Text1 |
| --- | --- | --- | --- | --- | --- | --- | --- | --- | --- | --- | --- | --- |
| 160 | 1.3.3.3.4.1.2.2 | **Re-imager** | 6.5d? | 2009-10-29 | 2009-11-09 |  | 378.65d |  |  | 60h | 3,680 |  |
| 161 | 1.3.3.3.4.1.2.2.1 | Interface Specification | 1.5d? | 2009-10-29 | 2009-11-02 | 143 | 378.65d | 0d | OE - Optical Engineer 2; ME - Jim Bell | 20h | 1,280 | PD |
| 162 | 1.3.3.3.4.1.2.2.2 | Mechanical Model | 5d? | 2009-11-02 | 2009-11-09 | 161 | 378.65d |  | ME - Jim Bell | 40h | 2,400 | PD |
| 163 | 1.3.3.3.4.1.2.3 | **Adjustable Lyot Stop** | 9d? | 2009-11-02 | 2009-11-13 |  | 320.34d |  |  | 76h | 4,600 |  |
| 164 | 1.3.3.3.4.1.2.3.1 | Interface Specification | 1.5d? | 2009-11-02 | 2009-11-04 | 144 | 320.34d | 0d | OE - Optical Engineer 2; ME - Jim Bell | 16h | 1,000 | PD |
| 165 | 1.3.3.3.4.1.2.3.2 | Mechanical Model | 7.5d? | 2009-11-04 | 2009-11-13 | 164 | 320.34d | 76.95d | ME - Jim Bell | 60h | 3,600 | PD |
| 166 | 1.3.3.3.4.1.3 | **Filter Wheels** | 33.26d? | 2009-12-11 | 2010-01-27 |  | 267.57d |  |  | 156h | 9,176 |  |
| 167 | 1.3.3.3.4.1.3.1 | **Mechanism** | 33.26d? | 2009-12-11 | 2010-01-27 |  | 267.57d |  |  | 132h | 7,920 |  |
| 168 | 1.3.3.3.4.1.3.1.1 | Interface Specification | 1.67d? | 2009-12-11 | 2009-12-15 | 146 | 281.08d | 0d | ME - Bob Weber [90%] | 12h | 720 | PD |
| 169 | 1.3.3.3.4.1.3.1.2 | Mechanical Model | 16.67d? | 2010-01-05 | 2010-01-27 | 170 | 267.57d | 24.19d | ME - Bob Weber [90%] | 120h | 7,200 | PD |
| 170 | 1.3.3.3.4.1.3.2 | Filter Specifications | 2.43d? | 2009-12-15 | 2010-01-04 | 168 | 267.57d | 0d | Sean Adkins; OE - Optical Engineer 2; Instrument Scientist [70%] | 24h | 1,256 | PD |
| 171 | 1.3.3.3.4.1.4 | **Imager** | 61.45d? | 2009-12-11 | 2010-03-08 |  | 222.89d |  |  | 260h | 15,680 |  |
| 172 | 1.3.3.3.4.1.4.1 | **Camera** | 9d? | 2009-12-11 | 2009-12-24 |  | 222.89d |  |  | 80h | 4,880 |  |
| 173 | 1.3.3.3.4.1.4.1.1 | Interface Specification | 1.5d? | 2009-12-11 | 2009-12-14 | 146 | 222.89d | 0d | OE - Optical Engineer 2; ME - Jim Bell | 20h | 1,280 | PD |
| 174 | 1.3.3.3.4.1.4.1.2 | Mechanical Model | 7.5d? | 2009-12-14 | 2009-12-24 | 173 | 222.89d | 0d | ME - Jim Bell | 60h | 3,600 | PD |
| 175 | 1.3.3.3.4.1.4.2 | **Detector Head** | 52.45d? | 2009-12-24 | 2010-03-08 |  | 222.89d |  |  | 180h | 10,800 |  |
| 176 | 1.3.3.3.4.1.4.2.1 | **Mount** | 6d? | 2009-12-24 | 2010-01-01 |  | 222.89d |  |  | 48h | 2,880 |  |
| 177 | 1.3.3.3.4.1.4.2.1.1 | Interface Specification | 1d? | 2009-12-24 | 2009-12-25 | 174 | 222.89d | 0d | ME - TBD | 8h | 480 | PD |
| 178 | 1.3.3.3.4.1.4.2.1.2 | Mechanical Model | 5d? | 2009-12-25 | 2010-01-01 | 177 | 222.89d | 0d | ME - TBD | 40h | 2,400 | PD |
| 179 | 1.3.3.3.4.1.4.2.2 | **Focus Mechanism** | 42.45d? | 2010-01-01 | 2010-03-02 |  | 222.89d |  |  | 100h | 6,000 |  |
| 180 | 1.3.3.3.4.1.4.2.2.1 | Interface Specification | 2.5d? | 2010-01-01 | 2010-01-28 | 178 | 222.89d | 0d | ME - TBD | 20h | 1,200 | PD |
| 181 | 1.3.3.3.4.1.4.2.2.2 | Mechanical Model | 10d? | 2010-01-28 | 2010-03-02 | 180 | 222.89d | 0d | ME - TBD | 80h | 4,800 | PD |
| 182 | 1.3.3.3.4.1.4.2.3 | **Cooling Interface** | 4d? | 2010-03-02 | 2010-03-08 |  | 222.89d |  |  | 32h | 1,920 |  |
| 183 | 1.3.3.3.4.1.4.2.3.1 | Interface Specification | 1d? | 2010-03-02 | 2010-03-03 | 181 | 222.89d | 0d | ME - TBD | 8h | 480 | PD |
| 184 | 1.3.3.3.4.1.4.2.3.2 | Mechanical Model | 3d? | 2010-03-03 | 2010-03-08 | 183 | 222.89d | 0d | ME - TBD | 24h | 1,440 | PD |

| ID | WBS | Task | Duration | Start | Finish | Predecessors | Total slack | Free slack | Resources | Work | Cost | Text1 |
| --- | --- | --- | --- | --- | --- | --- | --- | --- | --- | --- | --- | --- |
| 185 | 1.3.3.3.4.2 | **Warm Assemblies** | 84.95d? | 2009-12-21 | 2010-04-19 |  | 263.2d |  |  | 280h | 16,880 |  |
| 186 | 1.3.3.3.4.2.1 | **Dewar Shell** | 84.95d? | 2009-12-21 | 2010-04-19 |  | 263.2d |  |  | 228h | 13,760 |  |
| 187 | 1.3.3.3.4.2.1.1 | Interface Specification | 2.78d? | 2009-12-22 | 2009-12-25 | 189 | 268.67d | 0d | ME - Bob Weber [90%] | 20h | 1,200 | PD |
| 188 | 1.3.3.3.4.2.1.2 | Mechanical Model | 22.22d? | 2009-12-25 | 2010-01-26 | 187 | 268.67d | 44.95d | ME - Bob Weber [90%] | 160h | 9,600 | PD |
| 189 | 1.3.3.3.4.2.1.3 | Window Specifications | 1d? | 2009-12-21 | 2009-12-22 | 159 | 268.67d | 0d | OE - Optical Engineer 2 | 8h | 560 | PD |
| 190 | 1.3.3.3.4.2.1.4 | External Connections | 2.5d? | 2010-04-15 | 2010-04-19 | 191 | 263.2d |  | ME - Bob Weber; Electronics Engineer | 40h | 2,400 | PD |
| 191 | 1.3.3.3.4.2.2 | Vacuum System Requirements | 1.5d? | 2010-04-13 | 2010-04-15 | 192 | 263.2d | 0d | ME - Bob Weber | 12h | 720 | PD |
| 192 | 1.3.3.3.4.2.3 | Cryogenic System Requirements | 5d? | 2010-04-06 | 2010-04-13 | 188, 155 | 263.2d | 0d | ME - Bob Weber | 40h | 2,400 | PD |
| 193 | 1.3.3.3.5 | **Electronics** | 11.25d? | 2010-03-02 | 2010-03-18 |  | 265.2d |  |  | 144h | 8,856 |  |
| 194 | 1.3.3.3.5.1 | **Motion Control** | 7.5d? | 2010-03-02 | 2010-03-12 |  | 265.2d |  |  | 84h | 5,256 |  |
| 195 | 1.3.3.3.5.1.1 | Requirements | 5d? | 2010-03-02 | 2010-03-09 | 165, 169, 181 | 265.2d | 0d | Electronics Engineer; Software Engineer; ME - Jim Bell; Sean Adkins | 64h | 4,056 | PD |
| 196 | 1.3.3.3.5.1.2 | Initial Design | 2.5d? | 2010-03-09 | 2010-03-12 | 195 | 265.2d | 0d | Electronics Engineer | 20h | 1,200 | PD |
| 197 | 1.3.3.3.5.2 | Power Control | 1.25d? | 2010-03-12 | 2010-03-15 | 196 | 265.2d | 0d | Electronics Engineer; Software Engineer | 20h | 1,200 | PD |
| 198 | 1.3.3.3.5.3 | Pressure Monitoring | 1.25d? | 2010-03-15 | 2010-03-16 | 197 | 265.2d | 0d | Electronics Engineer; Software Engineer | 20h | 1,200 | PD |
| 199 | 1.3.3.3.5.4 | Temperature Monitoring and Control | 1.25d? | 2010-03-16 | 2010-03-18 | 198 | 273d | 0d | Electronics Engineer; Software Engineer | 20h | 1,200 | PD |
| 200 | 1.3.3.3.6 | **Software** | 55.05d? | 2010-03-02 | 2010-05-18 |  | 242.15d |  |  | 184h | 9,620 |  |
| 201 | 1.3.3.3.6.1 | Detector Control | 3d? | 2010-04-09 | 2010-04-14 | 206 | 263.7d | 0d | Software Engineer | 24h | 1,440 | PD |
| 202 | 1.3.3.3.6.2 | Global Server | 3d? | 2010-04-14 | 2010-04-19 | 201 | 263.7d |  | Software Engineer | 24h | 1,440 | PD |
| 203 | 1.3.3.3.6.3 | Motion Control | 2.5d? | 2010-03-02 | 2010-03-05 | 165, 169, 181 | 243.39d | 0d | Software Engineer | 20h | 1,200 | PD |
| 204 | 1.3.3.3.6.4 | Power Control | 1d? | 2010-03-05 | 2010-03-08 | 203 | 243.39d | 0d | Software Engineer | 8h | 480 | PD |
| 205 | 1.3.3.3.6.5 | Pressure Monitoring | 1d? | 2010-03-08 | 2010-03-09 | 204 | 243.39d | 20.5d | Software Engineer | 8h | 480 | PD |
| 206 | 1.3.3.3.6.6 | Temperature Monitoring and Control | 2.5d? | 2010-04-06 | 2010-04-09 | 155, 205 | 222.89d | 0d | Software Engineer | 20h | 1,200 | PD |
| 207 | 1.3.3.3.6.7 | User Interface Requirements | 3.33d? | 2010-04-09 | 2010-04-14 | 206 | 222.89d | 0d | Software Engineer; Sean Adkins; Instrument Scientist | 40h | 2,180 | PD |
| 208 | 1.3.3.3.6.8 | Data Reduction Tools | 5d? | 2010-04-30 | 2010-05-18 | 70FS-2w | 242.15d |  | Software Engineer; Instrument Scientist | 40h | 1,200 | PD |

| ID | WBS | Task | Duration | Start | Finish | Predecessors | Total slack | Free slack | Resources | Work | Cost | Text1 |
| --- | --- | --- | --- | --- | --- | --- | --- | --- | --- | --- | --- | --- |
| 209 | 1.3.3.3.7 | **Interfaces** | 35.85d? | 2010-03-18 | 2010-05-06 |  | 250.1d |  |  | 80h | 5,232 |  |
| 210 | 1.3.3.3.7.1 | Mechanical Interface Requirements | 2.5d? | 2010-04-20 | 2010-04-22 | 155 | 250.1d | 0d | ME - TBD | 20h | 1,200 | PD |
| 211 | 1.3.3.3.7.2 | Electronic Interface Requirements | 2.5d? | 2010-03-18 | 2010-03-22 | 199 | 273d | 22.9d | Electronics Engineer | 20h | 1,200 | PD |
| 212 | 1.3.3.3.7.3 | Software Interface Requirements | 2.5d? | 2010-04-14 | 2010-04-19 | 207 | 253.41d | 3.31d | Software Engineer | 20h | 1,200 | PD |
| 213 | 1.3.3.3.7.4 | Interface Control Document | 3.06d? | 2010-04-22 | 2010-05-06 | 210, 211, 212 | 250.1d |  | Sean Adkins [80%]; ME - Jim Bell [90%] | 20h | 1,632 |  |
| 214 | 1.3.3.3.8 | **Accessories** | 13d? | 2010-04-20 | 2010-05-06 |  | 234.55d |  |  | 104h | 6,240 |  |
| 215 | 1.3.3.3.8.1 | **Alignment Tooling** | 6.5d? | 2010-04-28 | 2010-05-06 |  | 250.05d |  |  | 52h | 3,120 |  |
| 216 | 1.3.3.3.8.1.1 | Initial Specifications | 1.5d? | 2010-04-28 | 2010-04-29 | 155, 220 | 250.05d | 0d | ME - TBD | 12h | 720 | PD |
| 217 | 1.3.3.3.8.1.2 | Mechanical Model | 5d? | 2010-04-30 | 2010-05-06 | 216 | 250.05d |  | ME - TBD | 40h | 2,400 | PD |
| 218 | 1.3.3.3.8.2 | **Assembly Tooling** | 6.5d? | 2010-04-20 | 2010-04-28 |  | 234.55d |  |  | 52h | 3,120 |  |
| 219 | 1.3.3.3.8.2.1 | Initial Specifications | 1.5d? | 2010-04-20 | 2010-04-21 | 155 | 234.55d | 0d | ME - TBD | 12h | 720 | PD |
| 220 | 1.3.3.3.8.2.2 | Mechanical Model | 5d? | 2010-04-21 | 2010-04-28 | 219 | 234.55d | 0d | ME - TBD | 40h | 2,400 | PD |
